# 3GPP_Release-2000

Schedule from MS Project, 2000-01-01 to 2009-12-25, A marks actual dates.

## Calendars

- Standard: Mon-Fri 08:00-12:00, 13:00-17:00; Sat-Sun off.

## Resources

| Resource |
| --- |
| NP |
| N1 |
| N2 |
| N3 |
| N4 |
| N5 |
| TP |
| T1 |
| T2 |
| T3 |
| RP |
| R1 |
| R2 |
| R3 |
| R4 |
| SP |
| S1 |
| S2 |
| S3 |
| S4 |
| S5 |
| PCG |
| GP |
| No |
| CN4 |
| ? |
| WG G2 |
| G2 |
| G1 |
| G4 |
| G3 |
| All |
| Generic |
| MLST |
| G5 |
| S3, G2 |
| WG T2 |
| GP,G1 |
| G4,G5 |
| OMA |
| GP-G2 |
| Yes |
| GP, |
| N4, |
| GP, N1 |
| CT5 |
| C5 |
| C1 |
| C4 |
| C3 |
| C6 |
| G1, |
| 4 |
| ct |
| c,s,r |
| CT,RAN,SA |
| G2, |
| G1, G3 |
| CT6 |
| CT1 |
| CT1, CT3, CT4 |
| C1, C3, C4 |
| CP |
| R5 |
| C |
| Rel-8 |
| GP, G2 |
| R1,R4 |
| S5,C1 |
| CT,RAN,SA,GERAN |
| S3,C1,C4 |
| 5 |
| S1,C1,C3,C4,S5 |
| S1,C1,C3,C5 |
| S1,C1,C3,C4 |
| S1,S5 |
| S2,S3 |
| RAN,SA |
| RP,S5 |
| S2,CT |
| S1,CT |
| S1,CT,GERAN |
| S1,C5 |
| S3,CT |
| S4,CT |
| C1,SA |
| S1,S2 |
| S1,S4 |
| S2,S2,S3,CT |
| S2,S3,CT |
| S1,CT,GX |
| S1,S4,CT |
| S2,S2,S3,S5,CT |
| S1,S2,CT |
| S1,S2,S3,CT |
| S1,S2,S3,S5CT |
| S1,S2,S3,S5,CT |
| S2,S5,CT |
| S4,S3 |
| S1,C1 |
| CP,C1 |
| C1,C3 |
| C1,C3,C4 |
| S1,S5,CT |
| C4,C3 |
| CP,RAN,SA,GERAN |
| S1,S2,S3,S5,CP |
| S2,S3,CP |
| S2,CP |
| S1,CP,GX |
| S1,CP |
| S1,S4,CP |
| S1,S2,CP |
| S1,S2,S3,CP |
| S2,S5,CP |
| S3,CP |
| S1,S5,CP |
| RAN,SA,GERAN |
| S1,S2,S3,S5,C1,C3,C4,C6 |
| S2,S3,C1,C3,C4 |
| S2,C4 |
| S2,C1,C3,C4 |
| S2,C1,C4 |
| S2,S3,C1,C4 |
| S1,C1,C4,G2 |
| C1,C4 |
| S1,C1,C3 |
| S1,S4,C1,C3,C4 |
| S1,S2,S3,C1,C3,C4 |
| S2,S5,C3 |
| S1,S2,C1,C4 |
| S2,C1 |
| S2,C1,C3 |
| S3,C1,C3,C4 |
| S1,S5,C1,C3,C4 |
| S2,C3,C4 |
| C3,C1 |
| R2,R4 |
| R2,R5 |
| RP,R5 |
| RP,S5,R5 |
| R1,R5 |
| S1,C1,R5 |
| S1,C1,S4,R5 |
| GERAN |
| G3new |
| G1, G3new |
| C4,C1,C3 |
| R1.R4 |
| R1, R4 |
| R2,R3 |
| C3,C4 |
| S4,C3 |
| S4,C3,C1,C4 |
| S1,S2,C1 |
| S1,S2<C1,C3,C4 |
| S1,S2,C1,C3,C4 |
| S5,C1,C3,C4 |
| GP,C4 |
| C4,C1 |
| S2,S1 |
| RP,SP,GP |
| RP,SP,CP,GP |
| CP,GP,RP,SP |
| GP,C4,S4 |
| S1,C1,C4 |
| S1,S2,C3,C1 |
| R2,R4,R3 |
| CP,GP, RP,SP |
| S2,S1,C1,S5 |
| S2,S1,C1 |
| S1,C1,S4 |
| S1,S2,GP,C4,R2 |
| S1,GP,R2 |
| S1,C6 |
| S1,S2,C1,S4 |
| S2,S3,S5,C1,C3,C4 |
| S2,S5,C1 |
| S2,S3,S5 |
| CP,GP, RP,SP,TP |
| S2,C4,C1 |
| S1,C1,C4,S3 |
| S2,S5 |
| S3,C1 |
| S3,C4 |
| S1,C4 |
| S2,S5,C3,C1 |
| S2,S1,S5,C1,C4 |
| S1,R1,C3 |
| S1,C1,R2 |
| S2,S1,C1,C4 |
| S1,C1,C6 |
| GP,S4,C4,C1,C3 |
| C3,C1,C4 |

## Schedule

| ID | WBS | Task | Type | Duration | Start | Finish | Complete | Remaining | Baseline start | Baseline finish | Baseline duration | Total slack | Constraint | Resources | Work | Actual work | Text9 | Text6 | Text1 | Text4 | Text5 | Text8 |
| --- | --- | --- | --- | --- | --- | --- | --- | --- | --- | --- | --- | --- | --- | --- | --- | --- | --- | --- | --- | --- | --- | --- |
| 1 | 1 | Version 2008 Sep 03 |  | 1d | 2000-01-03 | 2000-01-03 |  |  | 2000-01-03 | 2000-01-03 | 1d | 2604d |  |  |  |  | 2044 |  |  |  |  |  |
| 2 | 2 | "CTRL + a" to display all the 3GPP fields |  | 1d | 2000-01-03 | 2000-01-03 |  |  | 2000-01-03 | 2000-01-03 | 1d | 2604d | start no earlier than 2000-01-01 |  |  |  | 1462 |  |  |  |  |  |
| 4 | 3 | Gantt: dark blue=done; light blue=to be done; grey: previous values; black=summary |  | 1d? | 2000-01-03 | 2000-01-03 |  |  | 2000-01-03 | 2000-01-03 | 1d? | 2604d | start no earlier than 2000-01-01 |  |  |  |  |  |  |  |  |  |
| 6 | 4 | Release 9 Features | milestone | 0d? | 2000-01-01 | 2000-01-01 |  |  | 2000-01-01 | 2000-01-01 | 0d? | 2605d |  | CP,GP,RP,SP |  |  |  | Rel-9 |  |  |  |  |
| 7 | 5 | Services Alignment and Migration |  | 467d? | 2006-12-06 A | 2008-09-18 A | 100% |  | 2006-12-06 | 2008-09-18 | 467d? |  | finish no earlier than 2008-12-11 | S1 | 3736h | 3736h |  | Rel-9 | ServAl | China Mobile | fenglingjuan@chinamobile.com | Alain |
| 8 | 6 | **Registration in Densely-populated area (RED)** |  | 391d? | 2007-03-12 A | 2008-09-08 | 51% | 192.42d? | 2007-03-12 | 2008-09-08 | 391d? | 339d |  | S1,S2 | 5160h | 1064h |  | Rel-9 | RED | NTT DoCoMo | takakurat@s1.nttdocomo.co.jp | Alain |
| 9 | 6.1 | Stage 1 for RED |  | 4d? | 2007-03-12 A | 2007-03-15 A | 100% |  | 2007-03-12 | 2007-03-15 | 4d? |  | start no earlier than 2007-03-12 | S1 | 32h | 32h |  | Rel-9 | RED-St1 | NTT DoCoMo | takakurat@s1.nttdocomo.co.jp | Alain |
| 10 | 6.2 | Stage 2 for RED |  | 250d? | 2007-09-25 A | 2008-09-08 | 50% | 125d? | 2007-09-25 | 2008-09-08 | 250d? | 339d | finish no earlier than 2008-09-08 | S2 | 2000h | 1000h |  | Rel-9 | RED-St2 | NTT DoCoMo | tanakai@nttdocomo.co.jp | Maurice |
| 11 | 7 | End-User Identity |  | 334d? | 2007-09-03 A | 2008-12-11 | 5% | 316.8d? | 2007-09-03 | 2008-12-11 | 334d? | 271d | finish no earlier than 2008-12-11 | S1 | 2672h | 137.6h |  | Rel-9 | EUI | NSN | Joerg.Swetina@Siemens.com | Alain |
| 12 | 8 | Customized Ringing Signal |  | 266d? | 2007-12-06 A | 2008-12-11 | 95% | 13.3d? | 2007-12-06 | 2008-12-11 | 266d? | 271d | finish no earlier than 2008-12-11 | S1 | 2128h | 2021.6h |  | Rel-9 | CRS | China Mobile | zhengjianping@chinamobile.com | Alain |
| 13 | 9 | **Public Warning System** |  | 266d? | 2007-12-06 | 2008-12-11 |  |  | 2007-12-06 | 2008-12-11 | 266d? | 271d |  | S1 | 4256h |  |  | Rel-9 | PWS | Telecom Italia |  | Alain |
| 14 | 9.1 | Stage 1 for PWS |  | 266d? | 2007-12-06 | 2008-12-11 |  |  | 2007-12-06 | 2008-12-11 | 266d? | 271d | finish no earlier than 2008-12-11 | S1 | 2128h |  |  | Rel-9 | PWS-S1 | Telecom Italia |  | Alain |
| 15 | 10 | Network Selection for non-3GPP Access |  | 266d? | 2007-12-06 A | 2008-12-11 | 40% | 159.6d? | 2007-12-06 | 2008-12-11 | 266d? | 271d | finish no earlier than 2008-12-11 | S1 | 2128h | 851.2h |  | Rel-9 | N3GTONSP | Telecom Italia |  | Alain |
| 16 | 11 | **Enhancements to Multimedia Priority Service** |  | 584d? | 2006-03-13 A | 2008-06-05 A | 100% |  | 2006-03-13 | 2008-06-05 | 584d? |  |  | S1 | 4672h | 4672h |  | Rel-9 | ePRIOR | Telcordia | jgarraha@telcordia.com | Alain |
| 17 | 11.1 | Service Requirements for PRIOR_Ph2 |  | 584d? | 2006-03-13 A | 2008-06-05 A | 100% |  | 2006-03-13 | 2008-06-05 | 584d? |  | start no earlier than 2006-03-12 | S1 | 4672h | 4672h |  | Rel-9 | ePRIOR | Telcordia | jgarraha@telcordia.com | Alain |
| 18 | 12 | **Support of Personal Area Networks and Enhancements to Personal Network Management** |  | 0d? | 2008-06-05 A | 2008-06-05 A | 100% |  | 2008-06-05 | 2008-06-05 | 0d? |  |  | S1 |  |  |  | Rel-9 | PAN_EPNM | Vodafone | armin.toepfer@vodafone.com | Alain |
| 19 | 12.1 | Stage 1 for PAN_EPNM | milestone | 0d? | 2008-06-05 A | 2008-06-05 A | 100% |  | 2008-06-05 | 2008-06-05 | 0d? |  | finish no earlier than 2008-06-05 | S1 |  |  |  | Rel-9 | PAN_EPNM | Vodafone | armin.toepfer@vodafone.com | Alain |
| 20 | 13 | **Multi-Media Telephony Service enhancements** |  | 201d? | 2008-06-05 | 2009-03-12 |  |  | 2008-06-05 | 2009-03-12 | 201d? | 206d |  | S1 | 3216h |  |  | Rel-9 | eMMTel | France Telecom | Philippe Lottin | Alain |
| 21 | 13.1 | Stage 1 for eMMTel |  | 201d? | 2008-06-05 | 2009-03-12 |  |  | 2008-06-05 | 2009-03-12 | 201d? | 206d | start no earlier than 2008-06-05 | S1 | 1608h |  |  | Rel-9 | eMMTel | France Telecom | Philippe Lottin | Alain |
| 22 | 14 | **User Data Convergence** |  | 201d? | 2008-06-05 A | 2009-03-12 | 30% | 140.7d? | 2008-06-05 | 2009-03-12 | 201d? | 206d |  | S1 | 3216h | 964.8h |  | Rel-9 | UDC | China Mobile | Lan Sizhong (lansizhong@chinamobile.com | Alain |
| 23 | 14.1 | Stage 1 for UDC |  | 201d? | 2008-06-05 A | 2009-03-12 | 30% | 140.7d? | 2008-06-05 | 2009-03-12 | 201d? | 206d | start no earlier than 2008-06-05 | S1 | 1608h | 482.4h |  | Rel-9 | UDC | China Mobile | Lan Sizhong (lansizhong@chinamobile.com | Alain |
| 24 | 15 | **Enhanced Home NodeB / eNodeB** |  | 136d? | 2008-06-05 A | 2008-12-11 | 30% | 95.2d? | 2008-06-05 | 2008-12-11 | 136d? | 271d |  | S1 | 2176h | 652.8h |  | Rel-9 | EHNB | T-Mobile | Michael Kurz | Alain |
| 25 | 15.1 | Stage 1 for EHNB |  | 136d? | 2008-06-05 A | 2008-12-11 | 30% | 95.2d? | 2008-06-05 | 2008-12-11 | 136d? | 271d | finish no earlier than 2008-12-11 | S1 | 1088h | 326.4h |  | Rel-9 | EHNB | T-Mobile | Michael Kurz | Alain |
| 26 | 16 | Support for IMS Emergency Calls over GPRS and EPS |  | 171d? | 2008-01-14 A | 2008-09-08 | 25% | 128.25d? | 2008-01-14 | 2008-09-08 | 171d? | 339d | finish no earlier than 2008-09-08 | S2 | 1368h | 342h |  | Rel-9 | IMS_EMER_GPRS_EPS | Alcatel-Lucent | Deborah Barclay | Maurice |
| 27 | 17 | Harmonization of Gq'/Rx for Common IMS |  | 171d? | 2008-01-14 A | 2008-09-08 | 20% | 136.8d? | 2008-01-14 | 2008-09-08 | 171d? | 339d | finish no earlier than 2008-09-08 | S2 | 1368h | 273.6h |  | Rel-9 | IMS_Comm_GqRx_Harm | Alcatel-Lucent | geoffrey.cristallo@alcatel-lucent.be | Maurice |

Notes:
- 7: Triggered by Study UID_370086 (FSServAl). SA#39 moved to Rel-9. SA#41 completed Stage 1 / Text3: 22.182
- 8: SA#35 Stage 1 completed. SA#40 SA2 moved to Rel-9.
- 9: SA#35 completed / Text3: 22.101
- 10: SP#37 WID approved. SA#40 moved to Rel-9. / Text3: 23.880
- 11: SA#38 moved to Rel-9 / Text3: 22.101
- 12: SA#38 WID approved. SA#39 moved to Rel-9 / Text3: 22.183
- 13: Larger scope than Rel-8 Feature UID_370051 (ETWS). Triggered by Study UID_320025 (PWS-SI). SA#39 moved to Rel-9
- 14: SA#39 moved to Rel-9
- 15: Triggered by Study UID_340033 (N3GtoNSP). SA#38 WID approved. SA#39 exception granted to Jun 2008. S1#40: 06/08=>12/08. SA#40 moved to Rel-9
- 16: SA#40 Stage 1 completed.
- 17: SA#39 WID approved. SA#40 completed / Text3: 22.153
- 18: SA#40 WID approved & Stage 1 completed / Text3: 22.259
- 19: SA#40 WID approved & Stage 1 completed / Text3: 22.259
- 20: SA#40 WID approved. / Text3: 22.173
- 21: SA#40 WID approved. / Text3: 22.173
- 22: Triggered by SA5 Study Common Profile Storage (CPS) UID_390038 (OAM8-Studies) TR 32.808. SA#40 WID approved.
- 23: Triggered by SA5 Study Common Profile Storage (CPS) UID_390038 (OAM8-Studies) TR 32.808. SA#40 WID approved. / Text3: 22.985, 22.101
- 24: SA#40 WID approved. / Text3: 22.xxx, 22.011
- 25: SA#40 WID approved. / Text3: 22.xxx, 22.011
- 26: SA#38 WID approved. Moved to Rel-9. SA#40 updated WID SP-070820=>SP-080352 / Text3: 23.8xx, 22.101, 23.060, 23.167, 23.228, 23.271, 23.203, 23.401, 23.402, 23.221
- 27: WID approved SA#38. per OPs & ETSI GA 39. This is a joint effort of SA2 and TISPAN2. SA#40 moved to Rel-9. / Text3: 23.8xx, 23.203

| ID | WBS | Task | Type | Duration | Start | Finish | Complete | Remaining | Baseline start | Baseline finish | Baseline duration | Total slack | Constraint | Resources | Work | Actual work | Text1 | Text3 | Text4 | Text5 | Text6 | Text8 | Text12 |
| --- | --- | --- | --- | --- | --- | --- | --- | --- | --- | --- | --- | --- | --- | --- | --- | --- | --- | --- | --- | --- | --- | --- | --- |
| 28 | 18 | **LCS Control Plane Solution for EPS** |  | 266d? | 2008-06-05 | 2009-06-11 |  |  | 2008-06-05 | 2009-06-11 | 266d? | 141d |  | S2 | 4256h |  | LCS_CPS_EPS | 23.8xx, 23.271, 23.401, 23.402 | Polaris Wireless | Robert Gross | Rel-9 | Maurice |  |
| 29 | 18.1 | Stage 2 for LCS_CPS_EPS |  | 266d? | 2008-06-05 | 2009-06-11 |  |  | 2008-06-05 | 2009-06-11 | 266d? | 141d | finish no earlier than 2009-06-11 | S2 | 2128h |  | LCS_CPS_EPS | 23.8xx, 23.271, 23.401, 23.402 | Polaris Wireless | Robert Gross | Rel-9 | Maurice |  |
| 30 | 19 | **MBMS support in EPS** |  | 266d? | 2008-06-05 | 2009-06-11 |  |  | 2008-06-05 | 2009-06-11 | 266d? | 141d |  | S2 | 4256h |  | MBMS_EPS |  | China Mobile | Liu Hong (liuhongyfw@chinamobile.com) | Rel-9 | Maurice |  |
| 31 | 19.1 | Stage 2 for MBMS_EPS |  | 266d? | 2008-06-05 | 2009-06-11 |  |  | 2008-06-05 | 2009-06-11 | 266d? | 141d | finish no earlier than 2009-06-11 | S2 | 2128h |  | MBMS_EPS | 23.246 | China Mobile | Liu Hong (liuhongyfw@chinamobile.com) | Rel-9 | Maurice |  |
| 32 | 20 | **Deleted - SAES Enhancements (non RAN aspects)** |  | 381d? | 2007-06-25 A | 2008-12-08 A | 100% |  | 2007-06-25 | 2008-12-08 | 381d? |  |  | S2 | 11664h | 11664h | SAES_Ph2 |  | NSN |  | Rel-9 | Maurice | SP-39 |
| 33 | 20.1 | Deleted - Functions and procedures for SAE to support LTE MBMS |  | 381d? | 2007-06-25 A | 2008-12-08 A | 100% |  | 2007-06-25 | 2008-12-08 | 381d? |  | finish no earlier than 2008-12-08 | S2 | 3048h | 3048h | SAES_Ph2 |  |  |  | Rel-9 | Maurice | SP-39 |
| 34 | 20.2 | Deleted - CS over EPS |  | 194d? | 2008-03-12 A | 2008-12-08 A | 100% |  | 2008-03-12 | 2008-12-08 | 194d? |  | finish no earlier than 2008-12-08 | S2 | 1552h | 1552h | SAES_Ph2 |  |  |  | Rel-9 | Maurice | SP-39 |
| 35 | 20.3 | **Deleted - SAE for generic support for non-3GPP accesses** |  | 251d? | 2007-06-25 A | 2008-06-09 A | 100% |  | 2007-06-25 | 2008-06-09 | 251d? |  |  | S2 | 4016h | 4016h | SAES_Ph2 |  |  |  | Rel-9 | Maurice | SP-39 |
| 36 | 20.3.1 | Deleted - Single Radio Aspects of SAE for Optimized Handover with WiMAX |  | 251d? | 2007-06-25 A | 2008-06-09 A | 100% |  | 2007-06-25 | 2008-06-09 | 251d? |  | finish no earlier than 2008-06-09 | S2 | 2008h | 2008h | SAES_Ph2 |  |  |  | Rel-9 | Maurice | SP-39 |
| 37 | 21 | Deleted - Support of WiMAX - LTE Mobility |  | 406d? | 2008-06-06 A | 2009-12-25 A | 100% |  | 2008-06-06 | 2009-12-25 | 406d? |  | start no earlier than 2008-06-06 | R2 | 3248h | 3248h | WiMAX_LTE_Mobility | 36.306, 36.331, 36.413, 36.300, 36.214, 36.133, 36.304 | Samsung |  | Rel-9 | Joern | SP-39 |
| 38 | 22 | Deleted - Support of WiMAX - UMTS Mobility |  | 406d? | 2008-06-06 A | 2009-12-25 A | 100% |  | 2008-06-06 | 2009-12-25 | 406d? |  | start no earlier than 2008-06-06 | R2 | 3248h | 3248h | WiMAX_UMTS_Mobility | 25.306, 25.331, 25.413 | Intel |  | Rel-9 | Joern | SP-39 |
| 39 | 23 | Release 9 Feasibility Studies | milestone | 0d? | 2008-03-20 | 2008-03-20 |  |  | 2008-03-20 | 2008-03-20 | 0d? | 461d | finish no earlier than 2008-03-20 | CP,GP,RP,SP |  |  |  |  |  |  | Rel-9 |  |  |
| 40 | 24 | **Study on enhanced voice service requirements for the EPS** |  | 464d? | 2007-09-03 A | 2009-06-11 | 23% | 358d? | 2007-09-03 | 2009-06-11 | 464d? | 141d |  | S1,S4 | 9576h | 2187.59h | FS_EV_EPS | 22.813 | Orange | tim.haysom@orange-ftgroup.com | Rel-9 | Alain |  |
| 41 | 24.1 | Use cases definition and service and system requirements |  | 269d? | 2007-09-03 A | 2008-09-11 | 45% | 147.95d? | 2007-09-03 | 2008-09-11 | 269d? | 336d | finish no earlier than 2008-09-11 | S1 | 2152h | 968.4h | FS_EV_EPS-S1 | 22.813 | Orange | tim.haysom@orange-ftgroup.com | Rel-9 | Alain |  |
| 42 | 24.2 | Codec specific part of FSEV_EPS |  | 464d? | 2007-09-03 A | 2009-06-11 | 10% | 417.6d? | 2007-09-03 | 2009-06-11 | 464d? | 141d | finish no earlier than 2009-06-11 | S4 | 3712h | 371.2h | FS_EV_EPS-S4 |  | Orange | tim.haysom@orange-ftgroup.com | Rel-9 | Paolo |  |
| 43 | 25 | Study on advanced requirements for IP interconnect |  | 333d? | 2007-12-04 A | 2009-03-12 | 8% | 306.36d? | 2007-12-04 | 2009-03-12 | 333d? | 206d | finish no earlier than 2009-03-12 | S1 | 2664h | 213.12h | FS_IPXS | 22.893 | Telefonica O2 | chris.friel@O2.com | Rel-9 | Alain |  |
| 44 | 26 | Study on Service Specific Access Control in EPS |  | 201d? | 2008-06-05 | 2009-03-12 |  |  | 2008-06-05 | 2009-03-12 | 201d? | 206d | start no earlier than 2008-06-05 | S1 | 1608h |  | FS_SSAC_EPS | 22.986 | NTT DoCoMo | Frederic Thepot (thepot@docomolab-euro.com) | Rel-9 | Alain |  |
| 45 | 27 | Study on Unauthenticated PS Emergency Calls |  | 201d? | 2008-06-05 A | 2009-03-12 | 5% | 190.95d? | 2008-06-05 | 2009-03-12 | 201d? | 206d | start no earlier than 2008-06-05 | S1 | 1608h | 80.4h | FS_UAPSEC | 22.984 | NSN | Juergen Merkel | Rel-9 | Alain |  |
| 46 | 28 | Study on CS Domain Services over EPS access |  | 359d? | 2007-04-25 A | 2008-09-08 | 70% | 107.7d? | 2007-04-25 | 2008-09-08 | 359d? | 339d | finish no earlier than 2008-09-08 | S2 | 2872h | 2010.4h | FS_CSoPS | 23.879 | T-Mobile | Sabine.Demel@T-Mobile.at | Rel-9 | Maurice |  |
| 47 | 29 | Study on Extended Support of IMS Emergency Calls |  | 319d? | 2007-09-24 A | 2008-12-11 | 15% | 271d? | 2007-09-24 | 2008-12-11 | 319d? | 271d | finish no earlier than 2008-12-11 | S2 | 2552h | 384h | FS_IMS-eCall | 23.868 | Qualcomm |  | Rel-9 | Maurice |  |
| 48 | 30 | Study on System enhancements for the use of IMS services in local breakout and optimal routing of media |  | 314d? | 2007-10-01 A | 2008-12-11 | 20% | 251d? | 2007-10-01 | 2008-12-11 | 314d? | 271d | finish no earlier than 2008-12-11 | S2 | 2512h | 504h | FS_IMS_LBO_ORM | 23.894 | Telecom Italia | mario.madella@telecomitalia.it, victor.kueh@bt.com | Rel-9 | Maurice |  |
| 49 | 31 | Study on Architecture of IMS based Customized Alerting Tone (CAT) |  | 200d? | 2007-12-04 A | 2008-09-08 | 70% | 60d? | 2007-12-04 | 2008-09-08 | 200d? | 339d | finish no earlier than 2008-09-08 | S2 | 1600h | 1120h | FS_CAT-St2 | 23.872 | China Mobile | wangjing@chinamobilecom | Rel-9 | Maurice |  |
| 50 | 32 | Study on Intra Domain Connection of RAN Nodes to Multiple CN Nodes |  | 262d? | 2008-03-12 | 2009-03-12 |  |  | 2008-03-12 | 2009-03-12 | 262d? | 206d | finish no earlier than 2009-03-12 | S2 | 2096h |  | FS_IDC | 23.8xy | China Mobile | LIU HONG (liuhongyfw@chinamobile.com) | Rel-9 | Maurice |  |
| 51 | 33 | Study on Remote management of USIM application on M2M Equipment |  | 322d? | 2007-09-19 A | 2008-12-11 | 60% | 128.8d? | 2007-09-19 | 2008-12-11 | 322d? | 271d | finish no earlier than 2008-12-11 | S3 | 2576h | 1545.6h | FS_UM2M | 33.812 | Ericsson | vesa.lehtovirta@ericsson.com | Rel-9 | Dionisio |  |
| 52 | 34 | Study on UTRAN key management enhancements |  | 256d? | 2007-12-20 A | 2008-12-11 | 20% | 204.8d? | 2007-12-20 | 2008-12-11 | 256d? | 271d | finish no earlier than 2008-12-11 | S3 | 2048h | 409.6h | FS_UKM | TR | Ericsson |  | Rel-9 | Dionisio |  |
| 53 | 35 | Study on Home (e)NodeB Security |  | 256d? | 2007-12-20 A | 2008-12-11 | 40% | 153.6d? | 2007-12-20 | 2008-12-11 | 256d? | 271d | finish no earlier than 2008-12-11 | S3 | 2048h | 819.2h | FS_HNB_Sec | TR | Huawei | yangyanmei@huawei.com | Rel-9 | Dionisio |  |
| 54 | 36 | Study on Service Oriented Architecture (SOA) for IRP |  | 201d? | 2008-06-05 A | 2009-03-12 | 10% | 180.9d? | 2008-06-05 | 2009-03-12 | 201d? | 206d | finish no earlier than 2009-03-12 | S5 | 1608h | 160.8h | FS_OAM_SOA_IRP | 32.824 | Ericsson | TSE, Edwin | Rel-9 | Dionisio |  |
| 55 | 37 | Study on LTE-Advanced |  | 326d? | 2008-03-07 A | 2009-09-11 | 80% | 65.2d? | 2008-03-07 | 2009-09-11 | 326d? | 75d | finish no earlier than 2009-09-11 | R1 | 2608h | 2086.4h | FS_RAN_LTEA | 36.913 | NTT DoCoMo | Takehiro Nakamura | Rel-9 | Patrick |  |
| 56 | 38 | Release 8 Features | milestone | 0d? | 2000-01-03 | 2000-01-03 |  |  | 2000-01-03 | 2000-01-03 | 0d? | 2604d | start no earlier than 2000-01-03 | CP,GP,RP,SP |  |  |  |  |  |  | Rel-8 |  |  |

Notes:
- 28: SA#40 WID approved. Triggered by Study UID_380068 (FS_LCS_EPS)
- 29: SA#40 WID approved. Triggered by Study UID_380068 (FS_LCS_EPS)
- 30: SA#40 WID approved.
- 31: SA#40 WID approved.
- 32: SA#39 created to host Rel-9 Wis. BUT no agreed WID
- 33: SA#39 SAE functionality moved to Rel-9. WID returned to SA2 for re-consideration & remove MBMS for EPS from Rel 8
- 34: SA#39 SAE functionality moved to Rel-9. BUT no agreed WID
- 35: SA#39 SAE functionality moved to Rel-9. BUT no agreed WID
- 36: SA#39 SAE functionality moved to Rel-9. BUT no agreed WID
- 37: RAN#39: No agreed WID
- 38: RAN#39: No agreed WID
- 40: Moved to Rel-9
- 41: Moved to Re-9. SA#40 03/08=>09/08
- 42: Moved to Rel-9
- 43: SA#38 SID approved.
- 44: SA#40 SID approved.
- 45: SA#40 SID approved.
- 46: Moved to Rel-9
- 47: Moved to Rel-9
- 48: SA#39 Revised SID approved. Moved to Rel-9
- 50: SA#39: SID approved. Linked to 23.236
- 51: Triggered by SA1 Study UID_7029 (M2M) TR 22.868. SA#37: WID SP-070635=>SP-070702
- 54: SA#40 SID approved
- 55: SID in RP-080137. Status Report in RP-080293, RAN#40 TR approved ?! Target completion Sep 2009

| ID | WBS | Task | Duration | Start | Finish | Complete | Remaining | Baseline start | Baseline finish | Baseline duration | Total slack | Constraint | Resources | Work | Actual work | Text1 | Text4 | Text5 | Text6 | Text8 |
| --- | --- | --- | --- | --- | --- | --- | --- | --- | --- | --- | --- | --- | --- | --- | --- | --- | --- | --- | --- | --- |
| 57 | 39 | **3GPP System Architecture Evolution Specification - Evolved Packet System (non RAN aspects)** | 762d? | 2006-04-12 A | 2009-03-12 | 72% | 215.44d? | 2006-04-12 | 2009-03-12 | 762d? | 206d |  | S1,S2,S3,S5,C1,C3,C4,C6 | 228420h | 146683h | SAES | T-Mobile | michael.kurz@t-mobile.at | Rel-8 | Maurice |
| 58 | 39.1 | Requirements for evolution of the 3GPP system architecture | 395d? | 2006-06-08 A | 2007-12-12 A | 100% |  | 2006-06-08 | 2007-12-12 | 395d? |  | finish no earlier than 2007-11-30 | S1 | 3160h | 3160h | AIPN-SAE | T-Mobile | michael.kurz@t-mobile.at | Rel-8 | Alain |
| 59 | 39.2 | **High level and common (for all accesses) functions** | 509d? | 2007-01-02 A | 2008-12-15 | 67% | 169.64d? | 2007-01-02 | 2008-12-15 | 509d? | 270d |  | S2,S3,C1,C3,C4 | 38256h | 22983.2h | EPS-ComF | NSN |  | Rel-8 | Maurice |
| 60 | 39.2.1 | Stage 2 for High level functions | 370d? | 2007-01-02 A | 2008-06-02 A | 100% |  | 2007-01-02 | 2008-06-02 | 370d? |  | finish no earlier than 2008-06-02 | S2 | 2960h | 2960h | SAES-SA-HLF | Motorola | Irfan Ali | Rel-8 | Maurice |
| 61 | 39.2.2 | Stage 2 Security Architecture | 197d? | 2008-03-12 A | 2008-12-11 | 90% | 19.7d? | 2008-03-12 | 2008-12-11 | 197d? | 271d | finish no earlier than 2008-12-11 | S3 | 1576h | 1418.4h | SAES | NSN | marc.blommaert.ext@nsn.com | Rel-8 | Dionisio |
| 62 | 39.2.3 | Stage 3 (CT1) for SAE impact on services, network functions and capabilities | 485d? | 2007-02-05 A | 2008-12-15 | 55% | 218.25d? | 2007-02-05 | 2008-12-15 | 485d? | 270d | finish no earlier than 2008-12-15 | C1 | 3880h | 2134h | SAES | NSN | robert.zaus@nsn.com | Rel-8 | Frederic |
| 63 | 39.2.4 | Stage 3 SAE impact on existing capabilities | 485d? | 2007-02-05 | 2008-12-12 |  |  | 2007-02-05 | 2008-12-12 | 485d? | 270d | finish no earlier than 2008-12-12 | C3 | 3880h |  | SAES | Huawei | weiwh@huawei.com | Rel-8 | Gwiho |
| 64 | 39.2.5 | Stage 3 (CT4) of SAE impact on existing capabilities | 480d? | 2007-02-05 A | 2008-12-05 | 85% | 72d? | 2007-02-05 | 2008-12-05 | 480d? | 275d | finish no earlier than 2008-12-05 | C4 | 3840h | 3264h | SAES | Huawei | shahab.lavasani@huawei.com | Rel-8 | Kimmo |
| 65 | 39.2.6 | Stage 2/3 for Network selection procedures | 485d? | 2007-02-05 A | 2008-12-15 | 80% | 97d? | 2007-02-05 | 2008-12-15 | 485d? | 270d | finish no earlier than 2008-12-15 | C1 | 3880h | 3104h | SAES | NSN | robert.zaus@nsn.com | Rel-8 | Frederic |
| 66 | 39.2.7 | Stage 3 EPC interworking with external PDNs (SGi) | 485d? | 2007-02-05 A | 2008-12-12 | 60% | 194d? | 2007-02-05 | 2008-12-12 | 485d? | 270d | finish no earlier than 2008-12-12 | C3 | 3880h | 2328h | SAES-St3-intwk | Huawei | weiwh@huawei.com | Rel-8 | Gwiho |
| 67 | 39.2.8 | Stage 3 PCC within SAE | 485d? | 2007-02-05 A | 2008-12-12 | 60% | 194d? | 2007-02-05 | 2008-12-12 | 485d? | 270d | finish no earlier than 2008-12-12 | C3 | 3880h | 2328h | SAES-St3-PCC | Ericsson | j.javier.pastor@ericsson.com | Rel-8 | Gwiho |
| 68 | 39.2.9 | Stage 3 for SAE / LTE identities | 480d? | 2007-02-05 A | 2008-12-05 | 80% | 96d? | 2007-02-05 | 2008-12-05 | 480d? | 275d | finish no earlier than 2008-12-05 | C4 | 3840h | 3072h | SAES | Huawei | shahab.lavasani@huawei.com | Rel-8 | Kimmo |
| 69 | 39.2.10 | Unified guidelines for Diameter usage within 3GPP | 321d? | 2007-09-21 A | 2008-12-12 | 85% | 48.15d? | 2007-09-21 | 2008-12-12 | 321d? | 270d | finish no earlier than 2008-12-12 | C3 | 2568h | 2182.8h | SAES-DIAM | Huawei | Javier Gonzalez Gallego | Rel-8 | Gwiho |
| 70 | 39.3 | **SAE for LTE access** | 509d? | 2007-01-02 A | 2008-12-15 | 72% | 142.64d? | 2007-01-02 | 2008-12-15 | 509d? | 270d |  | S2,C1,C3,C4 | 52824h | 30630h | SAES-LTE | Motorola | Irfan.Ali@motorola.com | Rel-8 | Maurice |
| 71 | 39.3.1 | CT4 Stage 3 for protocol between EPCs | 480d? | 2007-02-05 A | 2008-12-05 | 80% | 96d? | 2007-02-05 | 2008-12-05 | 480d? | 275d | finish no earlier than 2008-12-05 | C4 | 3840h | 3072h | SAES | Huawei | shahab.lavasani@huawei.com | Rel-8 | Kimmo |
| 72 | 7.2.2.1 | **SAES-SA-FP_LTE with GTP variant** | 504d? | 2007-01-02 A | 2008-12-05 | 86% | 70.9d? | 2007-01-02 | 2008-12-05 | 504d? | 275d |  | S2,C4 | 10856h | 6440h | SAES-SA-FP_LTE-GTP | Motorola |  | Rel-8 | Maurice |
| 73 | 39.3.2.1 | Stage 2 for SAES-SA-FP_LTE with GTP variant | 373d? | 2007-01-02 A | 2008-06-05 A | 100% |  | 2007-01-02 | 2008-06-05 | 373d? |  | finish no earlier than 2008-06-02 | S2 | 2984h | 2984h | SAES-SA-FP_LTE-GTP-St2 | NSN |  | Rel-8 | Maurice |
| 74 | 39.3.2.2 | CT4 Stage 3 for GTP v2 protocol | 480d? | 2007-02-05 A | 2008-12-05 | 75% | 120d? | 2007-02-05 | 2008-12-05 | 480d? | 275d | finish no earlier than 2008-12-05 | C4 | 3840h | 2880h | SAES | Huawei | shahab.lavasani@huawei.com | Rel-8 | Kimmo |
| 75 | 7.2.2.2 | **SAES-SA-FP_LTE with PMIP variant** | 504d? | 2007-01-02 A | 2008-12-05 | 84% | 81.67d? | 2007-01-02 | 2008-12-05 | 504d? | 275d |  | S2,C4 | 14696h | 9512h | SAES-SA-FP_LTE-IETF | NSN |  | Rel-8 | Maurice |
| 76 | 39.3.3.1 | Stage 2 for SAES-SA-FP_LTE with PMIP variant | 373d? | 2007-01-02 A | 2008-06-05 A | 100% |  | 2007-01-02 | 2008-06-05 | 373d? |  | finish no earlier than 2008-06-02 | S2 | 2984h | 2984h | SAES-SA-FP_LTE-IETF-St2 | NSN |  | Rel-8 | Maurice |
| 77 | 39.3.3.2 | CT4 Stage 3 for PMIP protocol within EPC | 480d? | 2007-02-05 A | 2008-12-05 | 80% | 96d? | 2007-02-05 | 2008-12-05 | 480d? | 275d | finish no earlier than 2008-12-05 | C4 | 3840h | 3072h | SAES | Huawei | shahab.lavasani@huawei.com | Rel-8 | Kimmo |
| 78 | 39.3.3.3 | Mobile IPv4 (MIPv4) based Mobility protocols | 480d? | 2007-02-05 A | 2008-12-05 | 75% | 120d? | 2007-02-05 | 2008-12-05 | 480d? | 275d | finish no earlier than 2008-12-05 | C4 | 3840h | 2880h | SAES | Motorola | Lewis Milton | Rel-8 | Kimmo |
| 79 | 39.3.4 | Stage 3 for UE NAS mobility procedures in idle and active mode | 485d? | 2007-02-05 A | 2008-12-15 | 75% | 121.25d? | 2007-02-05 | 2008-12-15 | 485d? | 270d | finish no earlier than 2008-12-15 | C1 | 3880h | 2910h | SAES | NSN | robert.zaus@nsn.com | Rel-8 | Frederic |
| 80 | 39.3.5 | Stage 3 for Session management, bearer control and QoS aspects | 485d? | 2007-02-05 A | 2008-12-15 | 75% | 121.25d? | 2007-02-05 | 2008-12-15 | 485d? | 270d | finish no earlier than 2008-12-15 | C1 | 3880h | 2910h | SAES | NSN | robert.zaus@nsn.com | Rel-8 | Frederic |
| 81 | 39.3.6 | Stage 3 for security aspects of LTE Access | 485d? | 2007-02-05 A | 2008-12-15 | 65% | 169.75d? | 2007-02-05 | 2008-12-15 | 485d? | 270d | finish no earlier than 2008-12-15 | C1 | 3880h | 2522h | SAES | NSN | robert.zaus@nsn.com | Rel-8 | Frederic |
| 82 | 39.3.7 | Stage 3 for QoS mechanisms | 485d? | 2007-02-05 | 2008-12-12 |  |  | 2007-02-05 | 2008-12-12 | 485d? | 270d | finish no earlier than 2008-12-12 | C3 | 3880h |  | SAES | Ericsson | j.javier.pastor@ericsson.com | Rel-8 | Gwiho |
| 83 | 39.3.8 | Stage 3 for EPC - HSS interface | 480d? | 2007-02-05 A | 2008-12-05 | 80% | 96d? | 2007-02-05 | 2008-12-05 | 480d? | 275d | finish no earlier than 2008-12-05 | C4 | 3840h | 3072h | SAES | Huawei | shahab.lavasani@huawei.com | Rel-8 | Kimmo |

Notes:
- 58: SA#38 completed / Text3: 22.278, 22.011, 22.246
- 60: SA#40 completed / Text3: 23.402
- 61: SA#39: WID update of SP-070933. WP record created / Text3: 33.401, 33.210, 33.310
- 62: Text3: 24.229, 24.305, 27.007
- 63: Text3: 29.061
- 64: CT#40 WID updated CP-080026=>CP-080279 / Text3: 29.274, 29.275
- 65: Text3: 23.122, 24.302, 24.abc
- 66: Text3: 29.061
- 67: Text3: 29.125, 29.212, 29.213, 29.214, 29.215
- 68: CT#40 WID updated CP-080026=>CP-080279 / Text3: 23.003
- 69: CP#37 WID approved / Text3: 29.909
- 70: Text3: 23.401, 23.060, 23.002, 23.246, 23.203, 23.107, 23.234, 23.271
- 71: CT#40 WID updated CP-080026=>CP-080279 / Text3: 29.274, 29.275
- 73: SA#40 completed
- 74: CT#40 WID updated CP-080026=>CP-080279 / Text3: 29.274
- 76: Multiple PDN related alignments, 23.060-derived changes. SA#40 completed
- 77: CT#40 WID updated CP-080026=>CP-080279 / Text3: 29.275
- 78: CT#40 WID updated CP-080026=>CP-080279 / Text3: 29.new
- 79: Text3: 24.007, 24.301
- 80: Text3: 24.007, 24.301
- 81: Text3: 24.008, 24.301
- 83: CT#40 WID updated CP-080026=>CP-080279 / Text3: 29.272

| ID | WBS | Task | Type | Duration | Start | Finish | Complete | Remaining | Baseline start | Baseline finish | Baseline duration | Total slack | Constraint | Resources | Work | Actual work | Text1 | Text3 | Text4 | Text5 | Text6 | Text8 | Text12 |
| --- | --- | --- | --- | --- | --- | --- | --- | --- | --- | --- | --- | --- | --- | --- | --- | --- | --- | --- | --- | --- | --- | --- | --- |
| 84 | 39.4 | **SAE for Interoperation between LTE and legacy cellular PS accesses** |  | 485d? | 2007-02-05 A | 2008-12-15 | 68% | 154.38d? | 2007-02-05 | 2008-12-15 | 485d? | 270d |  | S2,C1,C4 | 33816h | 20601h | SAES-SA-FP_3GPP | 23.401, 23.402 | Motorola | Irfan.Ali@motorola.com | Rel-8 | Maurice |  |
| 85 | 39.4.1 | Stage 2 for Interoperation between LTE and 2G/3G |  | 419d? | 2007-02-05 A | 2008-09-11 | 90% | 41.9d? | 2007-02-05 | 2008-09-11 | 419d? | 336d | finish no earlier than 2008-09-11 | S2 | 3352h | 3016.8h | EPSto2_3G |  | NSN |  | Rel-8 | Maurice |  |
| 86 | 39.4.2 | Stage 3 for Inter-system mobility between E-UTRAN and 2G/3G |  | 485d? | 2007-02-05 A | 2008-12-12 | 40% | 291d? | 2007-02-05 | 2008-12-12 | 485d? | 270d | start no earlier than 2007-02-05 | C1 | 3880h | 1552h | SAES | 24.008, 24.301 | NSN | robert.zaus@nsn.com | Rel-8 | Frederic |  |
| 87 | 39.4.3 | Stage 2 GPRS enhancements for LTE access | milestone | 0d? | 2007-09-04 A | 2007-09-04 A | 100% |  | 2007-09-04 | 2007-09-04 | 0d? |  | start no earlier than 2007-09-04 | S2 |  |  | SAES-GPRS_LTE | 23.401 | Vodafone | chris.pudney@vodafone.com | Rel-8 | Maurice |  |
| 88 | 39.4.4 | Stage 2 GPRS for EPC (23.060, etc.) |  | 179d? | 2008-01-14 A | 2008-09-18 | 40% | 107.4d? | 2008-01-14 | 2008-09-18 | 179d? | 331d | finish no earlier than 2008-09-18 | S2 | 1432h | 572.8h | SAES | 23.060 | NSN |  | Rel-8 | Maurice |  |
| 89 | 39.4.5 | Stage 3 for EPC - GPRS |  | 480d? | 2007-02-05 A | 2008-12-05 | 50% | 240d? | 2007-02-05 | 2008-12-05 | 480d? | 275d | finish no earlier than 2008-12-05 | C4 | 3840h | 1920h | SAES | 29.274, 29.275GTP-U | Huawei | shahab.lavasani@huawei.com | Rel-8 | Kimmo |  |
| 90 | 39.4.6 | Stage 3 for EPC to UTRAN |  | 480d? | 2007-02-05 A | 2008-12-05 | 50% | 240d? | 2007-02-05 | 2008-12-05 | 480d? | 275d | finish no earlier than 2008-12-05 | C4 | 3840h | 1920h | SAES | 29.274, 29.275GTP-U | Huawei | shahab.lavasani@huawei.com | Rel-8 | Kimmo |  |
| 91 | 39.4.7 | Stage 3 for EPC to 3GPP2 |  | 480d? | 2007-02-05 A | 2008-12-05 | 90% | 48d? | 2007-02-05 | 2008-12-05 | 480d? | 275d | finish no earlier than 2008-12-05 | C4 | 3840h | 3456h | SAES | 29.277, 29.276 | Huawei | shahab.lavasani@huawei.com | Rel-8 | Kimmo |  |
| 92 | 39.4.8 | Stage 2 for Interoperation between LTE and CDMA2000 |  | 254d? | 2007-06-18 A | 2008-06-05 | 98% | 5.08d? | 2007-06-18 | 2008-06-05 | 254d? | 406d | finish no earlier than 2008-04-25 | S2 | 2032h | 1991.36h | EPStoC2k |  | NSN |  | Rel-8 | Maurice |  |
| 93 | 39.4.9 | Stage 3 for Inter-system mobility between E-UTRAN and CDMA2000 |  | 485d? | 2007-02-05 A | 2008-12-15 | 65% | 169.75d? | 2007-02-05 | 2008-12-15 | 485d? | 270d | finish no earlier than 2008-12-15 | C1 | 3880h | 2522h | SAES | 24.301, 24.302 | NSN | robert.zaus@nsn.com | Rel-8 | Frederic |  |
| 94 | 39.4.10 | Stage 3 for MME - SGSN "signalling free" protocol |  | 480d? | 2007-02-05 A | 2008-12-05 | 90% | 48d? | 2007-02-05 | 2008-12-05 | 480d? | 275d | finish no earlier than 2008-12-05 | C4 | 3840h | 3456h | SAES | 29.272, 29.274 | Huawei | shahab.lavasani@huawei.com | Rel-8 | Kimmo |  |
| 95 | 39.5 | **SAE for support for non-3GPP accesses** |  | 509d? | 2007-01-02 A | 2008-12-15 | 78% | 111.86d? | 2007-01-02 | 2008-12-15 | 509d? | 270d |  | S2,S3,C1,C4 | 51552h | 37432h | SAES-SA-FP_n3GPP | 23.402 | Motorola | Irfan.Ali@motorola.com | Rel-8 | Maurice |  |
| 96 | 7.2.4.1 | Stage 2 for Host-based Mobility aspects |  | 373d? | 2007-01-02 A | 2008-06-05 A | 100% |  | 2007-01-02 | 2008-06-05 | 373d? |  | finish no earlier than 2008-04-11 | S2 | 2984h | 2984h | SAES-SA-FP_n3GPP-HBMob |  | NSN |  | Rel-8 | Maurice |  |
| 97 | 7.2.4.2 | Stage 2 for Network-based Mobility aspects |  | 448d? | 2007-01-02 A | 2008-09-18 | 90% | 44.8d? | 2007-01-02 | 2008-09-18 | 448d? | 331d | finish no earlier than 2008-09-18 | S2 | 3584h | 3225.6h | SAES-SA-FP_n3GPP-NBMob |  | NSN |  | Rel-8 | Maurice |  |
| 98 | 39.5.3 | Stage 3 for Mobility management based on DSMIP v6 |  | 485d? | 2007-02-05 A | 2008-12-15 | 90% | 48.5d? | 2007-02-05 | 2008-12-15 | 485d? | 270d | finish no earlier than 2008-12-15 | C1 | 3880h | 3492h | SAES | 24.303 | NSN | robert.zaus@nsn.com | Rel-8 | Frederic |  |
| 99 | 39.5.4 | Stage 3 for Mobility management based on MIP v4 |  | 485d? | 2007-02-05 A | 2008-12-12 | 75% | 121.25d? | 2007-02-05 | 2008-12-12 | 485d? | 270d | start no earlier than 2007-02-05 | C1 | 3880h | 2910h | SAES | 24.304 | NSN | robert.zaus@nsn.com | Rel-8 | Frederic |  |
| 100 | 39.5.5 | Stage 3 for Inter-system mobility between E-UTRAN and non 3GPP accesses |  | 485d? | 2007-02-05 A | 2008-12-12 | 40% | 291d? | 2007-02-05 | 2008-12-12 | 485d? | 270d | start no earlier than 2007-02-05 | C1 | 3880h | 1552h | SAES | 24.301 | NSN | robert.zaus@nsn.com | Rel-8 | Frederic |  |
| 101 | 39.5.6 | Stage 2 for Optimized Dual-Radio Handover with WiMAX |  | 249d? | 2007-06-25 A | 2008-06-05 A | 100% |  | 2007-06-25 | 2008-06-05 | 249d? |  | finish no earlier than 2008-06-09 | S2 | 1992h | 1992h | SAES-SA-FP_n3GPP-OptWIMAX |  | NSN |  | Rel-8 | Maurice |  |
| 102 | 39.5.7 | Stage 2 Security aspects for non-3GPP Access |  | 197d? | 2008-03-12 A | 2008-12-11 | 90% | 19.7d? | 2008-03-12 | 2008-12-11 | 197d? | 271d | finish no earlier than 2008-12-11 | S3 | 1576h | 1418.4h | SAES | 33.402, 33.210, 33.310 | NSN | marc.blommaert.ext@nsn.com | Rel-8 | Dionisio |  |
| 103 | 39.5.8 | Stage 3 security aspects for DSMIP v6 Access |  | 485d? | 2007-02-05 A | 2008-12-15 | 90% | 48.5d? | 2007-02-05 | 2008-12-15 | 485d? | 270d | finish no earlier than 2008-12-15 | C1 | 3880h | 3492h | SAES | 24.303 | NSN | robert.zaus@nsn.com | Rel-8 | Frederic |  |
| 104 | 39.5.9 | Stage 3 security aspects for MIPv4 Access |  | 485d? | 2007-02-05 A | 2008-12-15 | 75% | 121.25d? | 2007-02-05 | 2008-12-15 | 485d? | 270d | finish no earlier than 2008-12-15 | C1 | 3880h | 2910h | SAES | 24.304 | NSN | robert.zaus@nsn.com | Rel-8 | Frederic |  |
| 105 | 39.5.10 | Stage 3 for Access to the EPC via non-3GPP access networks |  | 485d? | 2007-02-05 A | 2008-12-15 | 65% | 169.75d? | 2007-02-05 | 2008-12-15 | 485d? | 270d | finish no earlier than 2008-12-15 | C1 | 3880h | 2522h | SAES | 24.302 | NSN | robert.zaus@nsn.com | Rel-8 | Frederic |  |
| 106 | 39.5.11 | Stage 3 for interfaces within EPC |  | 318d? | 2007-09-19 A | 2008-12-05 | 75% | 79.5d? | 2007-09-19 | 2008-12-05 | 318d? | 275d | finish no earlier than 2008-12-05 | C4 | 2544h | 1908h | SAES | 29.274, 29.GTP-U | Huawei | shahab.lavasani@huawei.com | Rel-8 | Kimmo |  |
| 107 | 39.5.12 | Stage 3 for Interfaces EPC - non-3GPP IP access |  | 480d? | 2007-02-05 A | 2008-12-05 | 75% | 120d? | 2007-02-05 | 2008-12-05 | 480d? | 275d | finish no earlier than 2008-12-05 | C4 | 3840h | 2880h | SAES | 29.273, 29.275 | Huawei | shahab.lavasani@huawei.com | Rel-8 | Kimmo |  |
| 108 | 39.5.13 | Stage 3 for AAA/HSS related |  | 480d? | 2007-02-05 A | 2008-12-05 | 75% | 120d? | 2007-02-05 | 2008-12-05 | 480d? | 275d | finish no earlier than 2008-12-05 | C4 | 3840h | 2880h | SAES | 29.273 | Huawei | shahab.lavasani@huawei.com | Rel-8 | Kimmo |  |
| 109 | 39.5.14 | Stage 3 for EPC - AAA interface |  | 480d? | 2007-02-05 A | 2008-12-05 | 75% | 120d? | 2007-02-05 | 2008-12-05 | 480d? | 275d | finish no earlier than 2008-12-05 | C4 | 3840h | 2880h | SAES | 29.273 | Huawei | shahab.lavasani@huawei.com | Rel-8 | Kimmo |  |
| 110 | 39.5.15 | Deleted (already covered) SAES-SA-FP_n3GPP Optimized Handover with CDMA | milestone | 0d? | 2007-06-25 A | 2007-06-25 A | 100% |  | 2007-06-25 | 2007-06-25 | 0d? |  | finish no earlier than 2007-06-25 | S2 |  |  | SAES-SA-FP_n3GPP-OptCDMA |  | NSN |  | Rel-8 | Maurice | SP-37 |

Notes:
- 85: SA#40 exception to Sep 2008 (default bearer issue)
- 87: 25/03/08 claimed as SA#34 stopped. Resurrected. WID updated SP-060926 => SP-080132
- 88: SA#40 exception to Sep 2008 (QoS mapping related changes, Interoperation between Gn/Gp and S4 SGSN)
- 89: CT#40 WID updated CP-080026=>CP-080279
- 90: CT#40 WID updated CP-080026=>CP-080279
- 91: CT#40 WID updated CP-080026=>CP-080279
- 92: SA#40 exception to Sep 2008 (Handover of multiple PDNs, Handling of multiple BBERFs)
- 94: CT#40 WID updated CP-080026=>CP-080279
- 95: SA#39: retained in Rel 8 (in addition to the essential functionality defined in SP-070699). Replaces UID_340037
- 96: SA#40 completed
- 97: SA#40 exception to Sep 2008 (Multiple PDN connections to the same APN using PMIP)
- 101: SA#40 completed
- 102: SA#39: WID update of SP-070933. WP record created
- 103: post-CT#39: split into DSMIP v6 and MIPv4 Access
- 104: post-CT#39: split into DSMIP v6 and MIPv4 Access. 390072->390172
- 106: CT#40 WID updated CP-080026=>CP-080279
- 107: CT#40 WID updated CP-080026=>CP-080279
- 108: CT#40 WID updated CP-080026=>CP-080279
- 109: CT#40 WID updated CP-080026=>CP-080279
- 110: SA#37 stopped

| ID | WBS | Task | Type | Duration | Start | Finish | Complete | Remaining | Baseline start | Baseline finish | Baseline duration | Total slack | Constraint | Resources | Work | Actual work | Text1 | Text4 | Text5 | Text6 | Text8 | Text12 |
| --- | --- | --- | --- | --- | --- | --- | --- | --- | --- | --- | --- | --- | --- | --- | --- | --- | --- | --- | --- | --- | --- | --- |
| 111 | 39.6 | **Single Radio Voice Call Continuity for 3GPP (SRVCC)** |  | 509d? | 2007-01-02 A | 2008-12-12 | 75% | 127.76d? | 2007-01-02 | 2008-12-12 | 509d? | 270d |  | S2,C4 | 5704h | 4272.27h | SAES-SRVCC | NSN | Curt Wong | Rel-8 | Maurice |  |
| 112 | 39.6.1 | Single Radio Voice Call Continuity for 3GPP (SRVCC) |  | 445d? | 2007-01-02 A | 2008-09-15 A | 100% |  | 2007-01-02 | 2008-09-15 | 445d? |  | finish no earlier than 2008-09-15 | S2 | 3560h | 3560h | SAES-SRVCC | NSN | Curt Wong | Rel-8 | Maurice |  |
| 113 | 39.6.2 | Stage 3 for SRVCC in EPS |  | 136d? | 2008-05-30 | 2008-12-05 |  |  | 2008-05-30 | 2008-12-05 | 136d? | 275d | start no earlier than 2008-05-30 | C1 | 1088h |  | SAES-SRVCC | NSN | 23.009, 24.301, 24.008 | Rel-8 |  |  |
| 114 | 39.6.3 | MME to MSC interface for SRVCC |  | 66d? | 2008-09-12 A | 2008-12-12 | 60% | 26.4d? | 2008-09-12 | 2008-12-12 | 66d? | 270d | finish no earlier than 2008-12-12 | C4 | 528h | 316.8h | SAES-SRVCC | NSN | Giorgi Gulbani | Rel-8 |  |  |
| 115 | 39.7 | Voice Call Continuity for CDMA2000 1X |  | 249d? | 2007-06-25 A | 2008-06-05 A | 100% |  | 2007-06-25 | 2008-06-05 | 249d? |  | finish no earlier than 2008-06-13 | S2 | 1992h | 1992h | SAES-VCC_1X | NSN |  | Rel-8 | Maurice |  |
| 116 | 39.8 | SAE impacts on IMS |  | 373d? | 2007-01-02 A | 2008-06-05 A | 100% |  | 2007-01-02 | 2008-06-05 | 373d? |  | finish no earlier than 2008-06-13 | S2 | 2984h | 2984h | SAES-SA_IMS | NSN |  | Rel-8 | Maurice |  |
| 117 | 39.9 | **CS Fallback in EPS** |  | 193d? | 2008-03-12 A | 2008-12-05 | 63% | 70.73d? | 2008-03-12 | 2008-12-05 | 193d? | 275d |  | S2,C1,C4 | 3760h | 1692.8h | SAES-CSFB | T-Mobile, Vodafone | sabine.demel@t-mobile.at, chris.pudney@vodafone.com | Rel-8 | Maurice |  |
| 118 | 39.9.1 | Stage 2 for CS Fallback in EPS |  | 62d? | 2008-03-12 A | 2008-06-05 A | 100% |  | 2008-03-12 | 2008-06-05 | 62d? |  | finish no earlier than 2008-12-05 | S2 | 496h | 496h | SAES-CSFB | T-Mobile, Vodafone | sabine.demel@t-mobile.at, chris.pudney@vodafone.com | Rel-8 | Maurice |  |
| 119 | 39.9.2 | Stage 3 for CS Fallback in EPS |  | 136d? | 2008-05-30 A | 2008-12-05 | 50% | 68d? | 2008-05-30 | 2008-12-05 | 136d? | 275d | finish no earlier than 2008-12-05 | C1 | 1088h | 544h | SAES-CSFB | NEC | yannick.lair@nectech.fr | Rel-8 | Frederic |  |
| 120 | 39.9.3 | Stage 3 for CS Fallback in EPS |  | 136d? | 2008-05-30 A | 2008-12-05 | 60% | 54.4d? | 2008-05-30 | 2008-12-05 | 136d? | 275d | finish no earlier than 2008-12-05 | C4 | 1088h | 652.8h | SAES-CSFB | NEC | yannick.lair@nectech.fr | Rel-8 | Kimmo |  |
| 121 | 39.10 | System enhancements for the use of IMS services in local breakout |  | 62d? | 2008-03-12 A | 2008-06-05 A | 100% |  | 2008-03-12 | 2008-06-05 | 62d? |  | finish no earlier than 2008-06-05 | S2 | 496h | 496h | SAES-IMS_LBO | Telecom Italia | mario.madella@telecomitalia.it | Rel-8 | Maurice |  |
| 122 | 39.11 | **EPC Data Definitions** |  | 309d? | 2008-01-07 A | 2009-03-12 | 24% | 234.7d? | 2008-01-07 | 2009-03-12 | 309d? | 206d |  | S5 | 6624h | 1592.82h | EPC-OAM |  |  | Rel-8 | Dionisio |  |
| 123 | 39.11.1 | EPC Network Resource Model (NRM) Integration Reference Point (IRP) |  | 309d? | 2008-01-07 A | 2009-03-12 | 20% | 247.2d? | 2008-01-07 | 2009-03-12 | 309d? | 206d | finish no earlier than 2009-03-12 | S5 | 2472h | 494.4h | EPC-OAM | Huawei | WANG, Xuelong | Rel-8 | Dionisio |  |
| 124 | 39.11.2 | Performance measurements for EPC |  | 210d? | 2008-02-22 A | 2008-12-11 | 30% | 147d? | 2008-02-22 | 2008-12-11 | 210d? | 271d | start no earlier than 2008-02-22 | S5 | 1680h | 504h | EPC-OAM | China Mobile | Li Jian, Liang Shuangchun | Rel-8 | Dionisio |  |
| 125 | 39.12 | EPC Charging |  | 309d? | 2008-01-07 A | 2009-03-12 | 70% | 92.7d? | 2008-01-07 | 2009-03-12 | 309d? | 206d | finish no earlier than 2009-03-12 | S5 | 2472h | 1730.4h | EPC-CH | NSN | GÖRMER, Gerald | Rel-8 | Dionisio |  |
| 126 | 39.13 | Issues for CT1 TR 24.801 |  | 480d? | 2007-01-04 A | 2008-12-05 | 85% | 72d? | 2007-01-04 | 2008-12-05 | 480d? | 275d | finish no earlier than 2008-12-05 | C1 | 3840h | 3264h | SAES | NSN | robert.zaus@nsn.com | Rel-8 | Frederic |  |
| 127 | 39.14 | Issues for CT3 TR 29.804 |  | 485d? | 2007-02-05 A | 2008-12-12 | 90% | 48.5d? | 2007-02-05 | 2008-12-12 | 485d? | 270d | finish no earlier than 2008-12-12 | C3 | 3880h | 3492h | SAES | Ericsson | j.javier.pastor@ericsson.com | Rel-8 | Gwiho |  |
| 128 | 39.15 | Issues for CT4 TR 29.803 |  | 425d? | 2007-01-04 A | 2008-09-19 | 59% | 174.25d? | 2007-01-04 | 2008-09-19 | 425d? | 330d | finish no earlier than 2008-09-19 | C4 | 3400h | 2006h | SAES | Huawei |  | Rel-8 | Kimmo |  |
| 129 | 39.16 | Domain Name System Procedures for Evolved Packet System (DEPS) |  | 119.75d? | 2008-05-30 A | 2008-12-15 | 81% | 22.75d? | 2008-05-30 | 2008-12-15 | 119.75d? | 270d | finish no earlier than 2008-12-15 | C4 | 958h | 775.98h | SAES-DEPS | TeliaSonera | jouni.korhonen@teliasonera.com | Rel-8 | Kimmo |  |
| 130 | 39.17 | CT6 aspects of SAE |  | 425d? | 2007-02-05 | 2008-09-19 |  |  | 2007-02-05 | 2008-09-19 | 425d? | 330d | start no earlier than 2007-02-05 | C6 | 3400h |  | SAES | Nokia | Peter.vestergaard@nokia.com | Rel-8 | Xavier |  |
| 131 | 39.18 | Deleted (covered by 380068): Functions and procedures for SAE to support LCS | milestone | 0d? | 2008-03-03 A | 2008-03-03 A | 100% |  | 2008-03-03 | 2008-03-03 | 0d? |  | finish no earlier than 2008-03-03 | S2 |  |  | SAES-SA-FP_LCS | NSN |  | Rel-8 | Maurice | SP-37 |
| 132 | 39.19 | Deleted (covered by 380064): SAE aspects of Emergency Calls | milestone | 0d? | 2008-03-03 A | 2008-03-03 A | 100% |  | 2008-03-03 | 2008-03-03 | 0d? |  | start no earlier than 2008-03-03 | S2 |  |  | SAES-SA-EmCall | NSN |  | Rel-8 | Maurice | SP-37 |
| 133 | 39.20 | Deleted - CT1 aspects of SAES |  | 16.7d? | 2007-09-04 A | 2007-09-27 A | 100% |  | 2007-09-04 | 2007-09-27 | 16.7d? |  | start no earlier than 2007-09-04 | CP,C1 | 133.62h | 133.62h | SAES-St3 |  |  | Rel-8 | Frederic | SP-37 |
| 134 | 39.21 | Deleted - CT1 aspects of SAES | milestone | 0d? | 2007-09-04 A | 2007-09-04 A | 100% |  | 2007-09-04 | 2007-09-04 | 0d? |  | start no earlier than 2007-09-04 | C1 |  |  | SAES-St3 |  |  | Rel-8 | Frederic | SP-37 |
| 135 | 39.22 | Deleted - Interoperability | milestone | 0d? | 2008-03-14 A | 2008-03-14 A | 100% |  | 2008-03-14 | 2008-03-14 | 0d? |  | start no earlier than 2008-03-14 | C1 |  |  | SAES-St3-interop |  |  | Rel-8 | Frederic | SP-37 |
| 136 | 39.23 | Deleted - CT3 aspects of SAES | milestone | 0d? | 2007-09-04 A | 2007-09-04 A | 100% |  | 2007-09-04 | 2007-09-04 | 0d? |  | start no earlier than 2007-09-04 | C3 |  |  | SAES-St3 |  |  | Rel-8 | Gwiho | SP-37 |
| 137 | 39.24 | Deleted - CT4 aspects of SAES | milestone | 0d? | 2007-09-04 A | 2007-09-04 A | 100% |  | 2007-09-04 | 2007-09-04 | 0d? |  | start no earlier than 2007-09-04 | C4 |  |  | SAES-St3 |  |  | Rel-8 | Kimmo | SP-37 |
| 138 | 39.25 | Deleted - UE to EPC NAS signalling (incl. MBMS and QoS aspects) | milestone | 0d? | 2008-03-14 A | 2008-03-14 A | 100% |  | 2008-03-14 | 2008-03-14 | 0d? |  | start no earlier than 2008-03-14 | C1 |  |  | SAES-St3-sig |  |  | Rel-8 | Frederic | SP-37 |
| 139 | 39.26 | Deleted -User and Control plane protocols | milestone | 0d? | 2007-09-21 A | 2007-09-21 A | 100% |  | 2007-09-21 | 2007-09-21 | 0d? |  | start no earlier than 2007-09-21 | C4 |  |  | SAES-St3-prot |  |  | Rel-8 | Kimmo | SP-37 |
| 140 | 39.27 | Deleted - Architecture enhancements for non-3GPP accesses | milestone | 0d? | 2007-09-04 A | 2007-09-04 A | 100% |  | 2007-09-04 | 2007-09-04 | 0d? |  | start no earlier than 2007-09-04 | S2 |  |  | SAES-non_3GPP | Motorola | Irfan.Ali@motorola.com | Rel-8 | Maurice | SP-34 |
| 141 | 39.28 | Deleted: Stage 2 of architecture for the 3GPP System Architecture Evolution | milestone | 0d? | 2007-10-02 A | 2007-10-02 A | 100% |  | 2007-10-02 | 2007-10-02 | 0d? |  | start no earlier than 2007-10-02 | S2 |  |  | SAES-St2 | Vodafone | chris.pudney@vodafone.com | Rel-8 | Maurice | SP-34 |
| 142 | 39.29 | Deleted - SA aspects of System Architecture Evolution |  | 384d? | 2006-04-12 A | 2007-10-02 A | 100% |  | 2006-04-12 | 2007-10-02 | 384d? |  | finish no earlier than 2007-10-02 | S2 | 3072h | 3072h | SAES-SA |  |  | Rel-8 | Maurice | SP-34 |

Notes:
- 111: SA#38 WID approved. SA#40 exception to Sep 2008 for Single Radio VCC: incorporating of results of the RAN HSPA VoIP to CS alignment work
- 112: SA#38 WID approved. SA#40 exception to Sep 2008 for Single Radio VCC: incorporating of results of the RAN HSPA VoIP to CS alignment work / Text3: 23.216
- 114: CT#41 WID approved / Text3: 29.new
- 115: SA#40 completed
- 116: SA#40 completed
- 117: SA#40 Stge 2 completed. CT#40 WID approved / Text3: 23.272, 23.401
- 118: SA#40 completed / Text3: 23.272, 23.401
- 119: CT#40 WID approved / Text3: 24.301, 24.801, 24.008, 29.abc
- 120: CT#40 WID approved / Text3: 23.008, 29.274, 29.277
- 121: SA#40 completed / Text3: 23.228, 23.221, 23.203
- 123: SA#38 WID approved / Text3: 32.751/2/3/5
- 124: SA#39 WID approved / Text3: 32.426
- 125: SA#38 WID approved / Text3: 32.240/296/251/252/298/299
- 126: CT#39 WID approved / Text3: 24.801
- 127: CT#39 WID approved / Text3: 29.804
- 128: CT#39 WID approved / Text3: 29.803
- 129: CT#40 WID approved / Text3: 23.003, 29.303
- 130: CT#39 WID approved / Text3: 31.102, 31.111
- 131: SA#37 stopped
- 132: SA#37 stopped
- 133: SA#37 stopped
- 134: SA#37 stopped
- 135: SA#37 stopped
- 136: SA#37 stopped
- 137: SA#37 stopped / Text3: 29.803
- 138: SA#37 stopped
- 139: SA#37 stopped
- 140: SA#34 stopped. Replaced by UID_350027 and its children / Text3: 23.402
- 141: SA#34 stopped. Replaced by UIDs 340018 and 340037. (SA#34 report discussion of SP-060917.) / Text3: 23.002, 23.060, 23.107, 23.203, 23.228, 23.234, 23.246, 23.271, 23.279
- 142: SA#34 stopped

| ID | WBS | Task | Type | Duration | Start | Finish | Complete | Remaining | Baseline start | Baseline finish | Baseline duration | Total slack | Constraint | Resources | Work | Actual work | Text1 | Text4 | Text6 | Text8 | Text5 | Text12 |
| --- | --- | --- | --- | --- | --- | --- | --- | --- | --- | --- | --- | --- | --- | --- | --- | --- | --- | --- | --- | --- | --- | --- |
| 143 | 40 | **System enhancements for interconnection interfaces between two IMSs** |  | 608d? | 2006-08-16 A | 2008-12-12 | 90% | 61.41d? | 2006-08-16 | 2008-12-12 | 608d? | 270d |  | S2,S5,C3 | 11216h | 6366.4h | IMS_NNI | Orange | Rel-8 | Maurice |  |  |
| 144 | 40.1 | Stage 1 for IMS_NNI (covered by Feature IPinterc) |  | 70d? | 2007-12-06 A | 2008-03-12 A | 100% |  | 2007-12-06 | 2008-03-12 | 70d? |  | start no earlier than 2007-12-06 | S1 | 560h | 560h | IPinterc | Telefonica O2 | Rel-8 | Alain | chris.friel@O2.com |  |
| 145 | 40.2 | Stage 2 for IMS_NNI |  | 120d? | 2007-06-22 A | 2007-12-06 A | 100% |  | 2007-06-22 | 2007-12-06 | 120d? |  | finish no earlier than 2007-12-21 | S2 | 960h | 960h | IMS_NNI | Orange | Rel-8 | Maurice |  |  |
| 146 | 40.3 | IMS inter-operator service interconnection interface |  | 401d? | 2007-06-01 A | 2008-12-12 | 80% | 80.2d? | 2007-06-01 | 2008-12-12 | 401d? | 270d | finish no earlier than 2008-12-12 | C3 | 3208h | 2566.4h | FBI2-IOPSI | Telecom Italia | Rel-8 | Gwiho | mauro.ficaccio@telecomitalia.it |  |
| 147 | 40.4 | Charging harmonization for NGN between 3GPP and ATIS-TMOC |  | 51d? | 2006-09-28 A | 2006-12-07 A | 100% |  | 2006-09-28 | 2006-12-07 | 51d? |  | finish no earlier than 2006-12-07 | S5 | 408h | 408h | FBI2-TISP2-CH | Amdocs | Rel-8 | Dionisio | Brown, Yishai |  |
| 148 | 40.5 | Deleted - Protocol impact of FBI for TISPAN R2 |  | 152d? | 2006-08-16 A | 2007-03-15 A | 100% |  | 2006-08-16 | 2007-03-15 | 152d? |  | finish no earlier than 2007-03-15 | C1 | 1216h | 1216h | FBI2-TISP2-c1 | Ericsson | Rel-8 | Frederic |  | SP-38 |
| 149 | 40.6 | Deleted (never approved) - Stage 2 of FBI for TISPAN R2 - Rel 8 | milestone | 0d? | 2007-11-30 A | 2007-11-30 A | 100% |  | 2007-11-30 | 2007-11-30 | 0d? |  | finish no earlier than 2007-11-30 | S2 |  |  | FBI2-TISP2-s2 | NSN | Rel-8 | Maurice |  | SP-36 |
| 150 | 41 | **IMS Centralized Service Control (ICSRA)** |  | 330d? | 2007-09-03 A | 2008-12-05 | 58% | 139.59d? | 2007-09-03 | 2008-12-05 | 330d? | 275d |  | S1,S2,C1,C3,C4 | 7992h | 3725.12h | ICSRA | AT&T | Rel-8 | Alain | Randy Wohlert |  |
| 151 | 41.1 | Stage 1 for ICSRA |  | 138d? | 2007-09-03 A | 2008-03-12 A | 100% |  | 2007-09-03 | 2008-03-12 | 138d? |  | finish no earlier than 2007-12-14 | S1 | 1104h | 1104h | ICSRA | AT&T | Rel-8 | Alain | Randy Wohlert |  |
| 152 | 41.2 | Stage 2 for ICSRA |  | 125d? | 2007-12-14 A | 2008-06-05 A | 100% |  | 2007-12-14 | 2008-06-05 | 125d? |  | start no earlier than 2007-12-14 | S2 | 1000h | 1000h | ICSRA-St2 | ALU | Rel-8 | Maurice |  |  |
| 153 | 41.3 | Stage 3 for ICSRA – Protocol, Addressing, Subscriber Data |  | 136d? | 2008-05-30 A | 2008-12-05 | 60% | 54.4d? | 2008-05-30 | 2008-12-05 | 136d? | 275d | start no earlier than 2008-05-30 | C1 | 1088h | 652.8h | ICSRA | Ericsson | Rel-8 | Frederic | Sean Schneyer |  |
| 154 | 41.4 | Stage 3 for ICSRA – I1 interface |  | 136d? | 2008-05-30 A | 2008-12-05 | 4% | 130.56d? | 2008-05-30 | 2008-12-05 | 136d? | 275d | start no earlier than 2008-05-30 | C1 | 1088h | 43.52h | ICSRA | Ericsson | Rel-8 | Frederic | Sean Schneyer |  |
| 155 | 41.5 | Stage 3 for ICSRA – Protocol, Addressing, Subscriber Data |  | 136d? | 2008-05-30 A | 2008-12-05 | 35% | 88.4d? | 2008-05-30 | 2008-12-05 | 136d? | 275d | start no earlier than 2008-05-30 | C3 | 1088h | 380.8h | ICSRA | Ericsson | Rel-8 | Gwiho | Sean Schneyer |  |
| 156 | 41.6 | Stage 3 for ICSRA – Protocol, Addressing, Subscriber Data |  | 136d? | 2008-05-30 A | 2008-12-05 | 50% | 68d? | 2008-05-30 | 2008-12-05 | 136d? | 275d | start no earlier than 2008-05-30 | C4 | 1088h | 544h | ICSRA | Ericsson | Rel-8 | Kimmo | Sean Schneyer |  |
| 157 | 42 | AS/MRFC stage 2 and 3 work |  | 278d? | 2007-11-14 A | 2008-12-05 | 60% | 111.2d? | 2007-11-14 | 2008-12-05 | 278d? | 275d | finish no earlier than 2008-12-05 | C1 | 2224h | 1334.4h | MRFC_TS | HP | Rel-8 | Frederic | mark.syrett@hp.com |  |
| 158 | 43 | **IMS Multimedia Telephony and Supplementary Services** |  | 423d? | 2007-05-02 A | 2008-12-12 | 56% | 184.28d? | 2007-05-02 | 2008-12-12 | 423d? | 270d |  | S1,S5,C1,C3,C4 | 40318.4h | 18762.9h | IMSTSS |  | Rel-8 | Frederic |  |  |
| 159 | 43.1 | **General aspects of IMS Sup Services** |  | 335d? | 2007-09-03 A | 2008-12-12 | 96% | 11.97d? | 2007-09-03 | 2008-12-12 | 335d? | 270d |  | S1,C1,C3,C4 | 8792h | 6493.6h | IMSSS-Gal | Ericsson | Rel-8 | Alain | Susana Sabater |  |
| 160 | 43.1.1 | Service and Capability for Core IMS - inclusion of TISPAN requirements |  | 75d? | 2007-09-03 A | 2007-12-14 A | 100% |  | 2007-09-03 | 2007-12-14 | 75d? |  | finish no earlier than 2007-12-14 | S1 | 600h | 600h | TISCAPR8 | Ericsson | Rel-8 | Alain | Susana Sabater |  |
| 161 | 43.1.2 | Documentation of TISPAN R1 and R2 in CT1 |  | 208d? | 2007-11-28 A | 2008-09-12 A | 100% |  | 2007-11-28 | 2008-09-12 | 208d? |  | finish no earlier than 2008-09-12 | C1 | 1664h | 1664h | REDOC_TIS-C1 | NSN | Rel-8 | Frederic | peter.leis@nsn.com |  |
| 162 | 43.1.3 | Documentation of TISPAN R1 and R2 in CT3 |  | 273d? | 2007-11-28 A | 2008-12-12 | 90% | 27.3d? | 2007-11-28 | 2008-12-12 | 273d? | 270d | finish no earlier than 2008-12-12 | C3 | 2184h | 1965.6h | REDOC_TIS-C3 | NSN | Rel-8 | Gwiho | peter.leis@nsn.com |  |
| 163 | 43.1.4 | Documentation of TISPAN R1 and R2 in CT4 |  | 208d? | 2007-11-28 A | 2008-09-12 A | 100% |  | 2007-11-28 | 2008-09-12 | 208d? |  | finish no earlier than 2008-09-12 | C4 | 1664h | 1664h | REDOC_TIS-C4 | NSN | Rel-8 | Kimmo | peter.leis@nsn.com |  |
| 164 | 43.2 | **IMS Multimedia Telephony Service** |  | 328d? | 2007-09-10 A | 2008-12-10 | 53% | 155.27d? | 2007-09-10 | 2008-12-10 | 328d? | 272d |  | S1,S5 | 4568h | 1817.6h | IMS-MMTel |  | Rel-8 | Alain |  |  |
| 165 | 43.2.1 | Merging TISPAN MMTel [requirements] for Common IMS |  | 65d? | 2007-09-10 A | 2007-12-07 A | 100% |  | 2007-09-10 | 2007-12-07 | 65d? |  | finish no earlier than 2007-12-07 | S1 | 520h | 520h | TMMTEL | NSN | Rel-8 | Alain |  |  |
| 166 | 43.2.2 | MMTel and Supplementary Services Charging |  | 243d? | 2008-01-07 A | 2008-12-10 | 40% | 145.8d? | 2008-01-07 | 2008-12-10 | 243d? | 272d | finish no earlier than 2008-12-10 | S5 | 1944h | 777.6h | MMTel-CH | ALU | Rel-8 | Dionisio | GARDELLA, Maryse |  |

Notes:
- 143: SP-36 Name changed from "System enhancements for TISPAN Rel2". Stage 1 in Feature UID_380060 (IPinterc).
- 144: 22/07/08 Created. Stage 1 for IMS_NNI (covered by SA1 Feature 380060 IPinterc) / Text3: 22.101, 22.228
- 145: SA#38 completed / Text3: 23.002, 23.228
- 146: CP-36: WI approved. C3-36: draft 29.865 advanced. / Text3: 29.865, TS 29.def
- 147: SA#33 WID approved / Text3: 32.297
- 148: SA#38 stopped
- 149: SA#36 stopped
- 150: SA#40 SA1/2 completed. CT#40 WID approved.
- 151: SA#38 WID approved. SA#39 completed / Text3: 22.101
- 152: SA#38 WID approved. SA#40 completed / Text3: 23.292, 23.206
- 153: CT#40 WID approved. / Text3: 24.292, 24.229
- 154: 23/07/08 Line created at CT1 Zagreb request / Text3: 24.293
- 155: CT#40 WID approved. / Text3: 29.292
- 156: CT#40 WID approved. / Text3: 23.003, 29.232, 23.018, 29.002
- 157: Triggered by Study UID_7048 (MRFC) / Text3: 23.218, 24.229, 24.147, 24.247
- 160: SA#39 completed / Text3: 22.228, 22.115, 22.101
- 161: CT#41 completed / Text3: 24.141, 24.147, 24.173, 24.229, 24.247, 24.341, 24.604, 24.605, 24.606, 24.607, 24.608, 24.610, 24.611, 24.616, 24.623, 24.628, 24.629, 24.647, 24.654
- 162: Text3: 29.162, 29.163, 29.658
- 163: CT#41 completed / Text3: 29.228, 29.229
- 165: SA#38 completed / Text3: 22.173
- 166: SA#38 WID approved / Text3: 32.275, 32.298/299

| ID | WBS | Task | Duration | Start | Finish | Complete | Remaining | Baseline start | Baseline finish | Baseline duration | Total slack | Constraint | Resources | Work | Actual work | Text1 | Text4 | Text5 | Text6 | Text8 |
| --- | --- | --- | --- | --- | --- | --- | --- | --- | --- | --- | --- | --- | --- | --- | --- | --- | --- | --- | --- | --- |
| 167 | 43.3 | **Call Completion on Busy Subscriber (CCBS)/Call Completion on Non-Reachable (CCNR) on IMS** | 418d? | 2007-05-02 A | 2008-12-05 | 30% | 292.75d? | 2007-05-02 | 2008-12-05 | 418d? | 275d |  | C1,C3 | 10024h | 3003.6h | CCBS_CCNR | Deutsche Telekom | martin.huelsemann@telekom.de | Rel-8 | Frederic |
| 168 | 43.3.1 | Stage 3 CCBS_CCNR | 417d? | 2007-05-02 A | 2008-12-05 | 60% | 166.8d? | 2007-05-02 | 2008-12-05 | 417d? | 276d | finish no earlier than 2008-12-05 | C1 | 3336h | 2001.6h | CCBS_CCNR | Deutsche Telekom | martin.huelsemann@telekom.de | Rel-8 | Frederic |
| 169 | 43.3.2 | Stage 3 CCBS_CCNR | 418d? | 2007-05-02 | 2008-12-05 |  |  | 2007-05-02 | 2008-12-05 | 418d? | 275d | finish no earlier than 2008-12-05 | C3 | 3344h |  | CCBS_CCNR | Deutsche Telekom | martin.huelsemann@telekom.de | Rel-8 | Gwiho |
| 170 | 43.4 | **Flexible Alerting** | 222d? | 2008-01-30 A | 2008-12-05 | 77% | 51.79d? | 2008-01-30 | 2008-12-05 | 222d? | 276d |  | S1,C1 | 4222.4h | 1925.92h | FA | Nortel | milanpa@nortel.com | Rel-8 | Alain |
| 171 | 43.4.1 | Stage 1 FA | 92d? | 2008-01-30 A | 2008-06-05 A | 100% |  | 2008-01-30 | 2008-06-05 | 92d? |  |  | S1 | 670.4h | 670.4h | FA | Telecom Italia |  | Rel-8 | Alain |
| 172 | 43.4.2 | Stage 3 FA | 222d? | 2008-01-30 A | 2008-12-05 | 67% | 73.26d? | 2008-01-30 | 2008-12-05 | 222d? | 276d | finish no earlier than 2008-12-05 | C1 | 1776h | 1189.92h | FA | Nortel | milanpa@nortel.com | Rel-8 | Frederic |
| 173 | 43.5 | **Communication Wait on IMS** | 265d? | 2007-11-30 A | 2008-12-05 | 30% | 185.5d? | 2007-11-30 | 2008-12-05 | 265d? | 276d |  | C1,C3 | 6360h | 1908h | CW_IMS | Deutsche Telekom | martin.huelsemann@telekom.de | Rel-8 | Frederic |
| 174 | 43.5.1 | Stage 3 CW-IMS | 265d? | 2007-11-30 A | 2008-12-05 | 60% | 106d? | 2007-11-30 | 2008-12-05 | 265d? | 276d | finish no earlier than 2008-12-05 | C1 | 2120h | 1272h | CW_IMS | Deutsche Telekom | martin.huelsemann@telekom.de | Rel-8 | Frederic |
| 175 | 43.5.2 | Stage 3 CW-IMS | 265d? | 2007-11-30 | 2008-12-05 |  |  | 2007-11-30 | 2008-12-05 | 265d? | 276d | finish no earlier than 2008-12-05 | C3 | 2120h |  | CW_IMS | Deutsche Telekom | martin.huelsemann@telekom.de | Rel-8 | Gwiho |
| 176 | 43.6 | Advice of Charge (AoC) support in IMS Charging | 243d? | 2008-01-07 A | 2008-12-10 | 35% | 157.95d? | 2008-01-07 | 2008-12-10 | 243d? | 272d | finish no earlier than 2008-12-10 | S5 | 1944h | 680.4h | IMSTSS | NSN | GÖRMER, Gerald | Rel-8 | Dionisio |
| 177 | 43.7 | Add Interconnection Border Control Function (IBCF) to IMS Charging | 128d? | 2007-09-17 A | 2008-03-12 A | 100% |  | 2007-09-17 | 2008-03-12 | 128d? |  | finish no earlier than 2008-03-12 | S5 | 1024h | 1024h | IMSTSS | ALU | GARDELLA, Maryse | Rel-8 | Dionisio |
| 178 | 44 | **Interworking between User-to-User Signalling (UUS) and SIP** | 271d? | 2007-11-30 A | 2008-12-12 | 65% | 94.98d? | 2007-11-30 | 2008-12-12 | 271d? | 270d |  | C1,C3 | 6464h | 4198.59h | UUSIW | Huawei | Lili Yang (kadyyang@huawei.com) | Rel-8 | Kimmo |
| 179 | 44.1 | Stage 3 MGCF UUSIW | 266d? | 2007-11-30 A | 2008-12-05 | 70% | 79.8d? | 2007-11-30 | 2008-12-05 | 266d? | 275d | finish no earlier than 2008-12-05 | C1 | 2128h | 1489.6h | UUSIW | Huawei | Lili Yang (kadyyang@huawei.com) | Rel-8 | Frederic |
| 180 | 44.2 | Stage 3 MGCF UUSIW | 271d? | 2007-11-30 A | 2008-12-12 | 60% | 108.4d? | 2007-11-30 | 2008-12-12 | 271d? | 270d | finish no earlier than 2008-12-12 | C3 | 2168h | 1300.8h | UUSIW | Huawei | Lili Yang (kadyyang@huawei.com) | Rel-8 | Gwiho |
| 181 | 45 | **Support of Overlap signalling** | 271d? | 2007-11-30 A | 2008-12-12 | 2% | 264.65d? | 2007-11-30 | 2008-12-12 | 271d? | 270d |  | C3,C1,C4 | 8528.16h | 148.97h | Overlap | Deutsche Telekom | r.jesske@telekom.de | Rel-8 | Gwiho |
| 182 | 45.1 | Stage 3 Overlap (CT1) | 266d? | 2007-11-30 A | 2008-12-05 | 2% | 260.68d? | 2007-11-30 | 2008-12-05 | 266d? | 275d | finish no earlier than 2008-12-05 | C1 | 2128h | 42.57h | Overlap | Deutsche Telekom | r.jesske@telekom.de | Rel-8 | Frederic |
| 183 | 45.2 | Stage 3 Overlap (CT3) | 271d? | 2007-11-30 A | 2008-12-12 | 5% | 257.7d? | 2007-11-30 | 2008-12-12 | 271d? | 270d | finish no earlier than 2008-12-12 | C3 | 2168h | 106.4h | Overlap | Deutsche Telekom | r.jesske@telekom.de | Rel-8 | Gwiho |
| 184 | 45.3 | Stage 3 Overlap (CT4) | 258.02d? | 2007-11-30 | 2008-12-05 |  |  | 2007-11-30 | 2008-12-05 | 258.02d? | 275d | start no earlier than 2007-11-30 | C4 | 2064.16h |  | Overlap | Deutsche Telekom | r.jesske@telekom.de | Rel-8 | Gwiho |
| 185 | 46 | **Maintenance of TISPAN documentation** | 244d? | 2007-07-02 A | 2008-06-05 A | 100% |  | 2007-07-02 | 2008-06-05 | 244d? |  |  | S2,C1,C3,C4 | 5984h | 5984h | MAINTISP |  |  |  | Frederic |
| 186 | 46.1 | Maintenance of TISPAN R1 | 86d? | 2007-11-09 A | 2008-03-07 A | 100% |  | 2007-11-09 | 2008-03-07 | 86d? |  | start no earlier than 2007-11-09 | C1,C3,C4 | 688h | 688h | MAINT_R1 | ALU | drage@alcatel-lucent.com | Rel-7 | Kimmo |
| 187 | 46.2 | Maintenance of TISPAN R2 | 86d? | 2007-11-09 A | 2008-03-07 A | 100% |  | 2007-11-09 | 2008-03-07 | 86d? |  | start no earlier than 2007-11-09 | C1,C3,C4 | 688h | 688h | MAINT_R2 | ALU | drage@alcatel-lucent.com | Rel-8 | Kimmo |
| 188 | 46.3 | Documentation of TISPAN NGN R1 and R2 in 3GPP SA2 | 104d? | 2008-01-14 A | 2008-06-05 A | 100% |  | 2008-01-14 | 2008-06-05 | 104d? |  | finish no earlier than 2008-06-20 | S2 | 832h | 832h | IMS_Comm_Doc | NSN | jozsef.varga@nsn.com | Rel-8 | Maurice |
| 189 | 46.4 | Maintenance of TISPAN release 1 common IMS | 114d? | 2007-07-02 A | 2007-12-06 A | 100% |  | 2007-07-02 | 2007-12-06 | 114d? |  | finish no earlier than 2007-12-06 | S2,S1 | 912h | 912h | IMS_Comm_Mtce7 | BT, Ericsson | Dick Knight, Raymond Forbes | Rel-7 | Maurice |
| 190 | 46.5 | Maintenance of TISPAN release 2 common IMS | 114d? | 2007-07-02 A | 2007-12-06 A | 100% |  | 2007-07-02 | 2007-12-06 | 114d? |  | finish no earlier than 2007-12-06 | S2 | 912h | 912h | IMS_Comm_Mtce8 | Telecom Italia | antonio.ascolese@telecomitalia.it | Rel-8 | Maurice |

Notes:
- 168: Text3: 24.642, 24.229, 24.173
- 169: Text3: 29.163
- 171: SA#39: SA1 consider "Pilot Identity" concept need. SA#40 completed / Text3: 22.173
- 172: Text3: 24.239, 24.173
- 174: Text3: 24.615, 24.229, 24.173
- 175: Text3: 29.163
- 176: SA#38 WID approved / Text3: 32.280, 32.240/260/296/298/299
- 177: SA#39 completed / Text3: 32.260, 32.298
- 179: Text3: 24.279, 24.229
- 180: Text3: 29.163
- 181: CT#38 WID approved
- 182: CT#38 WID approved / Text3: 24.229
- 183: CT#38 WID approved / Text3: 29.163
- 184: CT#38 WID approved / Text3: 29.228, 29.229
- 185: SA#40 completed
- 186: CT#39 completed / Text3: 24.404, 24.405, 24.406, 24.407, 24.408, 24.410, 24.411, 24.416, 29.421, 24.423, 24.428, 24.429, 29.433, 24.441, 24.403, 29.427, 24.430, 29.412
- 187: CT#39 completed / Text3: 24.406, 24.407, 24.410, 24.411, 24.423, 24.430, 24.447, 24.451, 24.454, 24.503, 24.505, 24.508, 24.516, 24.528, 24.529, 29.412, 29.421, 29.433, 29.458, 29.527
- 188: WID approved SA#38. per OPs & ETSI GA 39. This is a joint effort of SA WG2 and TISPAN WG2. SA#40 completed / Text3: 23.228, 23.204, 23.167
- 189: WID and TSs approved at SA#38. SA#40 updated WID SP-070915=>SP-080315 / Text3: 22.273, 22.401, 23.406, 23.417, 23.508, 23.509, 23.511, 22.401, 22.173
- 190: SA#38 approved WID and TSs / Text3: 23.506, 23.507,23.517, 23.521

| ID | WBS | Task | Duration | Start | Finish | Complete | Remaining | Baseline start | Baseline finish | Baseline duration | Total slack | Constraint | Resources | Work | Actual work | Text1 | Text4 | Text5 | Text6 | Text8 | Text3 |
| --- | --- | --- | --- | --- | --- | --- | --- | --- | --- | --- | --- | --- | --- | --- | --- | --- | --- | --- | --- | --- | --- |
| 191 | 47 | **Security Enhancements for IMS** | 582.3d? | 2006-09-19 A | 2008-12-11 | 65% | 204.8d? | 2006-09-19 | 2008-12-11 | 582.3d? | 271d |  | S3,C1,C4 | 16616h | 8915.2h | IMS-Sec | Ericsson | Bengt Sahlin | Rel-8 | Dionisio |  |
| 192 | 47.1 | Stage 2 for IMS-Sec | 466d? | 2007-03-01 A | 2008-12-11 | 70% | 139.8d? | 2007-03-01 | 2008-12-11 | 466d? | 271d | finish no earlier than 2008-12-11 | S3 | 3728h | 2609.6h | IMS-Sec | Ericsson | Bengt Sahlin | Rel-8 | Dionisio | 33.203, 33.141, 33.978, 33.828, 33.803 |
| 193 | 47.2 | CT1 part of Stage 3 for IMS-Sec | 392d? | 2006-09-19 A | 2008-12-05 | 90% | 39.2d? | 2006-09-19 | 2008-12-05 | 392d? | 275d | finish no earlier than 2008-12-05 | C1 | 3136h | 2822.4h | IMS-Sec | Ericsson |  | Rel-8 | Frederic |  |
| 194 | 47.3 | CT4 part of Stage 3 for IMS-Sec | 332d? | 2007-06-07 | 2008-09-12 |  |  | 2007-06-07 | 2008-09-12 | 332d? | 335d | finish no earlier than 2008-09-12 | C4 | 2656h |  | IMS-Sec | Ericsson |  | Rel-8 | Frederic |  |
| 195 | 47.4 | CT1 part of NASS Bundled Authentication | 278d? | 2007-11-14 A | 2008-12-05 | 80% | 55.6d? | 2007-11-14 | 2008-12-05 | 278d? | 275d | finish no earlier than 2008-12-05 | C1 | 2224h | 1779.2h | NBA | ALU | drage@alcatel-lucent.com | Rel-8 | Frederic | 24.229 |
| 196 | 47.5 | CT4 part of NASS Bundled Authentication | 143d? | 2007-11-14 A | 2008-05-30 A | 100% |  | 2007-11-14 | 2008-05-30 | 143d? |  | start no earlier than 2007-11-14 | C4 | 1144h | 1144h | NBA-CT4 | ALU |  | Rel-8 | Kimmo | 29.229, 29.228, 23.008 |
| 197 | 48 | **IMS System enhancements for corporate network access** | 395d? | 2007-06-22 A | 2008-12-25 | 28% | 284.1d? | 2007-06-22 | 2008-12-25 | 395d? | 261d |  | S2,S1,C1,C4 | 9204.8h | 2171.2h | IMS_Corp | Orange | Delphin Barankanira | Rel-8 | Maurice |  |
| 198 | 48.1 | SA1 aspects of IMS_Corp | 23.6d? | 2008-03-12 A | 2008-06-05 A | 100% |  | 2008-03-12 | 2008-06-05 | 23.6d? |  | finish no earlier than 2008-06-05 | S1 | 188.8h | 188.8h | IMS_Corp | Telecom Italia |  | Rel-8 | Alain |  |
| 199 | 48.2 | SA2 aspects of IMS_Corp | 395d? | 2007-06-22 A | 2008-12-25 | 15% | 335.75d? | 2007-06-22 | 2008-12-25 | 395d? | 261d | finish no earlier than 2008-12-25 | S2 | 3160h | 474h | IMS_Corp | Orange | Delphin Barankanira | Rel-8 | Maurice | 23.228 |
| 200 | 48.3 | CT1 aspects of IMS_Corp | 196d? | 2008-03-07 A | 2008-12-05 | 30% | 137.2d? | 2008-03-07 | 2008-12-05 | 196d? | 275d | finish no earlier than 2008-12-05 | C1 | 1568h | 470.4h | IMS_Corp | ALU | drage@alcatel-lucent.com | Rel-8 | Frederic | 24.229, 24.503 |
| 201 | 48.4 | CT4 aspects of IMS_Corp | 141d? | 2008-02-26 A | 2008-09-19 | 50% | 70.5d? | 2008-02-26 | 2008-09-19 | 141d? | 330d | finish no earlier than 2008-09-19 | C4 | 1128h | 564h | IMS_Corp | ALU | drage@alcatel-lucent.com | Rel-8 | Kimmo | 29.228, 29.229, 23.003, 23.008, 29.433 |
| 202 | 49 | **IMS Enhancements for support of Packet Cable access** | 388d? | 2006-12-06 A | 2008-05-30 A | 100% |  | 2006-12-06 | 2008-05-30 | 388d? |  |  | S2,S3,C1,C3,C4 | 27448h | 27448h | PktCbl | Cablelabs | Bernie McKibben | Rel-8 | Maurice |  |
| 203 | 49.1 | **IMS Enhancements for Cable Client Types and Deployment Models** | 345d? | 2007-02-05 A | 2008-05-30 A | 100% |  | 2007-02-05 | 2008-05-30 | 345d? |  |  | S2,C1 | 6992h | 6992h | PktCbl-Deploy | Cablelabs | Bernie McKibben | Rel-8 | Maurice |  |
| 204 | 49.1.1 | Architecture aspects of PktCbl-Deploy | 219d? | 2007-02-05 A | 2007-12-06 A | 100% |  | 2007-02-05 | 2007-12-06 | 219d? |  | finish no earlier than 2007-12-03 | S2 | 1752h | 1752h | PktCbl-Deploy | Cablelabs | Bernie McKibben | Rel-8 | Maurice | 23.228 |
| 205 | 49.1.2 | CT1 aspects of PktCbl-Deploy | 310d? | 2007-03-26 A | 2008-05-30 A | 100% |  | 2007-03-26 | 2008-05-30 | 310d? |  | finish no earlier than 2008-06-15 | C1 | 2480h | 2480h | PktCbl-Deploy | Cablelabs | D.Hancock@ CableLabs.com | Rel-8 | Frederic |  |
| 206 | 49.2 | **IMS Inter-working aspects in Support of Cable Regulatory requirements** | 290d? | 2007-02-05 A | 2008-03-15 A | 100% |  | 2007-02-05 | 2008-03-15 | 290d? |  |  | S2,C1,C3 | 5640h | 5640h | PktCbl-Intw | Cablelabs | B.McKibben@CableLabs.com | Rel-8 | Maurice |  |
| 207 | 49.2.1 | Architecture PktCbl-Interwork | 160d? | 2007-02-05 A | 2007-09-14 A | 100% |  | 2007-02-05 | 2007-09-14 | 160d? |  | start no earlier than 2007-02-05 | S2 | 1280h | 1280h | PktCbl-Intw | Cablelabs | B.McKibben@CableLabs.com | Rel-8 | Maurice | 23.228 |
| 208 | 49.2.2 | CT1,CT3 PktCbl-Interwork | 255d? | 2007-03-26 A | 2008-03-15 A | 100% |  | 2007-03-26 | 2008-03-15 | 255d? |  | finish no earlier than 2008-03-15 | C1,C3 | 2040h | 2040h | PktCbl-Intw | Cablelabs | D.Hancock@ CableLabs.com | Rel-8 | Frederic | 24.229 |
| 209 | 49.3 | **IMS Enhancements for Security Requirements in Support of Cable Deployments** | 388d? | 2006-12-06 A | 2008-05-30 A | 100% |  | 2006-12-06 | 2008-05-30 | 388d? |  |  | S3,C1,C3,C4 | 11712h | 11712h | PktCbl-Sec | Cablelabs | s.dotson@cablelabs.com | Rel-8 | Dionisio |  |
| 210 | 49.3.1 | SA3 Aspects of PktCbl-Sec | 331d? | 2006-12-06 A | 2008-03-12 A | 100% |  | 2006-12-06 | 2008-03-12 | 331d? |  | finish no earlier than 2007-12-20 | S3 | 2648h | 2648h | PktCbl-Sec | Cablelabs | s.dotson@cablelabs.com | Rel-8 | Dionisio | 33.203, 33.210, 33.220 |
| 211 | 49.3.2 | CT1 Aspects of PktCbl-Sec | 310d? | 2007-03-26 A | 2008-05-30 A | 100% |  | 2007-03-26 | 2008-05-30 | 310d? |  | finish no earlier than 2008-06-06 | C1 | 2480h | 2480h | PktCbl-Sec | Cablelabs | D.Hancock@ CableLabs.com | Rel-8 | Frederic | 24.229 |
| 212 | 49.3.3 | CT3 Aspects of PktCbl-Sec | 180d? | 2007-03-26 A | 2007-11-30 A | 100% |  | 2007-03-26 | 2007-11-30 | 180d? |  | finish no earlier than 2008-03-15 | C3 | 1440h | 1440h | PktCbl-Intw | Cablelabs | D.Hancock@ CableLabs.com | Rel-8 | Gwiho |  |
| 213 | 49.3.4 | CT4 Aspects of PktCbl-Sec | 255d? | 2007-03-26 A | 2008-03-14 A | 100% |  | 2007-03-26 | 2008-03-14 | 255d? |  | finish no earlier than 2008-03-14 | C4 | 2040h | 2040h | PktCbl-Sec | Cablelabs | D.Hancock@ CableLabs.com | Rel-8 | Kimmo | 29.228, 29.229, 23.008 |
| 214 | 50 | **Multimedia interworking between IMS and CS networks** | 846d? | 2005-09-23 A | 2008-12-19 | 93% | 60.7d? | 2005-09-23 | 2008-12-19 | 846d? | 265d |  | C3,C4 | 16312h | 9251.2h | MIW-IMS | Vodafone | nico.gabriele@vodafone.com | Rel-8 | Gwiho |  |
| 215 | 50.1 | Note: Stages 1 and 2 defined in earlier Release | 49d? | 2005-09-23 A | 2005-11-30 A | 100% |  | 2005-09-23 | 2005-11-30 | 49d? |  | start no earlier than 2005-09-23 | S2 | 392h | 392h | MIW-IMS | Vodafone | nico.gabriele@vodafone.com | Rel-8 | Maurice |  |
| 216 | 50.2 | Stage 3 of MW-IMS | 571d? | 2005-09-23 A | 2007-11-30 A | 100% |  | 2005-09-23 | 2007-11-30 | 571d? |  | finish no earlier than 2007-09-14 | C3 | 4568h | 4568h | MIW-IMS-St3 | Vodafone | nico.gabriele@vodafone.com | Rel-8 | Gwiho | 29.863, 29.163 |
| 217 | 50.3 | Stage 3 for MW-IMS, MONA extension | 290d? | 2007-11-05 A | 2008-12-12 | 90% | 29d? | 2007-11-05 | 2008-12-12 | 290d? | 270d | finish no earlier than 2008-12-12 | C3 | 2320h | 2088h | MIW-IMS | Vodafone | Christer.Holmberg@ericsson.com | Rel-8 | Gwiho | 29.863, 29.163 |
| 218 | 50.4 | Mn interface (MGCF – IM MGW) | 283d? | 2007-11-21 A | 2008-12-19 | 80% | 56.6d? | 2007-11-21 | 2008-12-19 | 283d? | 265d | finish no earlier than 2008-12-19 | C4 | 2264h | 1811.2h | MIW-IMS | Vodafone | Christer.Holmberg@ericsson.com | Rel-8 | Kimmo | 29.332 |
| 219 | 51 | IMS Stage-3 IETF Protocol Alignment | 387d? | 2007-06-22 A | 2008-12-15 | 85% | 58.05d? | 2007-06-22 | 2008-12-15 | 387d? | 269d | finish no earlier than 2008-12-15 | C1 | 3096h | 2631.6h | IMSProtoc2 | ALU | drage@alcatel-lucent.com | Rel-8 | Frederic | 23.218, 24.229 |

Notes:
- 191: SA#36 WID approved
- 192: SA#39: SA3 to remove Stage 3 from 33.178-100 for CTx work. SA#40 withdrawn 33.178-100.
- 193: SA#39: SA3 to remove Stage 3 from 33.178-100 for CT1 work
- 194: SA#39: SA3 to remove Stage 3 from 33.178-100 for CT1 work. 23/07/08 Stage 3 spli C1/4; Line created at CT1 Zagreb request
- 196: CT#40 completed
- 197: SA#40 SA2 proposed Rel-9 move. Rel-8 exception to Sep 2008 (await output of Workshop)
- 198: SA#40 completed
- 199: SA#40 SA2 proposed Rel-9 move. Rel-8 exception to Sep 2008 (await output of Workshop)
- 200: CP#39 WID approved
- 201: CP#39 WID approved
- 202: CT#40 completed
- 203: CT#40 completed
- 204: SA#38 completed
- 205: CT#40 completed
- 206: CT#39 completed
- 207: SA#37 completed
- 208: CT#39 completed
- 209: CT#40 completed
- 210: SA#39 completed
- 211: CT#40 completed
- 212: CT#38 completed
- 213: CT#39 completed
- 215: SA#31 Moved from FS section Feb 2006
- 216: Moved from R7 WP because it is part of Feature UID_713024. This feature was extended to R8 by the inclusion (at Nov 2007 CT3 meeting) of Stage 3 extension covering MONA (WI 380021)

| ID | WBS | Task | Type | Duration | Start | Finish | Complete | Remaining | Baseline start | Baseline finish | Baseline duration | Total slack | Constraint | Resources | Work | Actual work | Text1 | Text4 | Text5 | Text6 | Text8 |
| --- | --- | --- | --- | --- | --- | --- | --- | --- | --- | --- | --- | --- | --- | --- | --- | --- | --- | --- | --- | --- | --- |
| 220 | 52 | **3GPP2 Input to Common IMS** |  | 200d? | 2008-03-07 A | 2008-12-11 | 39% | 121.48d? | 2008-03-07 | 2008-12-11 | 200d? | 271d |  | S1,S2,S3,C1,C3,C4 | 8205.2h | 3221.36h | CIMS_3GPP2 | Nortel | Amar Deol | Rel-8 | Alain |
| 221 | 52.1 | Stage 1 CIMS_3GPP2 (SA1) |  | 30.65d? | 2008-03-12 A | 2008-06-05 A | 100% |  | 2008-03-12 | 2008-06-05 | 30.65d? |  | finish no earlier than 2008-06-12 | S1 | 245.2h | 245.2h | CIMS_3GPP2 | Nortel | Amar Deol | Rel-8 | Alain |
| 222 | 52.2 | Stage 2 CIMS_3GPP2 (SA2) |  | 62d? | 2008-03-12 A | 2008-06-05 A | 100% |  | 2008-03-12 | 2008-06-05 | 62d? |  | finish no earlier than 2008-09-11 | S2 | 496h | 496h | IMS_Common | Nortel | Amar Deol | Rel-8 | Maurice |
| 223 | 52.3 | Security CIMS_3GPP2 (SA3) |  | 197d? | 2008-03-12 A | 2008-12-11 | 30% | 137.9d? | 2008-03-12 | 2008-12-11 | 197d? | 271d | finish no earlier than 2008-12-11 | S3 | 1576h | 472.8h | IMS_Common |  |  | Rel-8 | Dionisio |
| 224 | 52.4 | Stage 3 CIMS_3GPP2 (CT1) |  | 200d? | 2008-03-07 A | 2008-12-11 | 76% | 48d? | 2008-03-07 | 2008-12-11 | 200d? | 271d | finish no earlier than 2008-12-11 | C1 | 1600h | 1216h | REDOC_3GPP2 | ALU | orsic@alcatel-lucent.com | Rel-8 | Frederic |
| 225 | 52.5 | Stage 3 CIMS_3GPP2 (CT3) |  | 136d? | 2008-03-07 A | 2008-09-12 | 15% | 115.6d? | 2008-03-07 | 2008-09-12 | 136d? | 335d | finish no earlier than 2008-09-12 | C3 | 1088h | 163.2h | REDOC_3GPP2 | ALU | orsic@alcatel-lucent.com | Rel-8 | Gwiho |
| 226 | 52.6 | Stage 3 CIMS_3GPP2 (CT4) |  | 200d? | 2008-03-07 | 2008-12-11 |  |  | 2008-03-07 | 2008-12-11 | 200d? | 271d | finish no earlier than 2008-12-11 | C4 | 1600h |  | REDOC_3GPP2 | ALU | orsic@alcatel-lucent.com | Rel-8 | Kimmo |
| 227 | 53 | **IMS Service Continuity** |  | 197d? | 2008-03-12 A | 2008-12-11 | 79% | 41.79d? | 2008-03-12 | 2008-12-11 | 197d? | 271d |  | S2,S1,C1 | 3688h | 2160h | IMS-Cont | LG Electronics | JaeSeung SONG (anthonys@lge.com) | Rel-8 | Maurice |
| 228 | 53.1 | Stage 1 IMS Service Continuity |  | 62d? | 2008-03-12 A | 2008-06-05 A | 100% |  | 2008-03-12 | 2008-06-05 | 62d? |  | start no earlier than 2008-03-12 | S1 | 496h | 496h | IMS-Cont | LG Electronics | JaeSeung SONG (anthonys@lge.com) | Rel-8 | Alain |
| 229 | 53.2 | Stage 2 IMS Service Continuity |  | 62d? | 2008-03-12 A | 2008-06-05 A | 100% |  | 2008-03-12 | 2008-06-05 | 62d? |  | finish no earlier than 2008-06-05 | S2 | 496h | 496h | IMS-Cont | LG Electronics | JaeSeung SONG (anthonys@lge.com) | Rel-8 | Maurice |
| 230 | 53.3 | Stage 3 IMS Service Continuity |  | 140d? | 2008-05-30 A | 2008-12-11 | 60% | 56d? | 2008-05-30 | 2008-12-11 | 140d? | 271d | finish no earlier than 2008-12-11 | C1 | 1120h | 672h | IMS-Cont | Huawei | kadyyang@huawei.com | Rel-8 | Maurice |
| 231 | 54 | IMS initiated and controlled PSS and MBMS User Service |  | 197d? | 2008-03-12 A | 2008-12-11 | 60% | 78.8d? | 2008-03-12 | 2008-12-11 | 197d? | 271d |  | S4,S3 | 1003.2h | 372.8h | IMS_PSS_MBMS_US | FT, Ericsson | olle.franceschi@ericsson.com | Rel-8 | Paolo |
| 232 | 55 | **IMS Restoration Procedures** |  | 142d? | 2008-05-30 A | 2008-12-15 | 43% | 81.65d? | 2008-05-30 | 2008-12-15 | 142d? | 269d |  | C4,C1 | 3408h | 1448.4h | IMS_RP | Ericsson | german.blanco@ericsson.com | Rel-8 | Kimmo |
| 233 | 55.1 | IMS Restoration Procedures |  | 142d? | 2008-05-30 A | 2008-12-15 | 85% | 21.3d? | 2008-05-30 | 2008-12-15 | 142d? | 269d | finish no earlier than 2008-12-15 | C4 | 1136h | 965.6h | IMS_RP | Ericsson | german.blanco@ericsson.com | Rel-8 | Kimmo |
| 234 | 55.2 | IMS Restoration Procedures |  | 142d? | 2008-05-30 | 2008-12-15 |  |  | 2008-05-30 | 2008-12-15 | 142d? | 269d | finish no earlier than 2008-12-15 | C1 | 1136h |  | IMS_RP | Ericsson | german.blanco@ericsson.com | Rel-8 | Frederic |
| 235 | 56 | **I-WLAN Network Selection Principle (NSP)** |  | 386d? | 2007-06-14 A | 2008-12-05 | 70% | 114.07d? | 2007-06-14 | 2008-12-05 | 386d? | 275d |  | S1,C1,C6 | 5091.2h | 1411.2h | IWLANNSP | Telefonica O2 | chris.friel@o2.com | Rel-8 | Alain |
| 236 | 56.1 | Stage 1 for I-WLAN NSP | milestone | 0d? | 2007-06-14 A | 2007-06-14 A | 100% |  | 2007-06-14 | 2007-06-14 | 0d? |  |  | S1 |  |  | IWLANNSP | Telefonica O2 | chris.friel@o2.com | Rel-8 | Alain |
| 237 | 56.2 | Stage 3 for I-WLAN NSP |  | 196d? | 2008-03-07 A | 2008-12-05 | 90% | 19.6d? | 2008-03-07 | 2008-12-05 | 196d? | 275d | finish no earlier than 2008-12-05 | C1 | 1568h | 1411.2h | IWLANNSP | RIM | Adrian Buckley (abuckley@rim.com) | Rel-8 | Frederic |
| 238 | 56.3 | Stage 3 for I-WLAN NSP |  | 54.4d? | 2008-03-07 | 2008-09-12 |  |  | 2008-03-07 | 2008-09-12 | 54.4d? | 335d | start no earlier than 2008-03-07 | C6 | 435.2h |  | IWLANNSP | RIM | Adrian Buckley (abuckley@rim.com) | Rel-8 | Frederic |
| 239 | 57 | **Mobility between 3GPP-WLAN Interworking and 3GPP Systems** |  | 326d? | 2007-09-14 A | 2008-12-12 | 87% | 41.66d? | 2007-09-14 | 2008-12-12 | 326d? | 270d |  | S2,C1 | 5256h | 4584.31h | IWLAN_Mob | Orange | xiaobao.chen@orange-ftgroup.com | Rel-8 | Maurice |
| 240 | 57.1 | Stage 2: I-WLAN Mobility |  | 190d? | 2007-09-14 A | 2008-06-05 A | 100% |  | 2007-09-14 | 2008-06-05 | 190d? |  | finish no earlier than 2008-09-08 | S2 | 1520h | 1520h | IWLAN_Mob | Orange | xiaobao.chen@orange-ftgroup.com | Rel-8 | Maurice |
| 241 | 57.2 | CT1 aspects of I-WLAN Mobility |  | 141d? | 2008-05-30 A | 2008-12-12 | 70% | 42.3d? | 2008-05-30 | 2008-12-12 | 141d? | 270d | finish no earlier than 2008-12-12 | C1 | 1128h | 789.6h | IWLAN_Mob | Orange | reina.nader@orange-ftgroup.com | Rel-8 | Frederic |
| 242 | 58 | **Enhancements for VGCS Applications (EVA)** |  | 713d? | 2006-03-15 A | 2008-12-05 | 98% | 12.89d? | 2006-03-15 | 2008-12-05 | 713d? | 275d |  | S1,C1,C4,G2 | 20216h | 15777.6h | EVA | Nortel | deola@nortel.com | Rel-8 | Alain |
| 243 | 58.1 | SA1 aspects of EVA |  | 191d? | 2006-03-15 A | 2006-12-06 A | 100% |  | 2006-03-15 | 2006-12-06 | 191d? |  | finish no earlier than 2006-12-06 | S1 | 1528h | 1528h | EVA-s1 | Nortel | deola@nortel.com | Rel-8 | Alain |
| 244 | 58.2 | VGCS/VBS and GPRS Interactions |  | 145d? | 2007-09-03 A | 2008-03-21 A | 100% |  | 2007-09-03 | 2008-03-21 | 145d? |  | finish no earlier than 2008-03-21 | S1 | 1160h | 1160h | EVA | Huawei | Ling Liu | Rel-8 | Alain |
| 245 | 58.3 | CT1 aspects of EVA |  | 656d? | 2006-06-02 A | 2008-12-05 | 95% | 32.8d? | 2006-06-02 | 2008-12-05 | 656d? | 275d | finish no earlier than 2008-12-05 | C1 | 5248h | 4985.6h | EVA | Nortel | milanpa@nortel.com | Rel-8 | Frederic |
| 246 | 58.4 | CT4 aspects of EVA |  | 391d? | 2006-06-02 A | 2007-11-30 A | 100% |  | 2006-06-02 | 2007-11-30 | 391d? |  | finish no earlier than 2007-06-01 | C4 | 3128h | 3128h | EVA | Nortel |  | Rel-8 | Kimmo |
| 247 | 58.5 | GERAN2 aspects of EVA |  | 431d? | 2006-06-30 A | 2008-02-22 A | 100% |  | 2006-06-30 | 2008-02-22 | 431d? |  | finish no earlier than 2008-02-22 | G2 | 3448h | 3448h | EVA-EVGCSA | Nortel | frank.billenkamp@nortel.com | Rel-8 | Gert |

Notes:
- 220: SA#39 WID approved. SA#40 Stage 1/2 completed
- 221: SA#39 WID approved & Stage 1 exception Jun 2008. SA#40 completed / Text3: 22.228, 22.173, 22.101, 22.153
- 222: SA#39 WID approved. SA#40 completed / Text3: 23.002, 23.141, 23.203, 23.167, 23.228
- 223: SA#39 WID approved. SA#40 exception to Sep 2008. / Text3: 33.141, 33.203, 33.210
- 224: CT#39 WID approved. CT1 approved CRs with REDOC_3GPP2 / Text3: 23.218, 24.141, 24.147, 24.229, 24.238, 24.247, 24.604, 24.605, 24.606, 24.607, 24.608, 24.610, 24.611, 24.629, 24.930
- 225: CT#39 WID approved / Text3: 29.163, 29.212, 29.213, 29.214
- 226: CT#39 WID approved / Text3: 29.228, 29.229, 29.328, 29.329
- 227: SA#40 Stage 1/2 completed. CT#40 WID approved
- 228: SA#40 completed
- 229: SA#40 completed / Text3: 23.237, 23.292
- 230: CT#40 WID approved / Text3: 24.237, 24.229
- 231: SA#39 WID approved / Text3: 26.xyz, 26.234, 26.346, 33.246
- 232: CT#40 WID approved. Triggered by Study TR 23.820 (FS_IMS_RP) UID_350018
- 233: CT#40 WID approved. / Text3: 23.380, 29.228, 29.229, 29.230
- 234: CT#40 WID approved. / Text3: 24.229
- 235: SA#36 Stage 1 completed
- 236: SA#36 completed / Text3: 22.234
- 237: 08/08 az split CT1 from CT6 part in WID / Text3: 24.234
- 238: 08/08 az created to reflect CT6 part in WID / Text3: 31.102, 31.111
- 239: SA#40 Stage 2 completed. CT#40 WID approved
- 240: SA#40 completed / Text3: 23.234
- 241: CT#40 WID approved / Text3: 24.327, 24.303
- 242: Stage 1/2 completed
- 243: SA#38 completed / Text3: 42.068
- 244: SA#39 completed / Text3: 42.068, 42.069
- 245: 06/08=>09/08 / Text3: 43.068, 44.068
- 246: CT#38 completed / Text3: 29.002
- 247: GP#37 completed / Text3: 44.018, 48.008

| ID | WBS | Task | Type | Duration | Start | Finish | Complete | Remaining | Baseline start | Baseline finish | Baseline duration | Total slack | Constraint | Resources | Work | Actual work | Text1 | Text4 | Text5 | Text6 | Text8 | Text3 | Text12 |
| --- | --- | --- | --- | --- | --- | --- | --- | --- | --- | --- | --- | --- | --- | --- | --- | --- | --- | --- | --- | --- | --- | --- | --- |
| 248 | 59 | **Personal Network Management** |  | 890d? | 2005-07-11 A | 2008-12-05 | 83% | 153.58d? | 2005-07-11 | 2008-12-05 | 890d? | 275d |  | S1,C1,C4,S3 | 22760h | 11946.4h | PNM | Vodafone | armin.toepfer@vodafone.com | Rel-8 | Alain |  |  |
| 249 | 59.1 | Stage 1 for PNM |  | 276d? | 2005-07-11 A | 2006-07-31 A | 100% |  | 2005-07-11 | 2006-07-31 | 276d? |  | start no earlier than 2005-07-11 | S1 | 2208h | 2208h | PNM | Vodafone | armin.toepfer@vodafone.com | Rel-8 | Alain | 22.259 |  |
| 250 | 59.2 | Stage 2 for PNM |  | 445d? | 2007-03-26 A | 2008-12-05 | 96% | 17.8d? | 2007-03-26 | 2008-12-05 | 445d? | 275d | finish no earlier than 2008-12-05 | C1 | 3560h | 3417.6h | PNM | Vodafone | yang.lu@vodafone.com | Rel-8 | Frederic | 23.259 |  |
| 251 | 59.3 | **Stage 3 for PNM** |  | 445d? | 2007-03-26 A | 2008-12-05 | 65% | 155.7d? | 2007-03-26 | 2008-12-05 | 445d? | 275d |  | C1,C4 | 10200h | 4440.8h | PNM | Vodafone | yang.lu@vodafone.com | Rel-8 | Frederic |  |  |
| 252 | 59.3.1 | CT1 aspects of Stage 3 PNM |  | 445d? | 2007-03-26 A | 2008-12-05 | 78% | 97.9d? | 2007-03-26 | 2008-12-05 | 445d? | 275d | finish no earlier than 2008-12-05 | C1 | 3560h | 2776.8h | PNM | Vodafone | yang.lu@vodafone.com | Rel-8 | Frederic | 24.259, 24.229 |  |
| 253 | 59.3.2 | CT4 aspects of Stage 3 PNM |  | 385d? | 2007-03-26 A | 2008-09-12 | 50% | 192.5d? | 2007-03-26 | 2008-09-12 | 385d? | 335d | finish no earlier than 2008-09-12 | C4 | 3080h | 1540h | PNM | Vodafone | yang.lu@vodafone.com | Rel-8 | Kimmo | 23.008, 23.018, 29.002, 29.328, 29.329 |  |
| 254 | 59.4 | Key establishment between a UICC hosting device and a remote device |  | 235d? | 2006-12-06 A | 2007-10-30 A | 100% |  | 2006-12-06 | 2007-10-30 | 235d? |  | finish no earlier than 2007-10-30 | S3 | 1880h | 1880h | PNM | Ericsson | Vesa.Lehtovirta@ericsson.com | Rel-7 | Michael | 33.259 |  |
| 255 | 59.5 | Deleted - Actual Requirements of PNM | milestone | 0d? | 2007-03-26 A | 2007-03-26 A | 100% |  | 2007-03-26 | 2007-03-26 | 0d? |  | finish no earlier than 2007-03-26 | C1 |  |  | PNM | Ericsson |  | Rel-8 | Frederic |  | SP-37 |
| 256 | 60 | **eCall Data Transfer** |  | 577d? | 2006-09-28 A | 2008-12-12 | 84% | 93.69d? | 2006-09-28 | 2008-12-12 | 577d? | 270d |  | S1,C1 | 8784h | 6531.2h | Edata | Airbiquity | rrobinson@airbiquity.com | Rel-8 | Alain |  |  |
| 257 | 60.1 | eData Requirements |  | 380d? | 2006-09-28 A | 2008-03-12 A | 100% |  | 2006-09-28 | 2008-03-12 | 380d? |  | finish no earlier than 2006-12-07 | S1 | 3040h | 3040h | EData | Airbiquity | rrobinson@airbiquity.com | Rel-8 | Alain | 22.101, 22.105 |  |
| 258 | 60.2 | Transfer of data during an emergency call |  | 141d? | 2008-05-30 A | 2008-12-12 | 40% | 84.6d? | 2008-05-30 | 2008-12-12 | 141d? | 270d | start no earlier than 2008-05-30 | C1 | 1128h | 451.2h | EData | T-Mobile | Dieter Jacobsohn | Rel-8 | Kimmo | 24.008 |  |
| 259 | 61 | eCall data transfer Phase 2: Comparison of alternative in-band modem solutions and standardization of one in-band modem solution |  | 391d? | 2007-12-06 A | 2009-06-04 | 80% | 78.2d? | 2007-12-06 | 2009-06-04 | 391d? | 146d | finish no earlier than 2009-06-04 | S4 | 3128h | 2502.4h | eCall_Phase2 | Airbiquity | lhong@airbiquity.com & rrobinson@airbiquity.com | Rel-8 | Paolo | 26.xxx, 26.967 |  |
| 260 | 62 | **IP Interconnection of Services** |  | 70d? | 2007-12-06 A | 2008-03-12 A | 100% |  | 2007-12-06 | 2008-03-12 | 70d? |  |  | S1 | 1120h | 1120h | IPinterc | Telefonica O2 | chris.friel@O2.com | Rel-8 | Alain | 22.101, 22.228 |  |
| 261 | 62.1 | Stage 1 for IPinterc |  | 70d? | 2007-12-06 A | 2008-03-12 A | 100% |  | 2007-12-06 | 2008-03-12 | 70d? |  | start no earlier than 2007-12-06 | S1 | 560h | 560h | IPinterc | Telefonica O2 | chris.friel@O2.com | Rel-8 | Alain | 22.101, 22.228 |  |
| 262 | 63 | **Support of (G)MSC-S – (G)MSC-S Nc Interface based on the SIP-I protocol** |  | 326d? | 2007-09-14 A | 2008-12-12 | 52% | 155.25d? | 2007-09-14 | 2008-12-12 | 326d? | 270d |  | C4,C3 | 16152h | 6940.89h | SIP_Nc | Vodafone | David.Hutton@vodafone.com | Rel-8 | Kimmo |  |  |
| 263 | 63.1 | Stage 1 for SIP_Nc (covered by Feature IPinterc) |  | 70d? | 2007-12-06 A | 2008-03-12 A | 100% |  | 2007-12-06 | 2008-03-12 | 70d? |  | start no earlier than 2007-12-06 | S1 | 560h | 560h | IPinterc | Telefonica O2 | chris.friel@O2.com | Rel-8 | Alain | 22.101, 22.228 |  |
| 264 | 63.2 | SIP-I based circuit-switched core network; Stage 2 |  | 261d? | 2007-09-14 A | 2008-09-12 | 95% | 13.05d? | 2007-09-14 | 2008-09-12 | 261d? | 335d | finish no earlier than 2008-09-12 | C4 | 2088h | 1983.6h | SIP_Nc-St2 | Vodafone | David.Hutton@vodafone.com | Rel-8 | Kimmo | 23.231, 23.153, 23.205 |  |
| 265 | 63.3 | Application of SIP-I Protocols to Circuit Switched (CS) core network architecture; Stage 3 |  | 261d? | 2007-09-14 A | 2008-09-12 | 85% | 39.15d? | 2007-09-14 | 2008-09-12 | 261d? | 335d | finish no earlier than 2008-09-12 | C4 | 2088h | 1774.8h | SIP_Nc-St3 | Vodafone | David.Hutton@vodafone.com | Rel-8 | Kimmo | 29.231, 29.232, 29.332 |  |
| 266 | 63.4 | Interworking between the 3GPP CS domain with SIP-I as signalling protocol and other networks |  | 326d? | 2007-09-14 A | 2008-12-12 | 45% | 179.3d? | 2007-09-14 | 2008-12-12 | 326d? | 270d | finish no earlier than 2008-12-12 | C3 | 2608h | 1173.6h | SIP_Nc | NSN | Thomas.Belling@nsn.com | Rel-8 | Gwiho | 29.235, 23.172, 23.202, 29.007, 29.163, 29.414 |  |
| 267 | 63.5 | **CS-IBCF and CS-TrGW definition in 3GPP specifications** |  | 267d? | 2007-12-06 A | 2008-12-12 | 20% | 213.77d? | 2007-12-06 | 2008-12-12 | 267d? | 270d |  | C3,C4 | 6200h | 1236.09h | CS-IBCF | Telecom Italia | mauro.ficaccio@telecomitalia.it | Rel-8 | Kimmo |  |  |
| 268 | 63.5.1 | Stage 1 for CS-IBCF (covered by Feature IPinterc) |  | 70d? | 2007-12-06 A | 2008-03-12 A | 100% |  | 2007-12-06 | 2008-03-12 | 70d? |  | start no earlier than 2007-12-06 | S1 | 560h | 560h | IPinterc | Telefonica O2 | chris.friel@O2.com | Rel-8 | Alain | 22.101, 22.228 |  |
| 269 | 63.5.2 | CT3 aspects CS-IBCF |  | 141d? | 2008-05-30 A | 2008-12-12 | 30% | 98.7d? | 2008-05-30 | 2008-12-12 | 141d? | 270d | finish no earlier than 2008-12-12 | C3 | 1128h | 338.4h | CS-IBCF | Telecom Italia | mauro.ficaccio@telecomitalia.it | Rel-8 | Kimmo | 29.235 |  |
| 270 | 63.5.3 | CT4 aspects CS-IBCF |  | 141d? | 2008-05-30 | 2008-12-12 |  |  | 2008-05-30 | 2008-12-12 | 141d? | 270d | finish no earlier than 2008-12-12 | C4 | 1128h |  | CS-IBCF | Telecom Italia | mauro.ficaccio@telecomitalia.it | Rel-8 | Kimmo | 29.238, 23.231, 29.232 |  |
| 271 | 63.5.4 | IMS-IBCF –TrGW definitions in 3GPP |  | 141d? | 2008-05-30 A | 2008-12-12 | 5% | 133.95d? | 2008-05-30 | 2008-12-12 | 141d? | 270d | finish no earlier than 2008-12-12 | C4 | 1128h | 56.4h | IMS-IBCF | Alcatel-Lucent | bruno.landais@alcatel-lucent.fr | Rel-8 | Kimmo | 29.238 |  |
| 272 | 63.5.5 | ALGCF – IMA-MGW definitions in 3GPP |  | 141d? | 2008-05-30 A | 2008-12-12 | 5% | 133.95d? | 2008-05-30 | 2008-12-12 | 141d? | 270d | finish no earlier than 2008-12-12 | C4 | 1128h | 56.4h | AGCF | Alcatel-Lucent | bruno.landais@alcatel-lucent.fr | Rel-8 | Kimmo | 29.xxx |  |

Notes:
- 248: Feb 06 moved FS=>Feature. SA#31 Stage 1 completed. SA#40 WID updated with reduced scope SP-060574=>SP-080327
- 249: SA#31 completed. SA#40 WID updated SP-060574=>SP-080327
- 251: Moved from FS section Feb 06: SP-33: Create new section to capture the PNM stage 2 aspects and identify any impacts to existing stage 2 specifications.
- 254: 07/08: Moved from Rel-7 to Rel-8 WP; Feature=>BB as per SA3/SA WID in SP-060839, keeping the same UID
- 255: SA#37 stopped
- 256: SA#39 completed. Linked to SA4 Feature UID_34042 (eCall_Phase2). CT#40 approved Stage 3 WID.
- 257: SA4 to select a suitable in-band modem. SA#39 completed
- 258: CT#40 WID approved
- 259: Triggered by Study UID_360015 (eCALLIBMS). Linked to SA1 Feature UID_330005 (EData)
- 260: Inform GSMA of progress. SA#39 Stage 1 completed. Covers Stage 1 for IMS_NNI (UID 360024), SIP_Nc (UID 360026) , CS-IBCF (UID 400008).
- 261: SA#39 completed
- 262: Stage 1 in Feature UID_380060 (IPinterc). CT#40 updated WID CP-070517=>CP-080282
- 263: 22/07/08 Created. Stage 1 for SIP_Nc (covered by SA1 Feature 380060 Ipinterc)
- 264: CT#40 updated WID CP-070517=>CP-080282
- 265: CT#40 updated WID CP-070517=>CP-080282
- 266: CT#40 updated WID CP-070517=>CP-080282
- 267: Stage 1 in Feature UID_380060 (IPinterc). CT#40 WID approved.
- 268: 22/07/08 Created. Stage 1 for CS-IBCF (covered by SA1 Feature 380060 Ipinterc)
- 269: CT#40 WID approved
- 270: CT#40 WID approved
- 271: CT#40 WID approved
- 272: CT#40 WID approved

| ID | WBS | Task | Type | Duration | Start | Finish | Complete | Remaining | Baseline start | Baseline finish | Baseline duration | Total slack | Constraint | Resources | Work | Actual work | Text1 | Text4 | Text5 | Text6 | Text8 | Text3 | Text7 |
| --- | --- | --- | --- | --- | --- | --- | --- | --- | --- | --- | --- | --- | --- | --- | --- | --- | --- | --- | --- | --- | --- | --- | --- |
| 273 | 64 | **Earthquake and Tsunami Warning System** |  | 325d? | 2007-09-10 A | 2008-12-05 | 89% | 37.11d? | 2007-09-10 | 2008-12-05 | 325d? | 275d |  | S1,S2,C1 | 4900h | 3101.4h | ETWS | NTT DoCoMo | kitaharar@nttdocomo.co.jp | Rel-8 | Alain |  |  |
| 274 | 64.1 | Stage 1 for ETWS |  | 133d? | 2007-09-10 A | 2008-03-12 A | 100% |  | 2007-09-10 | 2008-03-12 | 133d? |  | finish no earlier than 2008-03-12 | S1 | 1064h | 1064h | ETWS | NTT DoCoMo | kitaharar@nttdocomo.co.jp | Rel-8 | Alain | 22.168 |  |
| 275 | 64.2 | SA2 aspects of ETWS |  | 104d? | 2008-01-14 A | 2008-06-05 A | 100% |  | 2008-01-14 | 2008-06-05 | 104d? |  | finish no earlier than 2008-09-08 | S2 | 832h | 832h | ETWS | NTT DoCoMo | tanakai@nttdocomo.co.jp | Rel-8 | Maurice | 23.828 |  |
| 276 | 64.3 | CT1 aspects of ETWS |  | 50.5d? | 2008-05-30 A | 2008-12-05 | 35% | 32.83d? | 2008-05-30 | 2008-12-05 | 50.5d? | 275d | finish no earlier than 2008-12-05 | C1 | 404h | 141.4h | ETWS | NTT DoCoMo | yamashitahi@s1.nttdocomo.co.jp | Rel-8 | Kimmo | 23.041 |  |
| 277 | 65 | **Storage and easy access of In Case of Emergency numbers on UICC** |  | 454d? | 2007-03-13 A | 2008-12-05 | 37% | 287.87d? | 2007-03-13 | 2008-12-05 | 454d? | 275d |  | S1,C6 | 7824h | 2862.97h | ICE | Vodafone | armin.toepfer@vodafone.com | Rel-8 | Alain |  |  |
| 278 | 65.1 | Storage and easy access of In Case of Emergency numbers on UICC |  | 262d? | 2007-03-13 A | 2008-03-12 A | 100% |  | 2007-03-13 | 2008-03-12 | 262d? |  | finish no earlier than 2008-03-12 | S1 | 2096h | 2096h | ICE | Vodafone | armin.toepfer@vodafone.com | Rel-8 | Alain | 22.030, 22.101 |  |
| 279 | 65.2 | Storage and easy access of In Case of Emergency numbers on UICC |  | 454d? | 2007-03-13 | 2008-12-05 |  |  | 2007-03-13 | 2008-12-05 | 454d? | 275d | finish no earlier than 2008-12-05 | C6 | 3632h |  | ICE | Vodafone |  | Rel-8 | Alain | 31.101, 31.102 |  |
| 280 | 66 | Local Charging Zone Requirements |  | 380d? | 2006-09-28 A | 2008-03-12 A | 100% |  | 2006-09-28 | 2008-03-12 | 380d? |  | finish no earlier than 2006-12-07 | S1 | 3040h | 3040h | LCZR | China Mobile | liuhongyfw@chinamobile.com | Rel-8 | Alain | 22.115 |  |
| 281 | 67 | **Customized Alerting Tone (CAT) Service** |  | 523d? | 2006-12-06 A | 2008-12-05 | 61% | 203.46d? | 2006-12-06 | 2008-12-05 | 523d? | 275d |  | S1,C1,C3 | 9198.4h | 5620h | CAT | China Mobile | fenglingjuan@chinamobile.com | Rel-8 | Alain |  |  |
| 282 | 67.1 | Stage 1 for CAT |  | 207d? | 2006-12-06 A | 2007-09-20 A | 100% |  | 2006-12-06 | 2007-09-20 | 207d? |  | start no earlier than 2006-12-06 | S1 | 1656h | 1656h | CAT | China Mobile | fenglingjuan@chinamobile.com | Rel-8 | Alain | 22.182 |  |
| 283 | 67.2 | TISPAN requirements for customized multimedia information services |  | 71d? | 2007-09-03 A | 2007-12-10 A | 100% |  | 2007-09-03 | 2007-12-10 | 71d? |  | finish no earlier than 2007-12-10 | S1 | 568h | 568h | TISCMI | China Mobile | Feng Lingjuan | Rel-8 | Alain | 22.182 |  |
| 284 | 67.3 | IMS CAT Supplementary Service |  | 164d? | 2008-01-30 A | 2008-12-05 | 64% | 59.04d? | 2008-01-30 | 2008-12-05 | 164d? | 276d | finish no earlier than 2008-12-05 | C1 | 1312h | 839.68h | CAT_SS | Nortel | milanpa@nortel.com | Rel-8 | Frederic | 24.182 |  |
| 285 | 67.4 | CAT solution for voice and video call in CS domain |  | 184.8d? | 2008-03-12 | 2008-12-05 |  |  | 2008-03-12 | 2008-12-05 | 184.8d? | 275d | finish no earlier than 2008-12-05 | C3 | 1478.4h |  | CAT | Ericsson |  | Rel-8 | Gwiho |  |  |
| 286 | 68 | **Service-Level Interworking for Messaging Services** |  | 449d? | 2007-03-26 A | 2008-12-12 | 64% | 161.69d? | 2007-03-26 | 2008-12-12 | 449d? | 270d |  | S1,S2,C3,C1 | 7664h | 2605.6h | MESSIW | Huawei | ling.liu@huawei.com; duanxiaoqin@huawei.com | Rel-8 | Alain |  |  |
| 287 | 68.1 | Stage 1 for MESSIW | milestone | 0d? | 2007-03-26 A | 2007-03-26 A | 100% |  | 2007-03-26 | 2007-03-26 | 0d? |  | finish no earlier than 2007-12-01 | S1 |  |  | MESSIW | Huawei | ling.liu@huawei.com | Rel-8 | Alain | 22.105, 22.340 |  |
| 288 | 68.2 | Stage 2 for MESSIW |  | 227d? | 2007-04-26 A | 2008-03-07 A | 100% |  | 2007-04-26 | 2008-03-07 | 227d? |  | finish no earlier than 2008-03-07 | S2 | 1816h | 1816h | MESSIW | Huawei | patrice.hede@huawei.com | Rel-8 | Maurice | 23.811, 23.204 |  |
| 289 | 68.3 | Stage 3 for MESSIW |  | 141d? | 2008-05-30 A | 2008-12-12 | 70% | 42.3d? | 2008-05-30 | 2008-12-12 | 141d? | 270d | finish no earlier than 2008-12-12 | C3 | 1128h | 789.6h | MESSIW | Huawei | xupeili@huawei.com | Rel-8 | Gwiho | 29.331 |  |
| 290 | 68.4 | Stage 3 for MESSIW |  | 141d? | 2008-05-30 | 2008-12-12 |  |  | 2008-05-30 | 2008-12-12 | 141d? | 270d | finish no earlier than 2008-12-12 | C1 | 1128h |  | MESSIW | Huawei | xupeili@huawei.com | Rel-8 | Frederic | 29.331, 24.341 |  |
| 291 | 69 | **Multimedia Priority Service** |  | 652d? | 2006-06-08 A | 2008-12-05 | 45% | 360.02d? | 2006-06-08 | 2008-12-05 | 652d? | 275d |  | S1,C1,C3,C4 | 17128h | 7670.22h | PRIOR | Telcordia | jgarraha@telcordia.com | Rel-8 | Alain |  |  |
| 292 | 69.1 | Service Requirements for PRIOR |  | 391d? | 2006-06-08 A | 2007-12-06 A | 100% |  | 2006-06-08 | 2007-12-06 | 391d? |  | finish no earlier than 2007-11-30 | S1 | 3128h | 3128h | PRIOR-EMR | Telcordia | jgarraha@telcordia.com | Rel-8 | Alain | 22.153 |  |
| 293 | 69.2 | Stage 3 for PRIOR |  | 526d? | 2006-12-01 A | 2008-12-05 | 50% | 263d? | 2006-12-01 | 2008-12-05 | 526d? | 275d | finish no earlier than 2008-12-05 | C1 | 4208h | 2104h | PRIOR-MM | ALU | drage@alcatel-lucent.com | Rel-8 | Frederic | 24.229 |  |
| 294 | 69.3 | Stage 3 for PRIOR |  | 316d? | 2007-09-21 | 2008-12-05 |  |  | 2007-09-21 | 2008-12-05 | 316d? | 275d | finish no earlier than 2008-12-05 | C3 | 2528h |  | PRIOR-MM | ALU | drage@alcatel-lucent.com | Rel-8 | Gwiho | 29.212, 29.213, 29.214, 29.163 |  |
| 295 | 69.4 | Stage 3 for PRIOR |  | 256d? | 2007-09-21 A | 2008-09-12 | 5% | 243.2d? | 2007-09-21 | 2008-09-12 | 256d? | 335d | finish no earlier than 2008-09-12 | C4 | 2048h | 102.4h | PRIOR-MM | Alcatel-Lucent | drage@alcatel-lucent.com | Rel-8 | Kimmo | 23.008, 29.228, 29.229 |  |
| 296 | 70 | **OSA Rel-8** |  | 202d? | 2007-08-23 A | 2008-05-30 A | 100% |  | 2007-08-23 | 2008-05-30 | 202d? |  |  | S1,C5 | 23552h | 23552h | OSA8 | Orange | Song Dong | Rel-8 | Alain |  | TSG |
| 297 | 70.1 | OSA Stage 1 - Service Requirements |  | 145d? | 2007-08-23 A | 2008-03-12 A | 100% |  | 2007-08-23 | 2008-03-12 | 145d? |  | finish no earlier than 2007-12-04 | S1 | 1160h | 1160h | OSA8 | Orange, AePONA | Song Dong | Rel-8 | Alain | 22.127 | TSG |
| 298 | 70.2 | OSA Stage 1 - NGN Service Requirement |  | 140d? | 2007-09-03 A | 2008-03-14 A | 100% |  | 2007-09-03 | 2008-03-14 | 140d? |  | finish no earlier than 2008-03-14 | S1 | 1120h | 1120h | OSA8-IMS | Orange | Song Dong | Rel-8 | Alain | 22.127 |  |

Notes:
- 273: SA#38 WID approved. Larger scope Feature UID_380057 (PWS) moved to Rel-9. Stage 1 completed. No SA2 impact. CT#40 WID approved
- 274: SA#39 completed
- 275: SA#38 WID approved. SA#40 exception to Sep 2008 on impacts from adding the CBC to MME interface
- 276: CT#40 WID approved
- 277: SA#39 Stage 1 completed
- 278: SA#39 Stage 1 completed
- 279: 23/07/08 Created to host CT6 work as per SA1 WID
- 280: SA#39 Stage 1 completed
- 281: Conflict 3GPP vs. 3GPP2 IMS CAT. SA#40 exception to Sep 2008 for SA2 (Forking, Early session model)
- 282: Conflict 3GPP vs. 3GPP2 IMS CAT
- 283: SA#38 completed
- 285: Based on conclusion of Study UID_360031 (FS_CAT_VVC_CS)
- 286: SA#39 Stage 2 completed. CT#40 added New Stage 3 WID.
- 287: SA#35 completed
- 288: SA#39 completed
- 289: CT#40 WID approved
- 290: CT#40 WID approved
- 291: SA#38 Stage 1 completed. No Stage 2 identified
- 292: SA#38 completed
- 296: TSG#40 completed. New OSA work in OMA. SA1 need to remove unfulfilled Requirements to align with CT5 Stage 2/3 reality.
- 297: TSG#40 New OSA work in OMA. SA1 to remove non-fulfilled Requirements.
- 298: TSG#40 New OSA work in OMA. SA1 to remove non-fulfilled Requirements.

| ID | WBS | Task | Duration | Start | Finish | Complete | Remaining | Baseline start | Baseline finish | Baseline duration | Total slack | Constraint | Resources | Work | Actual work | Text1 | Text3 | Text4 | Text5 | Text6 | Text8 | Text12 |
| --- | --- | --- | --- | --- | --- | --- | --- | --- | --- | --- | --- | --- | --- | --- | --- | --- | --- | --- | --- | --- | --- | --- |
| 299 | 70.3 | **OSA Stage 2/3 enhancements** | 157d? | 2007-10-25 A | 2008-05-30 A | 100% |  | 2007-10-25 | 2008-05-30 | 157d? |  |  | C5 | 20016h | 20016h | OSA8 | 23.198, 29.198, 29.199 | Orange | salim.mouniralaoui@orange-ftgroup.com | Rel-8 | Gwiho |  |
| 300 | 70.3.1 | Delete - Ensure Parlay-X composable with identity management frameworks, in particular Liberty Alliance | 157d? | 2007-10-25 A | 2008-05-30 A | 100% |  | 2007-10-25 | 2008-05-30 | 157d? |  | finish no earlier than 2008-12-25 | C5 | 1256h | 1256h | OSA8 | existing 29.199-xy | Ericsson, FT/Orange, Sprint, Telecom Italia | catherine.mulligan@ericsson.com | Rel-8 | Gwiho | CP-40 |
| 301 | 70.3.2 | Parlay-X Content Management web service (store/manage meta-data) | 157d? | 2007-10-25 A | 2008-05-30 A | 100% |  | 2007-10-25 | 2008-05-30 | 157d? |  | finish no earlier than 2008-12-04 | C5 | 1256h | 1256h | OSA8 | 29.199-21 | ETRI | Yoo, Hyunkyung (hkyoo@etri.re.kr) | Rel-8 | Gwiho |  |
| 302 | 70.3.3 | Parlay-X Policy web service | 157d? | 2007-10-25 A | 2008-05-30 A | 100% |  | 2007-10-25 | 2008-05-30 | 157d? |  | finish no earlier than 2008-12-04 | C5 | 1256h | 1256h | OSA8 | 29.199-22 | ETRI | Park, Yoo-mi ( parkym@etri.re.kr) | Rel-8 | Gwiho |  |
| 303 | 70.3.4 | Parlay-X Terminal status web service | 157d? | 2007-10-25 A | 2008-05-30 A | 100% |  | 2007-10-25 | 2008-05-30 | 157d? |  | finish no earlier than 2008-05-30 | C5 | 1256h | 1256h | OSA8 | 29.199-08 | Orange | salim.mouniralaoui@orange-ftgroup.com | Rel-8 | Gwiho |  |
| 304 | 70.3.5 | Delete - Identify communication format used by a particular application | 157d? | 2007-10-25 A | 2008-05-30 A | 100% |  | 2007-10-25 | 2008-05-30 | 157d? |  | finish no earlier than 2008-05-30 | C5 | 1256h | 1256h | OSA8 | existing 29.199-xy | Ericsson | catherine.mulligan@ericsson.com | Rel-8 | Gwiho | CP-40 |
| 305 | 70.3.6 | Delete - Security on User Profile Management - reuse GUP API (22.127 CR 0084 S1-071794) | 128d? | 2007-12-05 A | 2008-05-30 A | 100% |  | 2007-12-05 | 2008-05-30 | 128d? |  | finish no earlier than 2008-12-25 | C5 | 1024h | 1024h | OSA8 | PXWS Framework | Telecom Italia | vincenzo.amorino@telecomitalia.it | Rel-8 | Gwiho | CP-40 |
| 306 | 70.3.7 | Delete - Privacy on Subscriber Identity (Liberty Alliance, OASIS) (22.127 CR 0085 S1-071835) | 128d? | 2007-12-05 A | 2008-05-30 A | 100% |  | 2007-12-05 | 2008-05-30 | 128d? |  | finish no earlier than 2008-12-25 | C5 | 1024h | 1024h | OSA8 | PXWS Framework | Telecom Italia | vincenzo.amorino@telecomitalia.it | Rel-8 | Gwiho | CP-40 |
| 307 | 70.3.8 | Delete - Topology Hiding (22.127 CR 0086 S1-071838) | 128d? | 2007-12-05 A | 2008-05-30 A | 100% |  | 2007-12-05 | 2008-05-30 | 128d? |  | finish no earlier than 2008-12-25 | C5 | 1024h | 1024h | OSA8 | PXWS Framework | Telecom Italia | vincenzo.amorino@telecomitalia.it | Rel-8 | Gwiho | CP-40 |
| 308 | 70.3.9 | Delete - Subscriber event notification (22.127 CR 0087 S1-071836) | 128d? | 2007-12-05 A | 2008-05-30 A | 100% |  | 2007-12-05 | 2008-05-30 | 128d? |  | finish no earlier than 2008-12-25 | C5 | 1024h | 1024h | OSA8 | PXWS Framework | Telecom Italia | vincenzo.amorino@telecomitalia.it | Rel-8 | Gwiho | CP-40 |
| 309 | 70.3.10 | Delete - Event notification (22.127 CR 0088 S1-071762) | 128d? | 2007-12-05 A | 2008-05-30 A | 100% |  | 2007-12-05 | 2008-05-30 | 128d? |  | finish no earlier than 2008-12-25 | C5 | 1024h | 1024h | OSA8 | PXWS Framework | Telecom Italia | vincenzo.amorino@telecomitalia.it | Rel-8 | Gwiho | CP-40 |
| 310 | 70.3.11 | Delete - Access policy (22.127 CR 0089 S1-071763) | 128d? | 2007-12-05 A | 2008-05-30 A | 100% |  | 2007-12-05 | 2008-05-30 | 128d? |  | finish no earlier than 2008-12-25 | C5 | 1024h | 1024h | OSA8 | PXWS Framework | Telecom Italia | vincenzo.amorino@telecomitalia.it | Rel-8 | Gwiho | CP-40 |
| 311 | 70.3.12 | Delete - API usage accounting (22.127 CR 0090 S1-071792) | 128d? | 2007-12-05 A | 2008-05-30 A | 100% |  | 2007-12-05 | 2008-05-30 | 128d? |  | finish no earlier than 2008-12-25 | C5 | 1024h | 1024h | OSA8 | PXWS Framework | Telecom Italia | vincenzo.amorino@telecomitalia.it | Rel-8 | Gwiho | CP-40 |
| 312 | 70.3.13 | Presence alignment with OMA and IETF (22.127 CR 0092 S1-071764) | 128d? | 2007-12-05 A | 2008-05-30 A | 100% |  | 2007-12-05 | 2008-05-30 | 128d? |  | finish no earlier than 2008-05-30 | C5 | 1024h | 1024h | OSA8 | 29.199-14/13 | Ericsson | catherine.mulligan@ericsson.com | Rel-8 | Gwiho |  |
| 313 | 70.3.14 | Delete - Service identification (22.127 CR 0095 S1-071837) | 128d? | 2007-12-05 A | 2008-05-30 A | 100% |  | 2007-12-05 | 2008-05-30 | 128d? |  | finish no earlier than 2008-05-30 | C5 | 1024h | 1024h | OSA8 | existing 29.199-xy | Ericsson | catherine.mulligan@ericsson.com | Rel-8 | Gwiho | CP-40 |
| 314 | 70.3.15 | Framework Enterprise Operator (Service Subscription function) | 102d? | 2008-01-10 A | 2008-05-30 A | 100% |  | 2008-01-10 | 2008-05-30 | 102d? |  | finish no earlier than 2008-05-30 | C5 | 816h | 816h | OSA8 | 29.198-03 | AePONA | Alan.Taylor@aepona.com | Rel-8 | Gwiho |  |
| 315 | 70.3.16 | Mobility Emergency Location | 102d? | 2008-01-10 A | 2008-05-30 A | 100% |  | 2008-01-10 | 2008-05-30 | 102d? |  | finish no earlier than 2008-05-30 | C5 | 816h | 816h | OSA8 | 29.198-06 | AePONA | Alan.Taylor@aepona.com | Rel-8 | Gwiho |  |
| 316 | 70.3.17 | Connectivity Manager SCF | 102d? | 2008-01-10 A | 2008-05-30 A | 100% |  | 2008-01-10 | 2008-05-30 | 102d? |  |  | C5 | 816h | 816h | OSA8 | 29.198-10 | AePONA | Alan.Taylor@aepona.com | Rel-8 | Gwiho |  |
| 317 | 70.3.18 | PAM Presence Agent | 102d? | 2008-01-10 A | 2008-05-30 A | 100% |  | 2008-01-10 | 2008-05-30 | 102d? |  | finish no earlier than 2008-05-30 | C5 | 816h | 816h | OSA8 | 29.198-14 | AePONA | Alan.Taylor@aepona.com | Rel-8 | Gwiho |  |
| 318 | 71 | **Paging Permission with Access Control (PPACR)** | 389d? | 2007-06-12 A | 2008-12-05 | 98% | 9d? | 2007-06-12 | 2008-12-05 | 389d? | 275d |  | S1,C1,R2 | 7368h | 4696.8h | PPACR |  | NTT DoCoMo | Morita Takashi | Rel-8 | Alain |  |
| 319 | 71.1 | Stage 1 for PPACR | 69d? | 2007-06-12 A | 2007-09-14 A | 100% |  | 2007-06-12 | 2007-09-14 | 69d? |  | finish no earlier than 2007-09-14 | S1 | 552h | 552h | PPACR-S1 | 22.011 | NTT DoCoMo | Morita Takashi | Rel-8 | Alain |  |
| 320 | 71.2 | Stage 3 for PPACR (CT1) | 278d? | 2007-11-14 A | 2008-12-05 | 95% | 13.9d? | 2007-11-14 | 2008-12-05 | 278d? | 275d | finish no earlier than 2008-12-05 | C1 | 2224h | 2112.8h | PPACR-CT1 | 24.008, 23.122, 24.301 | NTT DoCoMo |  | Rel-8 | Frederic |  |
| 321 | 71.3 | RRC Protocol specification for PPACR | 254d? | 2007-06-12 A | 2008-05-30 A | 100% |  | 2007-06-12 | 2008-05-30 | 254d? |  | finish no earlier than 2007-09-14 | R2 | 2032h | 2032h | PPACR | 25.331 | NTT DoCoMo |  | Rel-8 | Alain |  |
| 322 | 72 | **Value-Added Services for Short Message Service** | 133d? | 2007-09-10 A | 2008-03-12 A | 100% |  | 2007-09-10 | 2008-03-12 | 133d? |  |  | S1 | 2128h | 2128h | VAS4SMS | 22.142 | China Mobile | wubin@chinamobile.com | Rel-8 | Alain |  |
| 323 | 72.1 | Stage 1 for VAS4SMS | 133d? | 2007-09-10 A | 2008-03-12 A | 100% |  | 2007-09-10 | 2008-03-12 | 133d? |  | finish no earlier than 2008-03-21 | S1 | 1064h | 1064h | VAS4SMS | 22.142 | China Mobile | wubin@chinamobile.com | Rel-8 | Alain |  |

Notes:
- 299: CT#40 WID updated CP-070349=>CP-080252. Started work completed. Unfulfilled Rel-8 Stage 1 and New OSA work to be done in OMA. SA1 needs to remove non-fulfilled requirements in 22.127
- 300: CT#40: Work moved to OMA
- 301: CT#40 completed
- 302: CT#40 completed
- 303: CT#40 completed
- 304: CT#40: Work moved to OMA
- 305: SA#38 SP-070853 R8 CRs 22.127 OSA Stage 1. CT#40: Work moved to OMA
- 306: SA#38 SP-070853 R8 CRs 22.127 OSA Stage 1. CT#40: Work moved to OMA
- 307: SA#38 SP-070853 R8 CRs 22.127 OSA Stage 1. CT#40: Work moved to OMA
- 308: SA#38 SP-070853 R8 CRs 22.127 OSA Stage 1. CT#40: Work moved to OMA
- 309: SA#38 SP-070853 R8 CRs 22.127 OSA Stage 1. CT#40: Work moved to OMA
- 310: SA#38 SP-070853 R8 CRs 22.127 OSA Stage 1. CT#40: Work moved to OMA
- 311: SA#38 SP-070853 R8 CRs 22.127 OSA Stage 1. CT#40: Work moved to OMA
- 312: CT#40 completed
- 313: SA#38 SP-070853 R8 CRs 22.127 OSA Stage 1. CT#40: Work moved to OMA
- 314: CT#40 completed
- 315: CT#40 completed
- 316: CT#40 completed
- 317: CT#40 completed
- 318: Triggered by Study UID_330016 (PPAC). SA#37 Stage 1 completed
- 319: Triggered by Study UID_330016 (PPAC). SA#37 completed
- 320: CT#38 WID approved.
- 321: 24/07/08 line added to cover RAN2 work
- 322: SA#39 completed
- 323: SA#39 completed

| ID | WBS | Task | Duration | Start | Finish | Complete | Remaining | Baseline start | Baseline finish | Baseline duration | Total slack | Constraint | Resources | Work | Actual work | Text1 | Text4 | Text6 | Text8 | Text7 | Text12 |
| --- | --- | --- | --- | --- | --- | --- | --- | --- | --- | --- | --- | --- | --- | --- | --- | --- | --- | --- | --- | --- | --- |
| 324 | 73 | **Charging for multi-phases services** | 70d? | 2007-12-06 A | 2008-03-12 A | 100% |  | 2007-12-06 | 2008-03-12 | 70d? |  |  | S1 | 1120h | 1120h | CHRGMPH | Telecom Italia | Rel-8 | Alain |  |  |
| 325 | 73.1 | Stage 1 for CHRGMPH | 70d? | 2007-12-06 A | 2008-03-12 A | 100% |  | 2007-12-06 | 2008-03-12 | 70d? |  | start no earlier than 2007-12-06 | S1 | 560h | 560h | CHRGMPH-s1 | Telecom Italia | Rel-8 | Alain |  |  |
| 326 | 74 | **Home NodeB / eNodeB** | 387d? | 2007-06-14 A | 2008-12-05 | 13% | 337.16d? | 2007-06-14 | 2008-12-05 | 387d? | 275d |  | S1 | 8848h | 1139.55h | HomeNB | Vodafone | Rel-8 | Alain |  |  |
| 327 | 74.1 | Stage 1 for HNB_eHNB | 70d? | 2007-12-06 A | 2008-03-12 A | 100% |  | 2007-12-06 | 2008-03-12 | 70d? |  | start no earlier than 2007-12-06 | S1 | 560h | 560h | HomeNB-S1 | Vodafone | Rel-8 | Alain |  |  |
| 328 | 74.2 | Stage 3 for HeNB (CT1) | 387d? | 2007-06-14 A | 2008-12-05 | 5% | 367.65d? | 2007-06-14 | 2008-12-05 | 387d? | 275d | finish no earlier than 2008-12-05 | C1 | 3096h | 154.8h | HomeNB-LTE | Huawei | Rel-8 |  |  |  |
| 329 | 74.3 | Stage 3 for HNB (CT1) | 387d? | 2007-06-14 A | 2008-12-05 | 5% | 367.65d? | 2007-06-14 | 2008-12-05 | 387d? | 275d | finish no earlier than 2008-12-05 | C1 | 3096h | 154.8h | HomeNB-3G | Qualcomm | Rel-8 |  |  |  |
| 330 | 75 | Access Security Enhancements | 509d? | 2007-07-02 A | 2009-06-11 | 60% | 205.8d? | 2007-07-02 | 2009-06-11 | 509d? | 141d | finish no earlier than 2009-06-11 | S3 | 4072h | 2425.6h | ACCSEC2 | Ericsson | Rel-8 | Dionisio | TSG |  |
| 331 | 76 | Lawful Interception in the 3GPP Rel-8 | 459d? | 2007-03-12 A | 2008-12-11 | 50% | 229.5d? | 2007-03-12 | 2008-12-11 | 459d? | 271d | finish no earlier than 2008-12-11 | S3 | 3672h | 1836h | LI8 | BMWi | Rel-8 | Dionisio |  |  |
| 332 | 77 | **Generic Bootstrapping Architecture Push Function** | 193d? | 2008-03-12 A | 2008-12-05 | 24% | 146.95d? | 2008-03-12 | 2008-12-05 | 193d? | 275d |  | S3 | 4420.8h | 1054.8h | GBAPush | Ericsson | Rel-8 | Dionisio |  |  |
| 333 | 77.1 | Generic Bootstrapping Architecture Push Function | 132d? | 2008-03-12 A | 2008-09-11 | 65% | 46.2d? | 2008-03-12 | 2008-09-11 | 132d? | 336d | finish no earlier than 2008-03-21 | S3 | 1056h | 686.4h | GBAPush | Ericsson | Rel-8 | Dionisio |  |  |
| 334 | 77.2 | Generic Bootstrapping Architecture Push Function | 113.8d? | 2008-03-12 | 2008-12-05 |  |  | 2008-03-12 | 2008-12-05 | 113.8d? | 275d | finish no earlier than 2008-12-05 | C1 | 910.4h |  | GBAPush |  | Rel-8 | Dionisio |  |  |
| 335 | 77.3 | Generic Bootstrapping Architecture Push Function | 113.8d? | 2008-03-12 | 2008-12-05 |  |  | 2008-03-12 | 2008-12-05 | 113.8d? | 275d | finish no earlier than 2008-12-05 | C4 | 910.4h |  | GBAPush |  | Rel-8 | Dionisio |  |  |
| 336 | 78 | Requirements and Test methods for Wideband Terminals | 197d? | 2008-03-12 A | 2008-12-11 | 70% | 59.1d? | 2008-03-12 | 2008-12-11 | 197d? | 271d | start no earlier than 2008-03-12 | S4 | 1576h | 1103.2h | RETEM_WB_T | FT, Ericsson | Rel-8 | Paolo |  |  |
| 337 | 79 | Extending PSS and MBMS User Services for optimized Mobile TV | 266d? | 2007-12-06 A | 2008-12-11 | 40% | 159.6d? | 2007-12-06 | 2008-12-11 | 266d? | 271d | finish no earlier than 2008-12-11 | S4 | 2128h | 851.2h | PSS_MBMS_OMTV | Ericsson | Rel-8 | Paolo |  |  |
| 338 | 80 | **Encoding formats, transport formats and media description signalling for interworking, QoE, and other enhancements to MTSI-MHI** | 267d? | 2007-12-06 A | 2008-12-12 | 16% | 225.15d? | 2007-12-06 | 2008-12-12 | 267d? | 270d |  | S4,C3,C1,C4 | 7648h | 1198.82h | MTSI_eMHI | Ericsson, Qualcomm | Rel-8 | Paolo |  |  |
| 339 | 80.1 | MTSI Video - Dynamic Rate Adaptation/Signalling of Image Size | 266d? | 2007-12-06 A | 2008-12-11 | 30% | 186.2d? | 2007-12-06 | 2008-12-11 | 266d? | 271d | finish no earlier than 2008-12-11 | S4 | 2128h | 638.4h | MTSI_eMHI-DRASIS | Qualcomm, Samsung | Rel-8 | Paolo |  |  |
| 340 | 80.2 | Enhancement of interworking between MTSI and Circuit Switched networks | 141d? | 2008-05-30 A | 2008-12-12 | 20% | 112.8d? | 2008-05-30 | 2008-12-12 | 141d? | 270d | start no earlier than 2008-05-30 | C3 | 1128h | 225.6h | MTSI_eMHI | Huawei | Rel-8 | Gwiho |  |  |
| 341 | 80.3 | Enhancement of interworking between MTSI and Circuit Switched networks | 141d? | 2008-05-30 | 2008-12-12 |  |  | 2008-05-30 | 2008-12-12 | 141d? | 270d | start no earlier than 2008-05-30 | C1 | 1128h |  | MTSI_eMHI | Huawei | Rel-8 | Frederic |  |  |
| 342 | 80.4 | Enhancement of interworking between MTSI and Circuit Switched networks | 141d? | 2008-05-30 | 2008-12-12 |  |  | 2008-05-30 | 2008-12-12 | 141d? | 270d | start no earlier than 2008-05-30 | C4 | 1128h |  | MTSI_eMHI | Huawei | Rel-8 | Kimmo |  |  |
| 343 | 81 | **OAM&P 8** | 461d? | 2007-06-07 A | 2009-03-12 | 70% | 139.81d? | 2007-06-07 | 2009-03-12 | 461d? | 206d |  | S5,C1 | 38499.2h | 23021.5h | OAM8 |  | Rel-8 | Dionisio |  |  |
| 344 | 81.1 | **Network Infrastructure Management 8** | 461d? | 2007-06-07 A | 2009-03-12 | 72% | 127.07d? | 2007-06-07 | 2009-03-12 | 461d? | 206d |  | S5 | 16992h | 10912.3h | OAM8-NIM |  | Rel-8 | Dionisio |  |  |
| 345 | 81.1.1 | Telecom Management Methodology | 396d? | 2007-06-07 A | 2008-12-11 | 75% | 99d? | 2007-06-07 | 2008-12-11 | 396d? | 271d | finish no earlier than 2008-12-11 | S5 | 3168h | 2376h | OAM8 | Ericsson | Rel-8 | Dionisio |  |  |
| 346 | 81.1.2 | Advanced Alarming on Itf-N | 266d? | 2007-06-07 A | 2008-06-12 A | 100% |  | 2007-06-07 | 2008-06-12 | 266d? |  | finish no earlier than 2008-12-11 | S5 | 2128h | 2128h | OAM8 | NSN | Rel-8 | Dionisio |  |  |
| 347 | 81.1.3 | CN CS Bearer Transport Network (BTN) relative NRM | 266d? | 2007-06-07 A | 2008-06-12 A | 100% |  | 2007-06-07 | 2008-06-12 | 266d? |  | finish no earlier than 2008-12-11 | S5 | 2128h | 2128h | OAM8 | China Mobile | Rel-8 | Dionisio |  |  |
| 348 | 81.1.4 | Deleted - End point modelling for reference point | 324d? | 2007-09-17 A | 2008-12-11 A | 100% |  | 2007-09-17 | 2008-12-11 | 324d? |  | finish no earlier than 2008-12-11 | S5 | 2592h | 2592h | OAM8 | Motorola | Rel-8 | Dionisio |  | SP-41 |
| 349 | 81.1.5 | Alignment with eTOM and M.3060 architectural concepts | 210d? | 2008-02-22 A | 2008-12-11 | 15% | 178.5d? | 2008-02-22 | 2008-12-11 | 210d? | 271d | start no earlier than 2008-02-22 | S5 | 1680h | 252h | OAM8 | TeliaSonera | Rel-8 | Dionisio |  |  |
| 350 | 81.1.6 | IRP SOAP Solution Sets | 201d? | 2008-06-05 A | 2009-03-12 | 10% | 180.9d? | 2008-06-05 | 2009-03-12 | 201d? | 206d | finish no earlier than 2009-03-12 | S5 | 1608h | 160.8h | OAM8 | Ericsson | Rel-8 | Dionisio |  |  |

Notes:
- 324: SA#39 completed / Text3: 22.115 / Text5: Marco.DeLuca1@telecomitalia.it
- 325: SA#39 completed / Text3: 22.115 / Text5: Marco.DeLuca1@telecomitalia.it
- 326: SA#39 Stage 1 completed / Text3: 22.011, 22.115 / Text5: John Watson
- 327: SA#39 completed / Text3: 22.011, 22.115 / Text5: John Watson
- 328: Text5: 23.122, 24.301, 24.801
- 329: Text5: 23.122, 24.008
- 330: SA#26 approved WID (about improved GERAN security). SA#38 moved to Rel-8. SA#41: Low priority target completion Jun 2009 (after completion of the main EPS work). / Text3: 33.102, 43.020 / Text5: Bengt.Sahlin@ericsson.com
- 331: SA#40 exception to Sep 2008 for LI for SAE/LTE / Text3: 33.106, 33.107, 33.108 / Text5: berthold.wilhelm@bnetza.de, ron_ryan@verizon.net
- 332: SA#39 WID approved / Text5: Rolf Blom
- 333: 03/08/08 split S3,C1,C4 parts in WID / Text3: 33.223, 33.224 / Text5: Rolf Blom
- 334: 03/08/08 split S3,C1,C4 parts in WID / Text3: 24.109
- 335: 03/08/08 split S3,C1,C4 parts in WID / Text3: 29.109
- 336: SA#39 WID approved / Text3: 26.131, 26.132 / Text5: stephane.ragot@orange-ftgroup.com, wanqing.shi@sonyericsson.com
- 337: SA#38 WID approved / Text3: 26.234, 26.346, 26.946 / Text5: thorsten.lohmar@ericsson.com
- 338: SA#40 WID approved / Text5: olle.franceschi@ericsson.com, nleung@qualcomm.com
- 339: SA#40 Feature=>BB under new Feature UID_400028 (MTSI). CT#40 updated WID SP-070755=>SP-080246 / Text3: 26.114 / Text5: nleung@qualcomm.com & kyunghun.jung@samsung.com
- 340: CT#40 WID approved / Text3: 29.163 / Text5: Tingfang Tang (tagna_online@huawei.com)
- 341: CT#40 WID approved / Text3: 24.229 / Text5: Tingfang Tang (tagna_online@huawei.com)
- 342: CT#40 WID approved / Text3: 29.332 / Text5: Tingfang Tang (tagna_online@huawei.com)
- 345: Text3: 32.155, 32.153 / Text5: TOVINGER, Thomas
- 346: Text3: 32.121, 32.122, 32.123 / Text5: SUERBAUM, Clemens
- 347: Text3: 32.632/3/5 / Text5: LI, Jian
- 348: SP-41 Work stopped. Contributions related to E-UTRAN/EPC to be submitted to UID_380036 E-UTRAN NRM IRP/ UID_380037 EPC NRM IRP / Text3: 32.152, 32.62/3/4x, 32.73x / Text5: YAO, Yizhi
- 349: SA#39 WID approved / Text3: 32.101/2, 32.xyz / Text5: Berggren, Tommy
- 350: SA#40 WID approved / Text3: 32.111-7, 32.617, 32.417, 32.367, 32.627, 32.327, 32.337, 32.347, 32.357, 32.387, 32.397, 32.447, 32.637, 32.647, 32.657, 32.677, 32.697, 32.717, 32.727, 32.737, 32.747 / Text5: edwin.tse@ericsson.com

| ID | WBS | Task | Type | Duration | Start | Finish | Complete | Remaining | Baseline start | Baseline finish | Baseline duration | Total slack | Constraint | Resources | Work | Actual work | Text1 | Text6 | Text8 | Text4 | Text5 | Text12 |
| --- | --- | --- | --- | --- | --- | --- | --- | --- | --- | --- | --- | --- | --- | --- | --- | --- | --- | --- | --- | --- | --- | --- |
| 351 | 81.2 | **Performance Management 8** |  | 396d? | 2007-06-07 A | 2008-12-11 | 83% | 66d? | 2007-06-07 | 2008-12-11 | 396d? | 271d |  | S5 | 12672h | 10560h | OAM8-PM | Rel-8 | Dionisio |  |  |  |
| 352 | 81.2.1 | IP bearer network Performance measurement definitions |  | 396d? | 2007-06-07 A | 2008-12-11 A | 100% |  | 2007-06-07 | 2008-12-11 | 396d? |  | finish no earlier than 2008-12-11 | S5 | 3168h | 3168h | OAM8 | Rel-8 | Dionisio | China Mobile | lilianyuan@chinamobile.com | SP-36 |
| 353 | 81.2.2 | HSUPA performance measurements |  | 396d? | 2007-06-07 A | 2008-12-11 | 80% | 79.2d? | 2007-06-07 | 2008-12-11 | 396d? | 271d | finish no earlier than 2008-12-11 | S5 | 3168h | 2534.4h | OAM8 | Rel-8 | Dionisio | China Mobile | LI, Jian |  |
| 354 | 81.2.3 | Key Performance Indicators (KPIs) for UMTS/GERAN |  | 396d? | 2007-06-07 A | 2008-12-11 | 70% | 118.8d? | 2007-06-07 | 2008-12-11 | 396d? | 271d | finish no earlier than 2008-12-11 | S5 | 3168h | 2217.6h | OAM8 | Rel-8 | Dionisio | China Mobile | Liang Shuangchun |  |
| 355 | 81.3 | **Trace Management 8** |  | 206d? | 2008-03-07 A | 2008-12-19 | 34% | 136.84d? | 2008-03-07 | 2008-12-19 | 206d? | 265d |  | S5,C1,C3,C4 | 6097.6h | 1549.12h | OAM8-Trace | Rel-8 | Dionisio |  |  |  |
| 356 | 81.3.1 | Service Level Tracing in IMS |  | 206d? | 2008-03-07 A | 2008-12-19 | 85% | 30.9d? | 2008-03-07 | 2008-12-19 | 206d? | 265d | start no earlier than 2008-03-07 | C1 | 1648h | 1400.8h | OAM8-Trace | Rel-8 | Frederic | Vodafone | peter.dawes@vodafone.com |  |
| 357 | 81.3.2 | Service Level Tracing in IMS |  | 185.4d? | 2008-03-07 | 2008-12-19 |  |  | 2008-03-07 | 2008-12-19 | 185.4d? | 265d | finish no earlier than 2008-12-19 | C3 | 1483.2h |  | OAM8-Trace | Rel-8 | Frederic | Vodafone | peter.dawes@vodafone.com |  |
| 358 | 81.3.3 | Service Level Tracing in IMS |  | 185.4d? | 2008-03-07 A | 2008-12-19 | 10% | 166.86d? | 2008-03-07 | 2008-12-19 | 185.4d? | 265d | finish no earlier than 2008-12-19 | C4 | 1483.2h | 148.32h | OAM8-Trace | Rel-8 | Frederic | Vodafone | peter.dawes@vodafone.com |  |
| 359 | 82 | **Charging Management small Enhancements** |  | 716d? | 2006-03-16 A | 2008-12-11 | 71% | 208.48d? | 2006-03-16 | 2008-12-11 | 716d? | 271d |  | S5 | 12056h | 8545.66h | CH8 | Rel-8 | Dionisio |  |  |  |
| 360 | 82.1 | Online charging correlation |  | 457d? | 2006-03-16 A | 2007-12-14 A | 100% |  | 2006-03-16 | 2007-12-14 | 457d? |  | start no earlier than 2006-03-16 | S5 | 3656h | 3656h | CH8 | Rel-8 | Dionisio | Orange | Chahine, Rony |  |
| 361 | 82.2 | SMS online charging |  | 137d? | 2007-06-07 A | 2007-12-14 A | 100% |  | 2007-06-07 | 2007-12-14 | 137d? |  | finish no earlier than 2007-12-14 | S5 | 1096h | 1096h | CH8 | Rel-8 | Dionisio | Vodafone | WONG, Gavin |  |
| 362 | 82.3 | WLAN Offline Charging |  | 244d? | 2008-01-07 | 2008-12-11 |  |  | 2008-01-07 | 2008-12-11 | 244d? | 271d | finish no earlier than 2008-12-11 | S5 | 1952h |  | CH8 | Rel-8 | Dionisio | ALU | GARDELLA, Maryse |  |
| 363 | 83 | **Conferencing enhancements for Mp interface** |  | 266d? | 2007-11-30 A | 2008-12-05 | 67% | 86.56d? | 2007-11-30 | 2008-12-05 | 266d? | 275d |  | C4 | 5904h | 3982.7h | eMp | Rel-8 | Kimmo | Huawei | Chencheng@huawei.com |  |
| 364 | 83.1 | Stage 2 for eMp |  | 206d? | 2007-11-30 A | 2008-09-12 | 90% | 20.6d? | 2007-11-30 | 2008-09-12 | 206d? | 335d | finish no earlier than 2008-09-12 | C4 | 1648h | 1483.2h | eMp | Rel-8 | Kimmo | Huawei | Chencheng@huawei.com |  |
| 365 | 83.2 | Stage 3 for eMp |  | 266d? | 2007-11-30 A | 2008-12-05 | 50% | 133d? | 2007-11-30 | 2008-12-05 | 266d? | 275d | finish no earlier than 2008-12-05 | C4 | 2128h | 1064h | eMp | Rel-8 | Kimmo | Huawei | Chencheng@huawei.com |  |
| 366 | 84 | **Contact Manager for 3GPP UICC applications** |  | 577d? | 2006-06-22 A | 2008-09-05 | 93% | 41.99d? | 2006-06-22 | 2008-09-05 | 577d? | 340d |  | C6 | 12312h | 11416.1h | eUPHBOOK | Rel-8 | Xavier | Gemalto | Jacques.seif@gemalto.com |  |
| 367 | 84.1 | Requirements for Contact Manager |  | 392d? | 2006-06-22 A | 2007-12-21 A | 100% |  | 2006-06-22 | 2007-12-21 | 392d? |  | finish no earlier than 2007-12-21 | C6 | 3136h | 3136h | eUPHBOOK-St1 | Rel-8 | Xavier | Gemalto | Jacques.seif@gemalto.com |  |
| 368 | 84.2 | External interface for eUPHBOOK |  | 220d? | 2007-05-07 A | 2008-03-07 A | 100% |  | 2007-05-07 | 2008-03-07 | 220d? |  | finish no earlier than 2008-03-07 | C6 | 1760h | 1760h | eUPHBOOK-Ext_Spec | Rel-8 | Xavier | Gemalto | Jacques.seif@gemalto.com |  |
| 369 | 84.3 | Internal interface for eUPHBOOK |  | 350d? | 2007-05-07 A | 2008-09-05 | 80% | 70d? | 2007-05-07 | 2008-09-05 | 350d? | 340d | finish no earlier than 2008-09-05 | C6 | 2800h | 2240h | eUPHBOOK-Int_Spec | Rel-8 | Xavier | Gemalto | Jacques.seif@gemalto.com |  |
| 370 | 84.4 | Deleted - Implementation of eUPHBOOK | milestone | 0d? | 2007-06-21 A | 2007-06-21 A | 100% |  | 2007-06-21 | 2007-06-21 | 0d? |  | start no earlier than 2007-06-21 | C6 |  |  | eUPHBOOK-St23 | Rel-8 | Xavier |  |  | SP-33 |
| 371 | 85 | Contact Manager Conformance Test specifications |  | 577d? | 2006-12-27 | 2009-03-12 |  |  | 2006-12-27 | 2009-03-12 | 577d? | 206d | finish no earlier than 2009-03-12 | C6 | 4616h |  | eUPHBOOK-Test | Rel-8 | Xavier | Comprion, Gemalto | jacques.seif@gemalto.com, Udo Willenbrink |  |
| 372 | 86 | Definition of 3GPP UICC services over the new high-speed interface |  | 200d? | 2007-12-10 A | 2008-09-12 | 10% | 180d? | 2007-12-10 | 2008-09-12 | 200d? | 335d | finish no earlier than 2008-09-12 | C6 | 1600h | 160h | UICCHS | Rel-8 | Xavier | Gemalto | jacques.seif@gemalto.com |  |
| 373 | 87 | **3G Long Term Evolution - Evolved Packet System RAN part** |  | 644d? | 2006-09-25 A | 2009-03-12 | 61% | 252.62d? | 2006-09-25 | 2009-03-12 | 644d? | 206d |  | RP,S5 | 43608h | 24891h | LTE | Rel-8 | Juergen | NTT DoCoMo | Takehiro Nakamura |  |
| 374 | 87.1 | LTE – Physical Layer |  | 380d? | 2006-09-25 A | 2008-03-07 A | 100% |  | 2006-09-25 | 2008-03-07 | 380d? |  | finish no earlier than 2007-09-14 | R1 | 3040h | 3040h | LTE-Phys | Rel-8 | Patrick | NTT DoCoMo | Sadayuki Abeta |  |
| 375 | 87.2 | LTE – Radio Interface Layer 2 and 3 Protocol Aspect |  | 515d? | 2006-09-25 A | 2008-09-12 | 95% | 25.75d? | 2006-09-25 | 2008-09-12 | 515d? | 335d | finish no earlier than 2008-09-12 | R2 | 4120h | 3914h | LTE-L23 | Rel-8 | Joern | Nokia | Benoist Sébire |  |
| 376 | 87.3 | LTE – eUTRAN Interfaces |  | 515d? | 2006-09-25 A | 2008-09-12 | 95% | 25.75d? | 2006-09-25 | 2008-09-12 | 515d? | 335d | finish no earlier than 2008-09-12 | R3 | 4120h | 3914h | LTE-interfaces | Rel-8 | Juergen | Ericsson | Mattias Wahlqvist |  |
| 377 | 87.4 | LTE – RF Radio Transmission/Reception, System Performance Requirements and Conformance Testing |  | 515d? | 2006-09-25 A | 2008-09-12 | 80% | 103d? | 2006-09-25 | 2008-09-12 | 515d? | 335d | finish no earlier than 2008-09-12 | R4 | 4120h | 3296h | LTE-RF | Rel-8 | Stefania | NSN | Tuomo Saynajakangas |  |
| 378 | 87.5 | LTE FDD repeaters |  | 325d? | 2007-09-14 A | 2008-12-11 | 25% | 243.75d? | 2007-09-14 | 2008-12-11 | 325d? | 271d | finish no earlier than 2008-12-11 | R4 | 2600h | 650h | LTE-Repeaters | Rel-8 | Stefania | Powerwave, Andrew Wireless | Alf Ahlström, Ralf Michanikl |  |

Notes:
- 352: SA#36 Moved Rel-7=>Rel-8; WID updated SP-050319=>SP-070301 / Text3: 32.321/2/3/5
- 353: Text3: 32.405
- 354: Text3: 32.xyz
- 356: Cannot proceed without substantial IETF contribution. CT#40 WID updated CP-060521=>CP-080315 / Text3: 24.323, 24.229
- 357: Cannot proceed without substantial IETF contribution. CT#40 WID updated CP-060521=>CP-080315 / Text3: 29.163
- 358: Cannot proceed without substantial IETF contribution. CT#40 WID updated CP-060521=>CP-080315 / Text3: 29.228, 29.229, 29.332
- 360: WID approved SA#35 / Text3: 32.296
- 361: Text3: 32.274, 32.240/299
- 362: SA#38 WID approved / Text3: 32.252/298/299
- 364: Text3: 23.333
- 365: Text3: 29.333
- 366: aka Enhanced USIM phonebook. CT#40: WID updated CP-070622=>CP-080382
- 367: CT#38 completed / Text3: 21.111
- 368: CT#39 completed / Text3: 31.220
- 369: CT#37 created. CT#40 TS for Information / Text3: 31.221
- 370: SA#33 stopped / Text3: 31.102
- 371: CT#40 WID approved / Text3: 31.320, 31.321
- 372: CT#38 WID approved. CT#40: SCP/CT6 work split defined / Text3: TS
- 373: WID in RP-060635. Status report in RP-080256. LTE completion target Jun => Sep =>Dec 2008 (excluding: FDD repeaters (?), E-UTRAN-OAM)
- 374: WID in RP-060630. Status report in RP-080256 / Text3: 36.201, 36.211, 36.212, 36.213, 36.214
- 375: WID in RP-060630. Status report in RP-080256 / Text3: 36.300, 36.304, 36.306, 36.321, 36.322, 36.323, 36.331
- 376: WID in RP-060630. Status report in RP-080256 / Text3: 36.401, 36.410, 36.411, 36.412, 36.413, 36.414, 36.420, 36.421, 36.422, 36.423, 36.424, 36.440, 36.441, 36.442, 36.443, 36.444, 36.445, 36.446, 36.902 (SON use cases)
- 377: WID in RP-080314. Status report in RP-080256 / Text3: 36.101, 36.104, 36.113, 36.124, 36.133, 36.141, 36.942
- 378: WID in RP-070749. Status report in RP-080257 / Text3: 36.x, 25.113

| ID | WBS | Task | Duration | Start | Finish | Complete | Remaining | Baseline start | Baseline finish | Baseline duration | Total slack | Constraint | Deadline | Resources | Work | Actual work | Text1 | Text6 | Text8 | Text4 | Text5 | Text7 | Text10 |
| --- | --- | --- | --- | --- | --- | --- | --- | --- | --- | --- | --- | --- | --- | --- | --- | --- | --- | --- | --- | --- | --- | --- | --- |
| 379 | 87.6 | **E-UTRAN Data Definitions** | 389d? | 2007-09-17 A | 2009-03-12 | 39% | 238.48d? | 2007-09-17 | 2009-03-12 | 389d? | 206d |  |  | S5 | 12056h | 4664.96h | E-UTRAN-OAM | Rel-8 | Dionisio |  |  |  |  |
| 380 | 87.6.1 | Subscriber and Equipment Trace for eUTRAN and EPC | 324d? | 2007-09-17 A | 2008-12-11 | 60% | 129.6d? | 2007-09-17 | 2008-12-11 | 324d? | 271d | finish no earlier than 2008-12-11 |  | S5 | 2592h | 1555.2h | E-UTRAN-OAM | Rel-8 | Dionisio | Ericsson | PETERSEN, Robert |  |  |
| 381 | 87.6.2 | E-UTRAN Network Resource Model (NRM) Integration Reference Point (IRP) | 309d? | 2008-01-07 A | 2009-03-12 | 30% | 216.3d? | 2008-01-07 | 2009-03-12 | 309d? | 206d | finish no earlier than 2009-03-12 |  | S5 | 2472h | 741.6h | E-UTRAN-OAM | Rel-8 | Dionisio | Ericsson | ELMDAHL, Per |  |  |
| 382 | 87.6.3 | Performance measurements for E-UTRAN | 210d? | 2008-02-22 A | 2008-12-11 | 30% | 147d? | 2008-02-22 | 2008-12-11 | 210d? | 271d | start no earlier than 2008-02-22 |  | S5 | 1680h | 504h | E-UTRAN-OAM | Rel-8 | Dionisio | Motorola, Huawei | YAO, Yizhi |  |  |
| 383 | 87.6.4 | Key Performance Indicators (KPIs) for E-UTRAN | 275d? | 2008-02-22 A | 2009-03-12 | 30% | 192.5d? | 2008-02-22 | 2009-03-12 | 275d? | 206d | finish no earlier than 2009-03-12 |  | S5 | 2200h | 660h | E-UTRAN-OAM | Rel-8 | Dionisio | Ericsson | HÜBINETTE, Ulf |  |  |
| 384 | 87.7 | **Self-Organizing Networks (SON)** | 210d? | 2008-02-22 A | 2008-12-11 | 33% | 141.75d? | 2008-02-22 | 2008-12-11 | 210d? | 271d |  |  | S5 | 8400h | 2730h | LTE_SON-OAM | Rel-8 | Dionisio | Vodafone | GOMPAKIS, Panagiotis |  |  |
| 385 | 87.7.1 | Self-Organizing Networks (SON) | 210d? | 2008-02-22 A | 2008-12-11 | 60% | 84d? | 2008-02-22 | 2008-12-11 | 210d? | 271d |  |  | S5 | 1680h | 1008h | LTE_SON-OAM | Rel-8 | Dionisio | Vodafone | GOMPAKIS, Panagiotis |  |  |
| 386 | 87.7.2 | Self-Establishment of eNBs | 210d? | 2008-02-22 A | 2008-12-11 | 30% | 147d? | 2008-02-22 | 2008-12-11 | 210d? | 271d | start no earlier than 2008-02-22 |  | S5 | 1680h | 504h | LTE_SON-OAM | Rel-8 | Dionisio | NSN | SUERBAUM, Clemens |  |  |
| 387 | 87.7.3 | SON Automatic Neighbour Relations (ANR) List Management | 210d? | 2008-02-22 A | 2008-12-11 | 30% | 147d? | 2008-02-22 | 2008-12-11 | 210d? | 271d | finish no earlier than 2008-12-11 |  | S5 | 1680h | 504h | LTE_SON-OAM | Rel-8 | Dionisio | Ericsson | TSE, Edwin |  |  |
| 388 | 87.7.4 | SON Self-Optimization & Self-Healing handling | 210d? | 2008-02-22 A | 2008-12-11 | 10% | 189d? | 2008-02-22 | 2008-12-11 | 210d? | 271d | finish no earlier than 2008-12-11 |  | S5 | 1680h | 168h | LTE_SON-OAM | Rel-8 | Dionisio | Huawei | WANG, Xuelong |  |  |
| 389 | 88 | **LTE – Terminal Conformance Test Specifications** | 401d? | 2007-06-01 A | 2008-12-12 | 15% | 338.85d? | 2007-06-01 | 2008-12-12 | 401d? | 270d |  |  | R5 | 8192.02h | 1269.77h | LTE-UEConTest | Rel-8 | Ingbert |  |  |  |  |
| 390 | 88.1 | 3G Long Term Evolution – Terminal Protocol Conformance Test Specifications | 401d? | 2007-06-01 A | 2008-12-12 | 11% | 356.89d? | 2007-06-01 | 2008-12-12 | 401d? | 270d | finish no earlier than 2008-12-12 |  | R5 | 3208h | 352.88h | LTE-UEConTest_SIG | Rel-8 | Ingbert | NEC, Motorola | david.lecompte@nectech.fr, Jacob.John@motorola.com |  |  |
| 391 | 88.2 | 3G Long Term Evolution – Terminal Radio Transmission and Reception Conformance Test Specifications | 401d? | 2007-06-01 A | 2008-12-12 | 20% | 320.8d? | 2007-06-01 | 2008-12-12 | 401d? | 270d | finish no earlier than 2008-12-12 |  | R5 | 3208h | 641.6h | LTE-UEConTest_RF | Rel-8 | Ingbert | Agilent | andrea_leonardi@agilent.com |  |  |
| 392 | 89 | **Improvements of the Radio Interface** | 532d? | 2007-03-05 A | 2009-03-17 | 68% | 168.89d? | 2007-03-05 | 2009-03-17 | 532d? | 203d |  |  | RP | 19816h | 11260.4h | RInImp8 | Rel-8 | Juergen |  |  |  |  |
| 393 | 89.1 | UMTS 1500 MHz | 140d? | 2007-03-05 A | 2007-09-14 A | 100% |  | 2007-03-05 | 2007-09-14 | 140d? |  | finish no earlier than 2007-09-14 |  | R4 | 1120h | 1120h | RInImp8-UMTS1500 | Rel-8 | Stefania | NTT DoCoMo | Takehiro Nakamura | TSG |  |
| 394 | 89.2 | UMTS 700 MHz FDD | 325d? | 2007-03-05 A | 2008-05-30 A | 100% |  | 2007-03-05 | 2008-05-30 | 325d? |  | finish no earlier than 2008-06-12 |  | R4 | 2600h | 2600h | RInImp8-UMTS700 | Rel-8 | Stefania | Nokia | Tuomo Saynajakangas | TSG |  |
| 395 | 89.3 | UMTS 2300 MHz FDD/TDD | 400d? | 2007-03-05 A | 2008-09-12 | 20% | 320d? | 2007-03-05 | 2008-09-12 | 400d? | 335d | finish no earlier than 2008-09-12 |  | R4 | 3200h | 640h | RInImp8-UMTS2300 | Rel-8 | Stefania | AT&T | marc.grant@cingular.com | TSG |  |
| 396 | 89.4 | UMTS 2300 MHz TDD LCR | 195d? | 2007-12-17 A | 2008-09-12 | 90% | 19.5d? | 2007-12-17 | 2008-09-12 | 195d? | 335d | finish no earlier than 2008-09-12 |  | R4 | 1560h | 1404h | RInImp8-UMTS2300TDD | Rel-8 | Stefania | Datang | songyuexia@datangmobile.cn |  |  |
| 397 | 89.5 | UMTS/LTE 3500 MHz | 327d? | 2007-12-17 A | 2009-03-17 | 15% | 277.95d? | 2007-12-17 | 2009-03-17 | 327d? | 203d | finish no earlier than 2009-03-17 |  | R4 | 2616h | 392.4h | RInImp8-UMTSLTE3500 | Rel-8 | Stefania | Ericsson | johan.skold@ericsson.com |  |  |
| 398 | 89.6 | Further Improved Minimum Performance Requirements for HSDPA UE (FDD) - Two-Branch Interference Cancellation | 265d? | 2007-03-05 A | 2008-03-07 A | 100% |  | 2007-03-05 | 2008-03-07 | 265d? |  | finish no earlier than 2008-03-12 |  | R4 | 2120h | 2120h | RInImp8-2BIC | Rel-8 | Stefania | AT&T | marc.grant@cingular.com |  |  |
| 399 | 89.7 | CS Voice Service over HSPA | 167d? | 2007-07-19 A | 2008-03-07 A | 100% |  | 2007-07-19 | 2008-03-07 | 167d? |  |  |  | R2 | 1336h | 1336h | RInImp8-CsHspa | Rel-8 | Joern | NSN | woonhee.hwang@nsn.com |  |  |
| 400 | 89.8 | Performance requirements for 15 code reception with 16QAM/QPSK | 126d? | 2007-06-11 A | 2008-03-07 A | 100% |  | 2007-06-11 | 2008-03-07 | 126d? |  | finish no earlier than 2008-06-12 |  | R4 | 1008h | 1008h | RInImp8-Hsdpa15codes | Rel-8 | Stefania | Vodafone | tim.frost@vodafone.com |  |  |
| 401 | 90 | **Improvements of the Radio Interface - UE Conformance Testing** | 801d? | 2005-11-11 A | 2008-12-05 | 75% | 203.56d? | 2005-11-11 | 2008-12-05 | 801d? | 275d |  |  | R5 | 21816h | 16271.9h | RInImp-UEConTest |  | Ingbert |  |  |  |  |
| 402 | 16.5.1 | UE conformance testing for UMTS 2600 MHz | 146d | 2005-11-11 A | 2006-06-02 A | 100% |  | 2005-11-11 | 2006-06-02 | 146d |  | finish no earlier than 2006-06-02 | 2006-06-02 | R5 | 1168h | 1168h | RInImp-UMTS2600_Test | Rel-7 | Ingbert | Nokia | Aleksi Heino |  | Fri 7/11/05 |
| 403 | 16.5.1 | UE Conformance Test for UMTS in 900 MHz band (band VIII) | 146d | 2005-11-11 A | 2006-06-02 A | 100% |  | 2005-11-11 | 2006-06-02 | 146d |  | finish no earlier than 2006-06-02 | 2006-06-02 | R5 | 1168h | 1168h | RInImp-UMTS900_Test | Rel-7 | Ingbert | Qualcomm | hanye@qualcomm.com |  | Fri 11/03/05 |
| 404 | 90.3 | Conformance Test Aspects – Improved Performance of HSDPA Receiver type 3 | 191d? | 2006-03-10 A | 2006-12-01 A | 100% |  | 2006-03-10 | 2006-12-01 | 191d? |  | finish no earlier than 2006-12-01 |  | R5 | 1528h | 1528h | RInImp-HSPerf-Type3_Test | Rel-7 | Ingbert | Motorola | carolyn.taylor@motorola.com |  |  |
| 405 | 90.4 | UE antenna Over The Air (OTA) conformance testing | 517d? | 2006-09-20 A | 2008-09-11 | 70% | 155.1d? | 2006-09-20 | 2008-09-11 | 517d? | 336d | finish no earlier than 2008-09-11 |  | R5 | 4136h | 2895.2h | RInImp-UEAnt_Test | Rel-7 | Ingbert | Nokia | Aleksi.Heino@nokia.com |  |  |
| 406 | 90.5 | UE conformance testing for FDD Inter-Band Operation | 131d? | 2006-06-02 A | 2006-12-01 A | 100% |  | 2006-06-02 | 2006-12-01 | 131d? |  | finish no earlier than 2006-12-01 |  | R5 | 1048h | 1048h | RInImp-InterBand_Test | Rel-7 | Ingbert | NEC, Motorola | Jacob.John@motorola.com |  |  |
| 407 | 90.6 | Conformance Test Aspects – Extended UMTS 1.7/2.1 GHz | 131d? | 2006-12-01 A | 2007-06-01 A | 100% |  | 2006-12-01 | 2007-06-01 | 131d? |  | finish no earlier than 2007-06-01 |  | R5 | 1048h | 1048h | RInImp-UEConTest_UMTS1721Ext | Rel-7 | Ingbert | Motorola | carolyn.taylor@motorola.com |  |  |
| 408 | 90.7 | Conformance Test Aspects – Minimum UE performance requirement for downlink physical channels in support of E-DCH operation based on type 1 enhanced receiver (Rx-Diversity) | 136d? | 2007-06-01 A | 2007-12-07 A | 100% |  | 2007-06-01 | 2007-12-07 | 136d? |  | finish no earlier than 2007-12-07 |  | R5 | 1088h | 1088h | RInImp-UEConTest_RxDivEDCH | Rel-7 | Ingbert | Motorola | carolyn.taylor@motorola.com |  |  |
| 409 | 90.8 | Conformance Test Aspects – Minimum UE performance requirement for downlink physical channels in support of MTCGH and MCCH operation based on type 1 enhanced receiver (Rx-Diversity) | 201d? | 2007-06-01 A | 2008-03-07 A | 100% |  | 2007-06-01 | 2008-03-07 | 201d? |  | finish no earlier than 2008-03-07 |  | R5 | 1608h | 1608h | RInImp-UEConTest_RxDivMBMS | Rel-7 | Ingbert | Ericsson | leif.mattisson@ericsson.com |  |  |
| 410 | 90.9 | Conformance Test Aspects – CS Voice Service over HSPA | 336d? | 2007-06-01 A | 2008-09-12 | 30% | 235.2d? | 2007-06-01 | 2008-09-12 | 336d? | 335d | finish no earlier than 2008-09-12 |  | R5 | 2688h | 806.4h | RInImp8-CsHspa_UEConTest | Rel-8 | Ingbert | Huawei | baoyi@huawei.com |  |  |
| 411 | 90.10 | Conformance Test Aspects – Performance requirements for 15 code reception with 16QAM/QPSK (FDD) | 136d? | 2008-05-30 | 2008-12-05 |  |  | 2008-05-30 | 2008-12-05 | 136d? | 275d | finish no earlier than 2008-12-05 |  | R5 | 1088h |  | RInImp8-UEConTest_ Hsdpa15codes | Rel-8 | Ingbert | Ericsson | Mikael Zirén |  |  |
| 412 | 91 | MBSFN Downlink Optimized Broadcast 3.84 Mcps TDD | 335d? | 2007-06-04 | 2008-09-12 |  |  | 2007-06-04 | 2008-09-12 | 335d? | 335d | finish no earlier than 2008-09-12 |  | R1 | 2680h |  | MBSFN-DOB | Rel-8 | Patrick | Ericsson | Lars Lindbom |  |  |

Notes:
- 380: Text3: 32.42x, 32.44x
- 381: SA#38 WID approved / Text3: 32.761/2/3/5
- 382: SA#39 WID approved / Text3: 32.425
- 383: SA#39 WID approved / Text3: 32.450, 32.451
- 384: SA#39 WID approved. SA#40 updated WID SP-080064=>SP-080275. SA#41 added WT to monitor 32.500 progress
- 385: SA#39 WID approved. SA#40 updated WID SP-080064=>SP-080275. SA#41 UID_390004 split to monitor 32.500 progress / Text3: 32.500
- 386: SA#39 WID approved / Text3: 32.501, 32.502, 32.76x/32.75x
- 387: SA#39 WID approved / Text3: 32.511, 32.76x
- 388: SA#39 WID approved / Text3: 32.521
- 389: Testing for Feature UID_20068 (LTE)
- 390: WID in RP-070428. Status Report in RP-080425 / Text3: 36.521-1, 36.521-2, 36.508
- 391: WID in RP-080382. Status Report in RP-080259. / Text3: 36.521-1, 36.521-2, 36.508, 36.509
- 393: WID in RP-070078. Status Report in RP-070526 / Text3: 25.101, 25.104, 25.133, 25.141, 25.331, 25.942, 25.306, 25.307, 34.121
- 394: WID in RP-070127. Status Report in RP-080260 / Text3: 25.101, 25.104, 25.133, 25.141, 25.331, 25.942, 25.306, 25.307, 34.121
- 395: WID in RP-070128. Status Report in RP-080261 / Text3: 25.101, 25.104, 25.133, 25.141, 25.331, 25.942, 25.306, 25.307, 34.121
- 396: WID in RP-071016. Status Report in RP-080263 / Text3: 25.102, 25.105, 25.113, 25.123, 25.142, 34.124, 25.306, 25.331, 34.122
- 397: WID in RP-071012. Status Report in RP-080262 / Text3: 25.101, 25.104, 25.113, 25.133, 25.141, 34.124, 25.307, 25.331, 25.461, 25.463, 34.108, 34.121, 36.101, 36.104, 36.141, 36.508, 25.307, 36.331, 36.521-1, 36.521-2
- 398: WID in RP-070254. Status Report in RP-080041.
- 399: WID in RP-070823. Status Report in RP-080042. / Text3: 25.323, 25.331, 25.322
- 400: WID in RP-070824. Status Report in RP-080043. / Text3: 25.101
- 401: 05/08: Linked to Feature UID_20028 (RInImp)
- 402: WID in / Text3: 34.108, 34.121
- 403: WID in / Text3: 34.108, 34.121
- 404: WID in / Text3: 34.121, 34.108
- 405: WID in RP-060486. Status report in RP-080279 / Text3: 34.114
- 406: WID in / Text3: 34.108, 34.123-1, 34.123-2, 34.123-3
- 407: WID in RP-060676 / Text3: 34.108, 34.121-1, 34.121-2
- 408: WID in RP-070414
- 409: WID in RP-070381. Status Report RP-080056
- 410: WID in RP-080160. Status Report in RP-080288. / Text3: 34.108, 34.123-1, 34.123-2, 34.123-3
- 411: WID in RP-080311, linked UID_370033
- 412: WID in RP-070493. Status Report in RP-080218 (RAN#39) / Text3: 25.346, 25.201, 25.221, 25.222, 25.223, 25.306, 25.331, 25.402, 25.433, 25.102, 25.105, 25.123

| ID | WBS | Task | Duration | Start | Finish | Complete | Remaining | Baseline start | Baseline finish | Baseline duration | Total slack | Constraint | Resources | Work | Actual work | Text1 | Text6 | Text8 | Text4 | Text5 |
| --- | --- | --- | --- | --- | --- | --- | --- | --- | --- | --- | --- | --- | --- | --- | --- | --- | --- | --- | --- | --- |
| 413 | 92 | **RAN improvements** | 529d? | 2007-06-04 A | 2009-06-11 | 44% | 294.78d? | 2007-06-04 | 2009-06-11 | 529d? | 141d |  | RP | 30792h | 13633.5h | RANimp | Rel-8 | Juergen |  |  |
| 414 | 92.1 | Combination of 64QAM and MIMO for HSDPA (FDD) | 130d? | 2007-06-04 A | 2008-05-30 A | 100% |  | 2007-06-04 | 2008-05-30 | 130d? |  | finish no earlier than 2008-09-12 | R1 | 1040h | 1040h | RANimp-64QamMimoHsdpa | Rel-8 | Patrick | Ericsson | Johan.Bergman@ericsson.com |
| 415 | 92.2 | Improved L2 for uplink | 186d? | 2007-09-14 A | 2008-05-30 A | 100% |  | 2007-09-14 | 2008-05-30 | 186d? |  | finish no earlier than 2008-05-30 | R2 | 1488h | 1488h | RANimp-UplinkL2dataRates | Rel-8 | Joern | Ericsson | Janne.Peisa@ericsson.com |
| 416 | 92.3 | Enhanced Uplink for CELL_FACH State in FDD | 261d? | 2007-09-14 A | 2008-09-12 | 72% | 73.08d? | 2007-09-14 | 2008-09-12 | 261d? | 335d | finish no earlier than 2008-09-12 | R2 | 2088h | 1503.36h | RANimp-UplinkEnhState | Rel-8 | Joern | NSN | markus.wimmer@nsn.com |
| 417 | 92.4 | Enhanced UE DRX for FDD | 261d? | 2007-09-14 A | 2008-09-12 | 70% | 78.3d? | 2007-09-14 | 2008-09-12 | 261d? | 335d | finish no earlier than 2008-09-12 | R2 | 2088h | 1461.6h | RANimp-DRX | Rel-8 | Joern | Nokia | luis.barreto@nokia.com |
| 418 | 92.5 | Enhancements for SRNS Relocation Procedure | 261d? | 2007-09-14 A | 2008-09-12 | 75% | 65.25d? | 2007-09-14 | 2008-09-12 | 261d? | 335d | finish no earlier than 2008-09-12 | R3 | 2088h | 1566h | RANimp-SrnsReloc | Rel-8 | Juergen | NSN | masatoshi.nakamata@nsn.com |
| 419 | 92.6 | Enhancements for FDD HSPA Evolution | 261d? | 2007-09-14 A | 2008-09-12 | 40% | 156.6d? | 2007-09-14 | 2008-09-12 | 261d? | 335d | finish no earlier than 2008-09-12 | R3 | 2088h | 835.2h | RANimp-HSPAEvo | Rel-8 | Juergen | NSN | masatoshi.nakamata@nsn.com |
| 420 | 92.7 | 64QAM for 1.28 Mcps TDD HSDPA | 204d? | 2007-12-04 A | 2008-09-12 | 85% | 30.6d? | 2007-12-04 | 2008-09-12 | 204d? | 335d | finish no earlier than 2008-09-12 | R1 | 1632h | 1387.2h | RANimp-64Qam1.28TDD | Rel-8 | Patrick | ZTE | zfmail@zte.com.cn |
| 421 | 92.8 | Enhanced CELL_FACH state in 1.28 Mcps TDD | 204d? | 2007-12-04 A | 2008-09-12 | 50% | 102d? | 2007-12-04 | 2008-09-12 | 204d? | 335d | finish no earlier than 2008-09-12 | R2 | 1632h | 816h | RANimp-EnhState1.28TDD | Rel-8 | Joern | ZTE | zhang.yincheng@zte.com.cn |
| 422 | 92.9 | 1.28 Mcps TDD Repeater Specification | 269d? | 2007-12-04 A | 2008-12-12 | 10% | 242.1d? | 2007-12-04 | 2008-12-12 | 269d? | 270d | finish no earlier than 2008-12-12 | R4 | 2152h | 215.2h | RANimp-Repeaters1.28TDD | Rel-8 | Stefania | RITT | qinyan@chinattl.com |
| 423 | 92.10 | Continuous Connectivity for packet data users for 1.28Mcps TDD | 201d? | 2008-03-07 A | 2008-12-12 | 10% | 180.9d? | 2008-03-07 | 2008-12-12 | 201d? | 270d | finish no earlier than 2008-12-12 | R1 | 1608h | 160.8h | RANimp-LCRCPC | Rel-8 | Patrick |  |  |
| 424 | 92.11 | HSPA VoIP to WCDMA/GSM CS continuity | 201d? | 2008-03-07 A | 2008-12-12 | 50% | 100.5d? | 2008-03-07 | 2008-12-12 | 201d? | 270d | finish no earlier than 2008-12-12 | R2 | 1608h | 804h | RANimp-HSPAVoIP | Rel-8 | Joern |  |  |
| 425 | 92.12 | HS-DSCH Serving Cell Change Enhancements | 201d? | 2008-03-07 A | 2008-12-12 | 30% | 140.7d? | 2008-03-07 | 2008-12-12 | 201d? | 270d | finish no earlier than 2008-12-12 | R2 | 1608h | 482.4h | RANimp-HSDSCH | Rel-8 | Joern |  |  |
| 426 | 92.13 | MIMO for 1.28 Mcps TDD | 205d? | 2008-05-30 | 2009-03-12 |  |  | 2008-05-30 | 2009-03-12 | 205d? | 206d | finish no earlier than 2009-03-12 | R1 | 1640h |  | RANimp-MIMOLCR | Rel-8 | Patrick |  |  |
| 427 | 92.14 | Support for Additional Navigation Satellite Systems (ANSS) for LCS | 205d? | 2008-05-30 | 2009-03-12 |  |  | 2008-05-30 | 2009-03-12 | 205d? | 206d | finish no earlier than 2009-03-12 | R2 | 1640h |  | RANimp-ANSS | Rel-8 | Joern |  |  |
| 428 | 92.15 | Dual-Cell HSDPA operation on adjacent carriers | 270d? | 2008-05-30 | 2009-06-11 |  |  | 2008-05-30 | 2009-06-11 | 270d? | 141d | finish no earlier than 2009-06-11 | R1 | 2160h |  | RANimp-DCHSDPA | Rel-8 | Patrick |  |  |
| 429 | 93 | **RAN improvements - UE Conformance Testing** | 713d? | 2006-09-20 A | 2009-06-12 | 61% | 275.44d? | 2006-09-20 | 2009-06-12 | 713d? | 140d |  | R5 | 25520h | 15661.3h | RANimp-UEConTest |  | Ingbert |  |  |
| 430 | 93.1 | Conformance Test Aspects - 3.84 Mcps and 7.68 Mcps TDD Enhanced Uplink | 518d? | 2006-09-20 A | 2008-09-12 | 55% | 233.1d? | 2006-09-20 | 2008-09-12 | 518d? | 335d | finish no earlier than 2008-09-12 | R5 | 4144h | 2279.2h | RANimp-UEConTest_EDCHTDH | Rel-7 | Ingbert | IPWireless | tspeight@ipwireless.com |
| 431 | 93.2 | Conformance Test Aspects – 64QAM for HSDPA (FDD) | 257d? | 2007-03-09 A | 2008-03-03 A | 100% |  | 2007-03-09 | 2008-03-03 | 257d? |  | finish no earlier than 2008-03-03 | R5 | 2056h | 2056h | RANimp-UEConTest_64QamDownlink | Rel-7 | Ingbert | Ericsson | leif.mattisson@ericsson.com |
| 432 | 93.3 | Conformance Test Aspects – 16QAM for HSUPA (FDD) | 321d? | 2007-03-09 A | 2008-05-30 A | 100% |  | 2007-03-09 | 2008-05-30 | 321d? |  | finish no earlier than 2008-06-03 | R5 | 2568h | 2568h | RANimp-UEConTest_16QamUplink | Rel-7 | Ingbert | Motorola | carolyn.taylor@motorola.com |
| 433 | 93.4 | Conformance Test Aspects – Improved L2 support for high data rates | 257d? | 2007-03-09 A | 2008-03-03 A | 100% |  | 2007-03-09 | 2008-03-03 | 257d? |  | finish no earlier than 2008-03-03 | R5 | 2056h | 2056h | RANimp-UEConTest_L2DataRates | Rel-7 | Ingbert | Ericsson | leif.mattisson@ericsson.com |
| 434 | 93.5 | Conformance Test Aspects – Continuous connectivity for packet data users | 321d? | 2007-03-09 A | 2008-05-30 A | 100% |  | 2007-03-09 | 2008-05-30 | 321d? |  | finish no earlier than 2008-05-30 | R5 | 2568h | 2568h | RANimp-UEConTest_CPC | Rel-7 | Ingbert | Nokia | jarkko.hellsten@nokia.com |
| 435 | 93.6 | Conformance Test Aspects – Enhanced CELL_FACH state in FDD | 396d? | 2007-03-09 A | 2008-09-12 | 20% | 316.8d? | 2007-03-09 | 2008-09-12 | 396d? | 335d | finish no earlier than 2008-09-12 | R5 | 3168h | 633.6h | RANimp–UEConTest_EnhancedCellFACHState | Rel-7 | Ingbert | Nokia | jarkko.hellsten@nokia.com |
| 436 | 93.7 | Conformance Test Aspects – Improved L2 for uplink | 136d? | 2008-05-30 | 2008-12-05 |  |  | 2008-05-30 | 2008-12-05 | 136d? | 275d | finish no earlier than 2008-12-05 | R5 | 1088h |  | RANimp-UEConTest_UplinkL2dataRates | Rel-8 | Ingbert | Ericsson | Leif Mattisson |
| 437 | 93.8 | Conformance Test Aspects – 64QAM for 1.28Mcps TDD HSDPA | 271d? | 2008-05-30 | 2009-06-12 |  |  | 2008-05-30 | 2009-06-12 | 271d? | 140d | finish no earlier than 2009-06-12 | R5 | 2168h |  | RANimp-UEConTest_64Qam1.28TDD | Rel-8 | Ingbert | ZTE | Zijiang Ma |

Notes:
- 414: WID in RP-070500. Status Report in RP-080264, 80% complete for RAN4 (100% for other WGs). WI completed but SR still required @RAN#41 / Text3: 25.308, 25.211, 25.212, 25.213, 25.306, 25.331, 25.433, 25.435, 25.423, 25.425, 25.101, 25.104, 25.141
- 415: WID in RP-070717. Status Report in RP-080265 / Text3: 25.319, 25.301, 25.306, 25.321, 25.331, 25.433, 25.435, 25.423, 25.425, 25.427
- 416: WID in RP-070677. Status Report in RP-080266 / Text3: 25.309, 25.211, 25.214, 25.321, 25.331, 25.423, 25.433
- 417: WID in RP-070679. Status Report in RP-080267 / Text3: 25.306, 25.308, 25.321, 25.331, 25.423
- 418: WID in RP-070759. Status Report in RP-080268 / Text3: 25.306, 25.308, 25.321, 25.331, 25.423, 25.433, 25.214, 25.133
- 419: WID in RP-070760. Status Report in RP-080269 / Text3: 25.423, 25.427, 25.433
- 420: WID in RP-080050. Status report in RP-080270. / Text3: 25.201, 25.221, 25.222, 25.223, 25.224, 25.306, 25.308, 25.321, 25.331, 25.423, 25.433, 25.102, 25.105, 25.142
- 421: WID in RP-080051. Status report in RP-080271. / Text3: 25.308, 25.304, 25.306, 25.224, 25.321, 25.331, 25.433, 25.435, 25.423, 25.425, 25.123
- 422: WID in RP-071003. Status report in RP-080272. / Text3: 25.113
- 423: WID in RP-080085. Status report in RP-080273 / Text3: 25.929
- 424: WID in RP-080229. Status report in RP-080274
- 425: WID in RP-080227. Status report in RP-080275.
- 426: WID in RP-080485
- 427: WID in RP-080346
- 428: WID in RP-080490
- 429: 05/08: Linked to Feature UID_20029 (RANimp)
- 430: WID in RP-060484. Status report in RP-080280 / Text3: 34.108, 34.122, 34.123-1, 34.123-2, 34.123-3
- 431: WID in RP-071319. RAN#39 completed. Status Report RP-080059 / Text3: 34.108, 34.121-1, 34.121-2, 34.123-1, 34.123-2, 34.123-3
- 432: WID in RP-070022. RAN#40 completed. Status Report in RP-080281 / Text3: 34.108, 34.121-1, 34.121-2, 34.123-1, 34.123-2, 34.123-3
- 433: WID in RP-070020. Status Report RP-080061 / Text3: 34.108, 34.123-1, 34.123-2, 34.123-3
- 434: WID in RP-070023. RAN#40 completed. Status Report in RP-080282 / Text3: 34.108, 34.121-1, 34.121-2, 34.123-1, 34.123-2, 34.123-3
- 435: WID in RP-070425. Status Report in RP-080283 / Text3: 34.108, 34.123-1, 34.123-2, 34.123-3
- 436: WID in RP-080310, linked UID_370036. / Text3: 34.108, 34.123-1, 34.123-2, 34.123-3
- 437: WID in RP-080334, linked UID_380075 / Text3: 34.108, 34.122, 34.123-1, 34.123-2, 34.123-3

| ID | WBS | Task | Type | Duration | Start | Finish | Complete | Remaining | Baseline start | Baseline finish | Baseline duration | Total slack | Constraint | Resources | Work | Actual work | Text1 | Text6 | Text8 | Text4 | Text7 |
| --- | --- | --- | --- | --- | --- | --- | --- | --- | --- | --- | --- | --- | --- | --- | --- | --- | --- | --- | --- | --- | --- |
| 438 | 94 | **UTRA HNB** |  | 201d? | 2008-03-07 A | 2008-12-12 | 7% | 187.22d? | 2008-03-07 | 2008-12-12 | 201d? | 270d |  | R2,R4,R3 | 4432h | 303.84h | HNB | Rel-8 | Juergen |  |  |
| 439 | 94.1 | Support of UTRA HNB |  | 76d? | 2008-05-30 A | 2008-09-12 | 5% | 72.2d? | 2008-05-30 | 2008-09-12 | 76d? | 335d | finish no earlier than 2008-09-12 | R2 | 608h | 30.4h | HNB-supp | Rel-8 | Joern | Huawei |  |
| 440 | 94.2 | FDD Home NodeB RF requirements |  | 136d? | 2008-03-07 A | 2008-09-12 | 15% | 115.6d? | 2008-03-07 | 2008-09-12 | 136d? | 335d | start no earlier than 2008-03-07 | R4 | 1088h | 163.2h | HNB-RF | Rel-8 | Stefania | Motorola | TSG |
| 441 | 94.3 | UTRAN Architecture for 3G HNB |  | 141d? | 2008-05-30 | 2008-12-12 |  |  | 2008-05-30 | 2008-12-12 | 141d? | 270d | finish no earlier than 2008-12-12 | R3 | 1128h |  | HNB-arch | Rel-8 | Juergen | Alcatel-Lucent |  |
| 442 | 95 | **MBMS - UE Conformance Testing** |  | 596d? | 2007-06-01 A | 2009-09-11 | 9% | 540.94d? | 2007-06-01 | 2009-09-11 | 596d? | 75d |  | R5 | 12752h | 1178.08h | MBMSE_UEConTest |  | Ingbert |  |  |
| 443 | 95.1 | MBMS TDD Physical layer Enhancements – MBSFN for HCR and VHCR TDD – UE Conformance Test Aspects |  | 461d? | 2007-06-01 A | 2009-03-06 | 20% | 368.8d? | 2007-06-01 | 2009-03-06 | 461d? | 210d | start no earlier than 2007-06-01 | R5 | 3688h | 737.6h | MBMSE-RANPhysTDD_UEConTest | Rel-7 | Ingbert | IPWireless |  |
| 444 | 95.2 | UE conformance test aspects – MBMS LCR TDD Physical Layer Enhancement |  | 336d? | 2008-05-30 | 2009-09-11 |  |  | 2008-05-30 | 2009-09-11 | 336d? | 75d | finish no earlier than 2009-09-11 | R5 | 2688h |  | MBMSE-RANPhysLCRTDD_UEConTest | Rel-8 | Ingbert |  |  |
| 445 | 95.3 | Conformance Test Aspects – MBSFN for FDD |  | 201d? | 2008-05-30 | 2009-03-06 |  |  | 2008-05-30 | 2009-03-06 | 201d? | 210d | finish no earlier than 2009-03-06 | R5 | 1608h |  | MBMSE-UEConTest_RANPhysFDD | Rel-8 | Ingbert |  |  |
| 446 | 96 | Test - (Small) Technical Enhancements and Improvements for Rel-8 |  | 140d? | 2008-05-30 | 2008-12-11 |  |  | 2008-05-30 | 2008-12-11 | 140d? | 271d | start no earlier than 2008-05-30 | R5 | 1120h |  | TEI8_Test | Rel-8 | Ingbert | ALL |  |
| 447 | 97 | GERAN support for GERAN - 3G Long Term Evolution interworking |  | 641d? | 2006-09-08 A | 2009-02-20 | 70% | 192.3d? | 2006-09-08 | 2009-02-20 | 641d? | 220d | finish no earlier than 2009-02-20 | GP | 5128h | 3589.6h | GELTE | Rel-8 | Paolo | Nokia, NSN |  |
| 448 | 98 | U-TDOA Enhancement | milestone | 0d? | 2007-05-18 A | 2007-05-18 A | 100% |  | 2007-05-18 | 2007-05-18 | 0d? |  | finish no earlier than 2007-05-18 | GP |  |  | GUTEN | Rel-8 | Paolo | TruePosition |  |
| 449 | 99 | **GAN Enhancements** |  | 386d? | 2007-08-31 A | 2009-02-20 | 28% | 276.46d? | 2007-08-31 | 2009-02-20 | 386d? | 220d |  | GP | 7184h | 2038.74h | GANENH | Rel-8 | Paolo | T-Mobile |  |
| 450 | 99.1 | Update to GAN specifications |  | 126d? | 2007-08-31 A | 2008-02-22 A | 100% |  | 2007-08-31 | 2008-02-22 | 126d? |  | finish no earlier than 2008-02-22 | GP | 1008h | 1008h | GANENH-SPEC | Rel-8 | Paolo | T-Mobile |  |
| 451 | 99.2 | Update TS 51.010 Mobile Station (MS) Conformance Specification for GAN Enhancements |  | 386d? | 2007-08-31 A | 2009-02-20 | 5% | 366.7d? | 2007-08-31 | 2009-02-20 | 386d? | 220d | finish no earlier than 2009-02-20 | GP | 3088h | 154.4h | GANENH-MStest | Rel-8 | Ingbert | T-Mobile |  |
| 452 | 100 | **AoIP (A-interface over IP)** |  | 2334d? | 2000-01-03 A | 2008-12-11 | 87% | 302.91d? | 2000-01-03 | 2008-12-11 | 2334d? | 271d |  | GP,S4,C4,C1,C3 | 40316.1h | 35065.6h | AoIP | Rel-8 | Paolo | China Mobile, Ericsson |  |
| 453 | 100.1 | GERAN aspects of AoIP |  | 2320d? | 2000-01-03 A | 2008-11-21 | 90% | 232d? | 2000-01-03 | 2008-11-21 | 2320d? | 285d | finish no earlier than 2008-11-21 | GP | 18560h | 16704h | AoIP | Rel-8 | Paolo | China Mobile, Ericsson |  |
| 454 | 100.2 | Media Requirements for CS over IP based User Plane |  | 267d? | 2007-12-05 A | 2008-12-11 | 80% | 53.4d? | 2007-12-05 | 2008-12-11 | 267d? | 271d | finish no earlier than 2008-12-11 | S4 | 1996.09h | 1568.89h | AoIP-CSoIP | Rel-8 | Paolo | China Mobile, Ericsson |  |
| 455 | 100.3 | Core Network Impacts for A-Interface User Plane over IP |  | 136d? | 2008-05-30 A | 2008-12-05 | 50% | 68d? | 2008-05-30 | 2008-12-05 | 136d? | 275d | start no earlier than 2008-05-30 | C4,C1,C3 | 1088h | 544h | AoIP-CN | Rel-8 | Kimmo | Ericsson |  |
| 456 | 101 | New multicarrier BTS class |  | 261d? | 2007-08-31 A | 2008-08-29 A | 100% |  | 2007-08-31 | 2008-08-29 | 261d? |  | finish no earlier than 2008-08-29 | G1 | 2088h | 2088h | MCBTS | Rel-8 | Paolo | Alcatel-Lucent |  |
| 457 | 102 | Support for Additional Navigation Satellite Systems (ANSS) for LCS |  | 136d? | 2008-05-16 A | 2008-11-21 | 80% | 27.2d? | 2008-05-16 | 2008-11-21 | 136d? | 285d | start no earlier than 2008-05-16 | G2 | 1088h | 870.4h | ANSS | Rel-8 | Paolo | Qualcomm |  |
| 458 | 103 | **A-GNSS Performances and Testing Procedures** |  | 341d? | 2008-05-16 A | 2009-09-04 | 2% | 333.61d? | 2008-05-16 | 2009-09-04 | 341d? | 80d |  | GP | 7544h | 163.54h | AGNSSPTP | Rel-8 | Paolo | Thales |  |
| 459 | 103.1 | A-GNSS Minimum Performances |  | 261d? | 2008-05-16 A | 2009-05-15 | 5% | 247.95d? | 2008-05-16 | 2009-05-15 | 261d? | 160d | start no earlier than 2008-05-16 | G1 | 2088h | 104.4h | AGNSSPTP- Perfreq | Rel-8 | Paolo | Thales |  |
| 460 | 103.2 | A-GNSS Testing Procedures |  | 341d? | 2008-05-16 | 2009-09-04 |  |  | 2008-05-16 | 2009-09-04 | 341d? | 80d | start no earlier than 2008-05-16 | G3new | 2728h |  | AGNSSPTP-MStest | Rel-8 | Paolo | Thales |  |
| 461 | 104 | **Conformance testing for the Latency Reductions feature** |  | 196d? | 2008-02-22 A | 2008-11-21 | 68% | 63.7d? | 2008-02-22 | 2008-11-21 | 196d? | 285d |  | G1, G3new | 4704h | 3175.2h | CTLATRED | Rel-8 | Paolo | Ericsson |  |
| 462 | 104.1 | MS conformance testing for the Latency Reductions feature |  | 196d? | 2008-02-22 A | 2008-11-21 | 40% | 117.6d? | 2008-02-22 | 2008-11-21 | 196d? | 285d | finish no earlier than 2008-11-21 | G3new | 1568h | 627.2h | CTLATRED-MStest | Rel-8 | Ingbert | Ericsson |  |
| 463 | 104.2 | BTS conformance testing for the Latency Reductions feature |  | 196d? | 2008-02-22 A | 2008-11-21 | 95% | 9.8d? | 2008-02-22 | 2008-11-21 | 196d? | 285d | finish no earlier than 2008-11-21 | G1 | 1568h | 1489.6h | CTLATRED-BTStest | Rel-8 | Paolo | Ericsson |  |
| 464 | 105 | MS Conformance Tests of changes introduced by WI “Support of Packet-switched Handover for GERAN A/Gb mode” |  | 196d? | 2008-02-22 A | 2008-11-21 | 90% | 19.6d? | 2008-02-22 | 2008-11-21 | 196d? | 285d | finish no earlier than 2008-11-21 | G3new | 1568h | 1411.2h | PSHCT-MStest | Rel-8 | Ingbert | Rohde & Schwarz |  |
| 465 | 106 | Mobile Station conformance testing of Support of Conversational Services in A/Gb mode via the PS domain |  | 321d? | 2008-02-22 | 2009-05-15 |  |  | 2008-02-22 | 2009-05-15 | 321d? | 160d | finish no earlier than 2009-05-15 | G3new | 2568h |  | SCSAGBCT-MStest | Rel-8 | Ingbert | Nokia |  |
| 466 | 107 | (Small) Technical Enhancements and Improvements for Rel-8 |  | 509d? | 2007-01-01 A | 2008-12-11 | 70% | 152.7d? | 2007-01-01 | 2008-12-11 | 509d? | 271d | finish no earlier than 2008-12-11 | All | 4072h | 2850.4h | TEI8 | Rel-8 |  | ALL |  |

Notes:
- 438: RAN#40 WID approved RP-080483
- 439: WID in RP-080483. Status report in RP-080276. / Text3: 25.304, 25.331, 25.306 / Text5: YangXuDong
- 440: WID in RP-080234. Status report in RP-080277. / Text3: 25.104, 25.141 / Text5: Howard Thomas
- 441: WID in RP-080487 / Text3: 25.401, 25.410, 25.412, 25.413, 25.414, 25.415, 25.4xy / Text5: Martin Warner
- 443: WID in RP-080155. 05/08: Linked to Feature UID_31084 (MBMSE), BB UID_340043 (MBMSE-RANPhysTDD). Status Report in RP-080287. / Text3: 34.108, 34.122, 34.123-1/2/3 / Text5: tspeight@ipwireless.com
- 444: WID in RP-080318, linked UID_xyz
- 445: WID in RP-080336, linked UID 4582
- 446: Created on RAN5/JMM request
- 447: GP#39 completion target 11/08=>02/09 / Text3: 24.008, 43.055, 43.129, 43.246, 44.018, 44.060, 45.002, 45.008, 45.010, 48.008, 48.018, 51.010 / Text5: sergio.parolari@nsn.com, vlora.rexhepi@nokia.com
- 448: GP#36 completed / Text3: 43.059, 45.008, 48.071 / Text5: terri.brooks@trueposition.com
- 449: GP#37 specifications completed. Testing open / Text5: mohammed.versi@t-mobile.com
- 450: GP#37 completed / Text3: 43.318, 44.318 / Text5: mohammed.versi@t-mobile.com
- 451: GP#38 target 08/08=>11/08. GP#39 completion target 11/08=>02/09 / Text3: 51.010 / Text5: mohammed.versi@t-mobile.com
- 452: GP#39 updated WID GP-080901=>GP-081361. CT#40 WID approved. Triggered by TR 43.903 Study on A-interface over IP (AINTIP) UID_50589 / Text5: wangshuaiyu@chinamobile.com and paul.schliwa-bertling@ericsson.com
- 453: GP#39 updated WID GP-080901=>GP-081362 / Text3: 48.001, 48.002, 48.008, 48.020, 49.008, 48.103 / Text5: wangshuaiyu@chinamobile.com and paul.schliwa-bertling@ericsson.com
- 454: SA#40 WID approved / Text3: 26.102, 26.202, 26.103 / Text5: Karl.Hellwig@Ericsson.com
- 455: CT#40 WID approved / Text3: 23.205, 23.153, 23.231, 23.009, 29.232, 29.002, 29.007 / Text5: Phil Hodges
- 456: GP#39 completed / Text3: 45.005, 45.050, 51.021 / Text5: thomas.bitzer@alcatel-lucent.de
- 457: Testing de-coupled (completion 09/2009) / Text3: 43.059, 44.031, 49.031, 44.071, 48.031, 51.010 / Text5: Mungal Dhanda
- 458: GP#38 WID approved / Text5: Michel.monnerat@thalesaleniaspace.com
- 459: GP#38 WID approved / Text3: 45.005 / Text5: Michel.monnerat@thalesaleniaspace.com
- 460: GP#38 WID approved / Text3: 51.010-1 / Text5: Michel.monnerat@thalesaleniaspace.com
- 461: Text5: mats.y.samuelsson@ericsson.com and hakan.e.grunditz@ericsson.com
- 462: Text3: 51.010 / Text5: hakan.e.grunditz@ericsson.com
- 463: GP#39 completion target 08/08=>11/08 / Text3: 51.021 / Text5: mats.y.samuelsson@ericsson.com
- 464: Text3: 51.010 / Text5: Franz.Segerer@ROHDE-SCHWARZ.COM
- 465: Text3: 51.010 / Text5: arsi.heino@nokia.com

| ID | WBS | Task | Type | Duration | Start | Finish | Complete | Remaining | Baseline start | Baseline finish | Baseline duration | Total slack | Constraint | Resources | Work | Actual work | Text1 | Text4 | Text5 | Text6 | Text7 | Text8 | Text12 | Text3 |
| --- | --- | --- | --- | --- | --- | --- | --- | --- | --- | --- | --- | --- | --- | --- | --- | --- | --- | --- | --- | --- | --- | --- | --- | --- |
| 467 | 108 | **Deleted - All-IP Network** |  | 448d? | 2004-06-28 A | 2006-03-15 A | 100% |  | 2004-06-28 | 2006-03-15 | 448d? |  |  | S1 | 7168h | 7168h | AIPN | NTT DoCoMo | c.masyu@nttdocomo.co.jp | Rel-8 | TSG | Alain | SP-38 |  |
| 468 | 108.1 | Deleted - Stage 1 |  | 448d? | 2004-06-28 A | 2006-03-15 A | 100% |  | 2004-06-28 | 2006-03-15 | 448d? |  | finish no earlier than 2006-03-15 | S1 | 3584h | 3584h | AIPN | NTT DoCoMo | c.masyu@nttdocomo.co.jp | Rel-8 | TSG | Alain | SP-38 | 22.258 |
| 469 | 109 | Deleted - was Rel7 - LCS for 3GPP Interworking WLAN | milestone | 0d? | 2007-09-28 A | 2007-09-28 A | 100% |  | 2007-09-28 | 2007-09-28 | 0d? |  | start no earlier than 2007-09-28 | S2 |  |  | LCS4_IWLAN | LG Electronics | dhshim@lge.com | Rel-8 |  | Maurice | SP-35 | 23.234, 23.271, 23.167 |
| 470 | 110 | Deleted - never approved- FBI Phase 2 | milestone | 0d | 2007-09-28 A | 2007-09-28 A | 100% |  | 2007-09-28 | 2007-09-28 | 0d |  | start no earlier than 2007-09-28 | S2 |  |  | FBI2 | NSN |  | Rel-8 | TSG | Maurice | SP-38 |  |
| 471 | 111 | Deleted -Enhancements to BS30 Bearer service for Videotelephony | milestone | 0d? | 2007-03-15 A | 2007-03-15 A | 100% |  | 2007-03-15 | 2007-03-15 | 0d? |  | finish no earlier than 2007-03-15 | S1 |  |  | BS30 |  | andre.jarvis@three.co.uk | Rel-8 |  | Alain | SP-38 | 22.002, 22.004, 22.101, 22.105, 24.008 |
| 472 | 112 | Deleted - IMS Enhancements Rel-8 |  | 75d? | 2007-09-03 A | 2007-12-14 A | 100% |  | 2007-09-03 | 2007-12-14 | 75d? |  |  | S1 | 600h | 600h | IMS8 | Telecom Italia |  | Rel-8 |  | Alain | SP-38 |  |
| 473 | 113 | Release 8 Feasibility Studies | milestone | 0d? | 2008-03-20 | 2008-03-20 |  |  | 2008-03-20 | 2008-03-20 | 0d? | 461d | finish no earlier than 2008-03-20 | CP,GP,RP,SP |  |  |  |  |  | Rel-8 |  |  |  |  |
| 474 | 114 | Study on Customised Alerting Tone (CAT) Requirements |  | 245d? | 2005-10-07 A | 2006-09-14 A | 100% |  | 2005-10-07 | 2006-09-14 | 245d? |  | start no earlier than 2005-10-07 | S1 | 1960h | 1960h | FS_CAT | China Mobile | fenglingjuan@chinamobile.com | Rel-8 |  | Michael |  | 22.982 |
| 475 | 115 | Study on Facilitating Machine to Machine Communication in GSM and UMTS (M2M) |  | 350d? | 2005-11-04 A | 2007-03-08 A | 100% |  | 2005-11-04 | 2007-03-08 | 350d? |  | finish no earlier than 2006-06-16 | S1 | 2800h | 2800h | FS_M2M | Siemens | Juergen Merkel | Rel-8 |  | Alain |  | 22.868 |
| 476 | 116 | Study on Network Composition |  | 526d? | 2005-12-07 A | 2007-12-12 A | 100% |  | 2005-12-07 | 2007-12-12 | 526d? |  | finish no earlier than 2006-09-27 | S1 | 4208h | 4208h | FS_NetComp | Siemens | joerg.swetina@siemens.com | Rel-8 |  | Alain |  | 22.980 |
| 477 | 117 | Study on Requirements of IMS Multimedia Conferencing |  | 330d? | 2006-06-08 A | 2007-09-12 A | 100% |  | 2006-06-08 | 2007-09-12 | 330d? |  | finish no earlier than 2007-03-21 | S1 | 2640h | 2640h | FS_IMSconf | China Mobile | zhengjianping@chinamobile.com | Rel-8 |  | Alain |  | 22.948 |
| 478 | 118 | Study on support of a Public Warning System |  | 140d? | 2007-09-03 A | 2008-03-14 A | 100% |  | 2007-09-03 | 2008-03-14 | 140d? |  |  | S1 | 1120h | 1120h | FS_PWS | T-Mobile | mark.younge@t-mobile.com | Rel-8 |  | Alain |  | 22.968 |
| 479 | 119 | Study on Paging Permission with Access Control |  | 256d? | 2006-09-28 A | 2007-09-20 A | 100% |  | 2006-09-28 | 2007-09-20 | 256d? |  | finish no earlier than 2007-09-20 | S1 | 2048h | 2048h | FS_PPAC | NTT DoCoMo | noguchi@nttdocomo.co.jp | Rel-8 |  | Alain |  | 22.908 |
| 480 | 120 | Study on Non 3GPP access NSP |  | 392d? | 2006-12-06 A | 2008-06-05 A | 100% |  | 2006-12-06 | 2008-06-05 | 392d? |  | finish no earlier than 2007-11-19 | S1 | 3136h | 3136h | FS_N3GtoNSP | Telefonica O2 | chris.friel@o2.com | Rel-8 |  | Alain |  | 22.912 |
| 481 | 121 | Study on Value Added Services for Short Message Service |  | 263d? | 2006-12-06 A | 2007-12-07 A | 100% |  | 2006-12-06 | 2007-12-07 | 263d? |  | finish no earlier than 2007-12-07 | S1 | 2104h | 2104h | FS_VAS4SMS | China Mobile | wubin@chinamobile.com | Rel-8 |  | Alain |  | 22.942 |
| 482 | 122 | Study on Service continuity between mobile and WLAN networks |  | 537d? | 2006-12-06 A | 2008-12-25 A | 100% |  | 2006-12-06 | 2008-12-25 | 537d? |  | finish no earlier than 2008-12-25 | S1 | 4296h | 4296h | FS_SMLSWLAN | BT | mike.meyerstein@bt.com | Rel-8 |  | Alain |  | 22.937 |
| 483 | 123 | Study on Services Alignment and Migration |  | 331d? | 2006-12-06 A | 2008-03-12 A | 100% |  | 2006-12-06 | 2008-03-12 | 331d? |  | finish no earlier than 2007-09-20 | S1 | 2648h | 2648h | FS_ServAl | China Mobile | fenglingjuan@chinamobile.com | Rel-8 |  | Alain |  | 22.983 |
| 484 | 124 | **Study on 3GPP System Architecture Evolution** |  | 1050d? | 2004-12-03 A | 2008-12-11 | 90% | 105d? | 2004-12-03 | 2008-12-11 | 1050d? | 271d |  | S2,S3 | 21736h | 19562.4h | FS_SAE | Vodafone | Chris Pudney | Rel-8 | TSG | Maurice |  | 23.882 |
| 485 | 124.1 | Stage 2 Interim conclusion for RAN Work to start |  | 915d? | 2004-12-03 A | 2008-06-05 | 90% | 91.5d? | 2004-12-03 | 2008-06-05 | 915d? | 406d | finish no earlier than 2005-09-23 | S2 | 7320h | 6588h | FS_SAE | Vodafone | Chris Pudney | Rel-8 |  | Maurice |  | 23.882 |
| 486 | 124.2 | Stage 2 study on 3GPP architectural development |  | 629d? | 2006-01-09 A | 2008-06-05 | 90% | 62.9d? | 2006-01-09 | 2008-06-05 | 629d? | 406d | finish no earlier than 2007-09-28 | S2 | 5032h | 4528.8h | FS_SAE | Vodafone | Chris Pudney | Rel-8 |  | Maurice |  | 23.882 |
| 487 | 124.3 | Security study for Inter-access mobility between non 3GPP and 3GPP system |  | 334d? | 2007-09-03 A | 2008-12-11 | 90% | 33.4d? | 2007-09-03 | 2008-12-11 | 334d? | 271d | finish no earlier than 2008-12-11 | S3 | 2672h | 2404.8h | FS_SAE | Nokia | dajiang.zhang@nokia.com | Rel-8 |  | Dionisio |  | 33.821, 33.922 |
| 488 | 125 | Study on Stage 2 aspects of IMS Service Brokering |  | 581d? | 2006-06-19 A | 2008-09-08 | 55% | 261.45d? | 2006-06-19 | 2008-09-08 | 581d? | 339d | finish no earlier than 2008-09-08 | S2 | 4648h | 2556.4h | FS_ISB_ST2 | Telcordia | raquel@research.telcordia.com | Rel-8 |  | Maurice |  | 23.810 |
| 489 | 126 | Study on VCC support for Emergency Calls |  | 657d? | 2006-06-08 A | 2008-12-12 | 35% | 427.05d? | 2006-06-08 | 2008-12-12 | 657d? | 270d | finish no earlier than 2008-12-12 | S2 | 5256h | 1839.6h | FS_VCCEm | Nortel |  | Rel-8 |  | Maurice |  | 23.826 |
| 490 | 127 | Study on IMS utilizing multicast bearer services |  | 447d? | 2006-03-22 A | 2007-12-06 A | 100% |  | 2006-03-22 | 2007-12-06 | 447d? |  | finish no earlier than 2007-12-03 | S2 | 3576h | 3576h | FS_MLTICAST-IMS | NSN |  | Rel-8 |  | Maurice |  | 23.847 |
| 491 | 128 | Study on Mobility between 3GPP-WLAN Interworking and 3GPP Systems |  | 393d? | 2007-03-20 A | 2008-09-18 | 60% | 157.2d? | 2007-03-20 | 2008-09-18 | 393d? | 331d | finish no earlier than 2008-09-18 | S2 | 3144h | 1886.4h | FS_SM3GWLAN | Orange | orange | Rel-8 |  | Maurice |  | 23.827 |
| 492 | 129 | Study on Multimedia Session Continuity |  | 291d? | 2007-04-26 A | 2008-06-05 A | 100% |  | 2007-04-26 | 2008-06-05 | 291d? |  | finish no earlier than 2008-06-05 | S2 | 2328h | 2328h | FS_MMSC | LG Electronics |  | Rel-8 |  | Maurice |  | 23.893 |

Notes:
- 467: SA#38 stopped. 25/07/08 Moved UID_31059 Study on All-IP Network (FS_AIPN/was AIPFS ) to Rel-7 out of the stopped Rel-8 Feature UID_31067 Deleted - All-IP Network (AIPN)
- 468: 22.258 withdrawn, superseded by 22.278 (UID 320022). SA#38 stopped
- 469: SP-35 stopped
- 470: SA#38 stopped
- 471: SA#38 stopped (no support)
- 472: SA#38 stopped
- 475: SA#35 completed. Spin-off SA3 SID UID_370053. SA#40 Spin-off new Feature UID_400033 (NIMTC)
- 476: SA#38 completed
- 477: SA#37 completed. Spin-off New Feature UID_370026 (VAS4SM)
- 478: SA#39 completed. Spin-off Rel-9 Feature UID_380057 (PWS)
- 479: SA#37 completed. Spin-off new Feature UID_370084 (PPACR)
- 480: SA#38 completed. Spin-off New Feature UID_380062 (N3GTONSP). SA#40 WID updated SP-060930=>SP-080318. TR re-approved with new # 22.812=>22.912
- 481: SA#38 completed. Spin-off New Feature UID_370026 (VAS4SM)
- 482: SA#38 completed
- 483: SA#39 completed. Spin-off Feature UID_330017 (ServAl)
- 484: Moved from Rel-7
- 485: TR 23.882 is 100% complete, but technically out-of-date. SA2 to submit for SA#40 Approval with disclaimer text.
- 486: TR 23.882 is 100% complete, but technically out-of-date. SA2 to submit for SA#40 Approval with disclaimer text.
- 487: Moved from Rel-7
- 488: IMS Service Brokering enhancements UID_31088 moved back from R8 to R7 to give a home to 22228CR0036_(Rel-7)_S1-051232. Hence, Rel-7 ISB has Stage 1 only (and is misaligned with Rel-7 Stages 2/3. SA#32 SID approved
- 490: SA#38 completed
- 491: 08/08/08 TR 23.827 v 0.4.0 no progress for 1 year. MCC recommended FS be completed and 23.827 brought under CR as Rel-9 ASAP or better as Rel-8
- 492: SA#40 completed

| ID | WBS | Task | Duration | Start | Finish | Complete | Remaining | Baseline start | Baseline finish | Baseline duration | Total slack | Constraint | Resources | Work | Actual work | Text1 | Text4 | Text5 | Text6 | Text8 | Text3 | Text12 |
| --- | --- | --- | --- | --- | --- | --- | --- | --- | --- | --- | --- | --- | --- | --- | --- | --- | --- | --- | --- | --- | --- | --- |
| 493 | 130 | **Study on centralized IMS service control** | 363d? | 2006-10-23 A | 2008-03-12 A | 100% |  | 2006-10-23 | 2008-03-12 | 363d? |  |  | S2,S1 | 7952h | 7952h | FS_ICS | Ericsson | peter.bleckert@ericsson.com | Rel-8 | Alain |  |  |
| 494 | 130.1 | Study on centralized IMS services requirements | 268d? | 2007-03-05 A | 2008-03-12 A | 100% |  | 2007-03-05 | 2008-03-12 | 268d? |  | start no earlier than 2007-03-05 | S1 | 2144h | 2144h | FS_ICS-S1 | Ericsson | peter.bleckert@ericsson.com | Rel-8 | Alain | 22.892 |  |
| 495 | 130.2 | Study on centralized IMS services control | 363d? | 2006-10-23 A | 2008-03-12 A | 100% |  | 2006-10-23 | 2008-03-12 | 363d? |  | finish no earlier than 2008-02-21 | S2 | 2904h | 2904h | FS_IMS_CSC | Alcatel-Lucent | andybennett@Alcatel-Lucent.com | Rel-8 | Maurice | 23.892 |  |
| 496 | 131 | Study on Protection against SMS and MMS spam | 657d? | 2006-06-08 A | 2008-12-12 | 30% | 459.9d? | 2006-06-08 | 2008-12-12 | 657d? | 270d | finish no earlier than 2008-12-12 | S3 | 5256h | 1576.8h | FS_CPSMal | Orange | eric.gauthier@orange.ch | Rel-8 | Dionisio | 33.9xx |  |
| 497 | 132 | Study on Transferring of emergency call data – in-band modem solution | 265d? | 2006-12-07 A | 2007-12-12 A | 100% |  | 2006-12-07 | 2007-12-12 | 265d? |  | finish no earlier than 2008-09-18 | S4 | 2120h | 2120h | eCALLIBMS | Airbiquity | lhong@airbiquity.com | Rel-8 | Paolo | 26.967 |  |
| 498 | 133 | Study on Element Operations Systems Function (EOSF) definition | 266d? | 2007-06-07 A | 2008-06-12 A | 100% |  | 2007-06-07 | 2008-06-12 | 266d? |  | finish no earlier than 2008-12-11 | S5 | 2128h | 2128h | OAM7-NIM- EOSF | China Mobile | LI, Jian | Rel-8 | Dionisio | 32.819 |  |
| 499 | 134 | Study on SA5 MTOSI XML Harmonization | 351d? | 2006-05-10 A | 2007-09-12 A | 100% |  | 2006-05-10 | 2007-09-12 | 351d? |  | finish no earlier than 2007-12-14 | S5 | 2808h | 2808h | OAM7-NIM-XML | Nortel | jduguay@nortel.com | Rel-8 | Dionisio | 32.818 |  |
| 500 | 135 | Study on Common Profile Storage (CPS) Framework of User Data for network services and management | 244d? | 2006-07-03 A | 2007-06-07 A | 100% |  | 2006-07-03 | 2007-06-07 | 244d? |  | finish no earlier than 2007-06-07 | S5 | 1952h | 1952h | OAM7-CPS | T-Mobile | ABA, Istvan | Rel-8 | Dionisio | 32.808 |  |
| 501 | 136 | Study on Management for LTE and SAE | 526d? | 2006-12-07 A | 2008-12-11 | 95% | 26.3d? | 2006-12-07 | 2008-12-11 | 526d? | 271d | finish no earlier than 2008-12-11 | S5 | 4208h | 3997.6h | FS_OAM_LTE_SAE | Ericsson | PETERSEN, Robert | Rel-8 | Dionisio | 32.816 |  |
| 502 | 137 | Study on Charging Aspects of 3GPP System Evolution | 179d? | 2007-04-02 A | 2007-12-06 A | 100% |  | 2007-04-02 | 2007-12-06 | 179d? |  | finish no earlier than 2007-12-06 | S5 | 1432h | 1432h | FS_SAEcharg | NSN | GÖRMER, Gerald | Rel-8 | Dionisio | 32.820 |  |
| 503 | 138 | Study on System Maintenance over Itf-N | 396d? | 2007-06-07 A | 2008-12-11 | 65% | 138.6d? | 2007-06-07 | 2008-12-11 | 396d? | 271d | finish no earlier than 2008-12-11 | S5 | 3168h | 2059.2h | FS_OAM-Maint-Itf-N | ZTE | HUANG, Shuqiang | Rel-8 | Dionisio | 32.822 |  |
| 504 | 139 | Study on Self-Organizing Networks (SON) related OAM interfaces for Home NodeB | 396d? | 2007-06-07 A | 2008-12-11 | 45% | 217.8d? | 2007-06-07 | 2008-12-11 | 396d? | 271d | finish no earlier than 2008-12-11 | S5 | 3168h | 1425.6h | FS_OAM-SON-HNB | Huawei | YANG, Li | Rel-8 | Dionisio | 32.821 |  |
| 505 | 140 | Study on Self-healing of Self-Organizing Networks (SON) | 275d? | 2008-02-22 A | 2009-03-12 | 15% | 233.75d? | 2008-02-22 | 2009-03-12 | 275d? | 206d | finish no earlier than 2009-03-12 | S5 | 2200h | 330h | FS_OAM-SON-SH | Huawei | WANG, Xuelong | Rel-8 | Dionisio | 32.823 |  |
| 506 | 141 | Study on AS-MRFC media server control protocol | 583d? | 2006-03-22 A | 2008-06-13 A | 100% |  | 2006-03-22 | 2008-06-13 | 583d? |  | finish no earlier than 2008-06-13 | C1 | 4664h | 4664h | MRFC | HP | mark.syrett@hp.com | Rel-8 | Frederic | 24.880 |  |
| 507 | 142 | Study on IMS Restoration Procedures | 310d? | 2007-03-26 A | 2008-05-30 A | 100% |  | 2007-03-26 | 2008-05-30 | 310d? |  | finish no earlier than 2008-05-30 | C4 | 2480h | 2480h | FS_IMS_RP | Ericsson | german.blanco@ericsson.com | Rel-8 | Kimmo | 23.820 |  |
| 508 | 143 | Study on IMS Application Server Service Data Descriptions for AS interoperability | 261d? | 2007-09-14 A | 2008-09-12 A | 100% |  | 2007-09-14 | 2008-09-12 | 261d? |  | finish no earlier than 2008-09-12 | C4 | 2088h | 2088h | FS_IMS_ASIO | Alcatel-Lucent | nhberry@ALCATEL-LUCENT.COM | Rel-8 | Kimmo | 29.864 |  |
| 509 | 144 | IMS Application Server Service Data Descriptions for AS interoperability | 60d? | 2008-09-12 A | 2008-12-05 | 5% | 57d? | 2008-09-12 | 2008-12-05 | 60d? | 275d | finish no earlier than 2008-09-12 | C4 | 480h | 24h | IMS_ASIO | Alcatel-Lucent | nhberry@ALCATEL-LUCENT.COM | Rel-8 | Kimmo | 29.328, 29.329, 29.new |  |
| 510 | 145 | Study on Customized Alerting Tone (CAT) solution for voice and video call in CS domain | 261d? | 2007-09-14 A | 2008-09-12 A | 100% |  | 2007-09-14 | 2008-09-12 | 261d? |  |  | C4 | 626.4h | 626.4h | FS_CAT_VVC_CS | China Mobile | zhanghao@chinamobile.com | Rel-8 | Kimmo | 29.new |  |
| 511 | 146 | Study on InterWorking Function between MAP based and Diameter based interfaces | 271d? | 2007-11-30 A | 2008-12-12 A | 100% |  | 2007-11-30 | 2008-12-12 | 271d? |  | finish no earlier than 2008-12-12 | C4 | 2168h | 2168h | FS_MAP2Diam | Huawei | liming49985@HUAWEI.COM | Rel-8 | Kimmo | 29.805 |  |
| 512 | 147 | InterWorking Function (IWF) between MAP based and Diameter based interfaces | 61d? | 2008-09-12 A | 2008-12-05 | 20% | 48.8d? | 2008-09-12 | 2008-12-05 | 61d? | 275d | start no earlier than 2008-09-12 | C4 | 488h | 97.6h | MAP2Diam | Huawei | liming49985@HUAWEI.COM | Rel-8 | Kimmo | 29.new |  |
| 513 | 148 | Study on Scope of future HSPA Evolution for 1.28Mcps TDD | 186d? | 2007-09-14 A | 2008-05-30 A | 100% |  | 2007-09-14 | 2008-05-30 | 186d? |  | finish no earlier than 2008-05-30 | R1 | 1488h | 1488h | FS_RAN-LCRTDDHSPAEvo | RITT | Xu Fei | Rel-8 | Patrick | 25.824 |  |
| 514 | 149 | Study on Synchronized E-DCH for UTRA FDD | 126d? | 2007-09-14 A | 2008-03-07 A | 100% |  | 2007-09-14 | 2008-03-07 | 126d? |  | finish no earlier than 2008-03-14 | R1 | 1008h | 1008h | FS_RAN-UplinkSync | NSN | Karri.Ranta-aho@nsn.com | Rel-8 | Patrick | 25.823 |  |
| 515 | 150 | Study on Dual-Cell HSDPA operation | 196d? | 2008-03-07 A | 2008-12-05 | 75% | 49d? | 2008-03-07 | 2008-12-05 | 196d? | 275d | finish no earlier than 2008-12-05 | R1,R4 | 1568h | 1176h | FS_RAN-DCHS | Qualcomm | Josef Blanz | Rel-8 | Patrick | 25.825 |  |
| 516 | 151 | Study on Improved network controlled mobility between LTE and 3GPP2/mobile WiMAX radio technologies | 131d? | 2007-06-04 A | 2007-12-03 A | 100% |  | 2007-06-04 | 2007-12-03 | 131d? |  | finish no earlier than 2007-12-03 | R4 | 1048h | 1048h | FS_RAN-LTEmob | Motorola | hao.bi@Motorola.com | Rel-8 | Joern | 36.938 |  |
| 517 | 152 | Study on 3G Home NodeB/eNodeB | 325d? | 2007-03-05 A | 2008-05-30 A | 100% |  | 2007-03-05 | 2008-05-30 | 325d? |  | finish no earlier than 2008-05-30 | R4 | 2600h | 2600h | FS_RAN-HNBeNB | Motorola | Howard Thomas | Rel-8 | Stefania | 25.820 |  |
| 518 | 153 | Study on Evaluation of the inclusion of Path Loss Based Technology in the UTRAN | 195d? | 2007-12-17 A | 2008-09-12 | 10% | 175.5d? | 2007-12-17 | 2008-09-12 | 195d? | 335d | start no earlier than 2007-12-17 | R4 | 1560h | 156h | FS_RAN-Pathloss | Polaris Wireless | Norman Shaw | Rel-8 | Stefania | 25.9xx |  |
| 519 | 154 | Study on HS-PDSCH serving cell change enhancements | 60d? | 2007-12-17 A | 2008-03-07 A | 100% |  | 2007-12-17 | 2008-03-07 | 60d? |  | finish no earlier than 2008-06-12 | R4 | 480h | 480h | FS_RAN-HSPDSCH | Qualcomm |  | Rel-8 | Stefania | none |  |
| 520 | 155 | Study on A-interface over IP | 126d? | 2007-08-31 A | 2008-02-22 A | 100% |  | 2007-08-31 | 2008-02-22 | 126d? |  | finish no earlier than 2008-02-22 | GP | 1008h | 1008h | AINTIP | China Mobile, Ericsson | paul.schliwa-bertling@ericsson.com | Rel-8 | Paolo | 43.903 |  |
| 521 | 156 | Study on Multi-User Reusing-One-Slot | 266d? | 2007-11-16 A | 2008-11-21 | 70% | 79.8d? | 2007-11-16 | 2008-11-21 | 266d? | 285d | finish no earlier than 2008-11-21 | GP | 2128h | 1489.6h | MUROS | NSN | juergen.hofmann@nsn.com | Rel-8 | Paolo | TR |  |
| 522 | 157 | Study on Optimized Transmit Pulse Shape for Downlink EGPRS2-B | 266d? | 2007-11-16 A | 2008-11-21 | 50% | 133d? | 2007-11-16 | 2008-11-21 | 266d? | 285d | finish no earlier than 2008-11-21 | G1 | 2128h | 1064h | WIDER | RIM, NSN | jdwyer@RIM.COM and eddie.riddington@nsn.com | Rel-8 | Paolo | 45.9xx |  |
| 523 | 158 | Deleted - equals 340035 -FS on Service continuity between mobile and WLAN networks | 75d? | 2007-09-03 A | 2007-12-14 A | 100% |  | 2007-09-03 | 2007-12-14 | 75d? |  | finish no earlier than 2007-12-14 | S1 | 600h | 600h | FSSCMobToW | BT | mike.meyerstein@bt.com | Rel-8 | Alain | 22.937 | SP-39 |
| 524 | 159 | Deleted - Study on Evaluation of LCS Control Plane Solution for EPS | 100d? | 2008-01-14 A | 2008-05-30 A | 100% |  | 2008-01-14 | 2008-05-30 | 100d? |  | finish no earlier than 2009-03-20 | S2 | 800h | 800h | FS_LCS_EPS | SiRF Technology |  | Rel-8 | Maurice | none | SP-40 |
| 525 | 160 | Release 7 Features | 1d? | 2000-01-03 | 2000-01-03 |  |  | 2000-01-03 | 2000-01-03 | 1d? | 2604d | start no earlier than 2000-01-01 | CP,GP, RP,SP | 8h |  |  |  |  | Rel-7 |  |  |  |

Notes:
- 493: SA#39 completed
- 494: SA#39 completed
- 495: SA#39 completed
- 496: Mechanisms to define spam messages still being evaluated. No progress
- 497: SA#38 completed. Spin-off WID UID_34042 (eCall_Phase2)
- 498: SID updated SP-050608=>SP-070307; SA#40 completed
- 499: SID updated SP-050295=>SP-070305; SA#37 completed
- 500: SA#36 completed. Spin-off New Feature UID_400034 (UDC)
- 501: Slow progress
- 502: SA#38 completed
- 503: Slow progress
- 504: Slow progress
- 505: SA#39 SID approved. Slow progress
- 506: CT#40 completed. Spin-off New Feature UID_380035 (MRFC_TS)
- 507: CT#40 completed. Spin-off WID UID_400012 (IMS_RP)
- 508: CT#41 completed. Spin-off WID UID_4100xy (IMS_ASIO)
- 509: Triggered by UID_360030 (FS_IMS_ASIO). CT#41 WID approved
- 510: CT#41 completed
- 511: CT#41 completed. Spin-off WID UID_4100xy (MAP2Diam)
- 512: Triggered by UID_ 380023 (FS_MAP2Diam). CT#41 WID approved
- 513: SID in RP-070748. RAN#40 completed. Status Report in 080290
- 514: SID in RP-070678. RAN#39 completed. Status Report in RP-080068
- 515: SID in RP-080228. Status Report in RP-080292, SI is on hold. New WI approved in RP-080490 Dual-Cell HSDPA operation on adjacent carriers (RANimp-DCHSDPA) UID_400052.
- 516: SID in RP-070511. Status Report in RP-070827. RAN#38 completed
- 517: SID in RP-070257. RAN#40 completed. Status Report in RP-080289
- 518: SID in RP-071050. Status Report in RP-080291
- 519: SID in RP-071044. Status Report in RP-080070. The study produced no TR. RAN#39 completed. Spin-off New implementation WID in RP-080227
- 520: GP#37 completed. Spin-off implementation Feature AoIP (A-interface over IP) UID_50591
- 521: GP#39 completion target 08/08=>11/08
- 522: GP#38 completion target 08/08=>11/08.
- 523: SA#39 stopped
- 524: SA#38 SID approved. SA#40 spin-off Feature UID_400038 (LCS_CPS_EPS). SP-40 FS stopped

| ID | WBS | Task | Type | Duration | Start | Finish | Complete | Baseline start | Baseline finish | Baseline duration | Total slack | Constraint | Resources | Work | Actual work | Text1 | Text4 | Text5 | Text6 | Text8 | Text12 | Text7 | Text2 | Text9 |
| --- | --- | --- | --- | --- | --- | --- | --- | --- | --- | --- | --- | --- | --- | --- | --- | --- | --- | --- | --- | --- | --- | --- | --- | --- |
| 526 | 161 | **Identification of Communication Services in IMS** |  | 620d? | 2005-05-02 A | 2007-09-14 A | 100% | 2005-05-02 | 2007-09-14 | 620d? |  |  | S2,S1,C1,S5 | 13016h | 13016h | ServID | Ericsson | stephen.terrill@ericsson.com | Rel-7 | Maurice |  |  |  |  |
| 527 | 161.1 | TR on ServID |  | 232d? | 2005-05-02 A | 2006-03-21 A | 100% | 2005-05-02 | 2006-03-21 | 232d? |  | finish no earlier than 2006-03-20 | S2 | 1856h | 1856h | ServID | Ericsson | stephen.terrill@ericsson.com | Rel-7 | Maurice |  |  |  |  |
| 528 | 161.2 | Stage 1,2 of ServID |  | 144d? | 2005-11-11 A | 2006-05-31 A | 100% | 2005-11-11 | 2006-05-31 | 144d? |  | start no earlier than 2005-11-11 | S1,S2 | 1152h | 1152h | ServID | Ericsson | stephen.terrill@ericsson.com | Rel-7 | Maurice |  |  |  |  |
| 529 | 161.3 | Stage 3 of ServID |  | 250d? | 2006-03-31 A | 2007-03-15 A | 100% | 2006-03-31 | 2007-03-15 | 250d? |  | finish no earlier than 2007-03-15 | C1 | 2000h | 2000h | ServID | Ericsson | christer.holmberg@ericsson.com | Rel-7 | Frederic |  |  |  |  |
| 530 | 161.4 | Charging of ServID |  | 381d? | 2006-03-31 A | 2007-09-14 A | 100% | 2006-03-31 | 2007-09-14 | 381d? |  | finish no earlier than 2007-09-14 | S5 | 3048h | 3048h | ServID | Orange | alain.bibas@orange-ft.com | Rel-7 | Adrian |  |  |  |  |
| 531 | 162 | **Supporting Globally Routable User Agent URIs in IMS** |  | 415d? | 2005-11-14 A | 2007-06-15 A | 100% | 2005-11-14 | 2007-06-15 | 415d? |  |  | S2,S1,C1 | 7760h | 7760h | GRUU | RIM | abuckley@rim.com | Rel-7 | Maurice |  |  |  |  |
| 532 | 162.1 | Deleted - TR on GRUU |  | 219d? | 2005-11-14 A | 2006-09-14 A | 100% | 2005-11-14 | 2006-09-14 | 219d? |  | finish no earlier than 2006-09-14 | S2 | 1752h | 1752h | GRUU | RIM | abuckley@rim.com | Rel-7 | Maurice | SP-32 |  |  |  |
| 533 | 162.2 | Stage 1,2 of GRUU |  | 65d? | 2006-07-03 A | 2006-09-29 A | 100% | 2006-07-03 | 2006-09-29 | 65d? |  | start no earlier than 2006-07-03 | S1,S2 | 520h | 520h | GRUU | RIM | abuckley@rim.com | Rel-7 | Maurice |  |  |  |  |
| 534 | 162.3 | Stage 3 of GRUU |  | 271d? | 2006-06-02 A | 2007-06-15 A | 100% | 2006-06-02 | 2007-06-15 | 271d? |  | finish no earlier than 2007-06-15 | C1 | 2168h | 2168h | GRUU | CableLabs | Bernie McKibben | Rel-7 | Frederic |  |  |  |  |
| 535 | 163 | **Multimedia Telephony Service for IMS** |  | 357d? | 2006-02-01 A | 2007-06-15 A | 100% | 2006-02-01 | 2007-06-15 | 357d? |  |  | S1,C1,S4 | 8976h | 8976h | MTSI | Ericsson | peter.bleckert @ericsson.com | Rel-7 | Patrick |  |  |  |  |
| 536 | 163.1 | Stage 1 of MTSI |  | 173d? | 2006-02-01 A | 2006-09-29 A | 100% | 2006-02-01 | 2006-09-29 | 173d? |  | start no earlier than 2006-02-01 | S1 | 1384h | 1384h | MTSI-REQ | Ericsson | peter.bleckert @ericsson.com | Rel-7 | Alain |  |  |  |  |
| 537 | 163.2 | Stage 3 of MTSI |  | 330d? | 2006-03-10 A | 2007-06-15 A | 100% | 2006-03-10 | 2007-06-15 | 330d? |  | finish no earlier than 2007-06-15 | C1 | 2640h | 2640h | MTSI | Ericsson | christer.holmberg@ericsson.com | Rel-7 | Frederic |  |  |  |  |
| 538 | 163.3 | Media handling and interaction in MTSI |  | 262d? | 2006-03-15 A | 2007-03-15 A | 100% | 2006-03-15 | 2007-03-15 | 262d? |  | finish no earlier than 2007-03-15 | S4 | 2096h | 2096h | MTSI-MHI | Ericsson | olle.franceschi@ericsson.com | Rel-7 | Paolo |  |  |  |  |
| 539 | 163.4 | Deleted - duplicates UID7039 - IMS Multimedia Telephony Service | milestone | 0d? | 2007-06-15 A | 2007-06-15 A | 100% | 2007-06-15 | 2007-06-15 | 0d? |  | start no earlier than 2007-06-15 | S1 |  |  | MMTEL | Ericsson | peter.bleckert @ericsson.com | Rel-7 | Mike | SP-32 |  |  |  |
| 540 | 164 | Multimedia Telephony Service for IMS (MTSI) - UE Conformance Testing |  | 257d | 2007-09-19 | 2008-09-11 |  | 2007-09-19 | 2008-09-11 | 257d | 336d | finish no earlier than 2008-09-11 | R5 | 624h |  | MTSI-UEConfTest | Ericsson, Motorola | Leif.Mattisson@ericsson.com, Jacob.John@motorola.com | Rel-7 | Ingbert |  |  |  |  |
| 541 | 165 | TISPAN requirements for Multimedia Telephony with PSTN/ISDN simulation services |  | 58d? | 2007-09-18 A | 2007-12-06 A | 100% | 2007-09-18 | 2007-12-06 | 58d? |  | start no earlier than 2007-09-18 | S1 | 464h | 464h | TMMTEL7 |  |  | Rel-7 |  |  |  |  |  |
| 542 | 166 | **Maintenance of TISPAN release 1 common IMS** |  | 58d? | 2007-09-18 A | 2007-12-06 A | 100% | 2007-09-18 | 2007-12-06 | 58d? |  |  | S2 | 1392h | 1392h | MCIMSTR1 | Ericsson | Raymond Forbes | Rel-7 | Alain |  |  |  |  |
| 543 | 166.1 | SA1 aspects of MCIMSTR1 |  | 58d? | 2007-09-18 A | 2007-12-06 A | 100% | 2007-09-18 | 2007-12-06 | 58d? |  | finish no earlier than 2007-12-06 | S1 | 464h | 464h | MCIMSTR1-S1 | Telecom Italia | Marco De Luca | Rel-7 |  |  |  |  |  |
| 544 | 166.2 | SA2 aspects of MCIMSTR1 |  | 58d? | 2007-09-18 A | 2007-12-06 A | 100% | 2007-09-18 | 2007-12-06 | 58d? |  | finish no earlier than 2007-12-06 | S2 | 464h | 464h | MCIMSTR1-S2 | Ericsson | Raymond Forbes | Rel-7 |  |  |  |  |  |
| 545 | 167 | **PS domain and IMS impacts for supporting IMS Emergency calls** |  | 1760d? | 2000-09-18 A | 2007-06-15 A | 100% | 2000-09-18 | 2007-06-15 | 1760d? |  |  | S2,S1 | 44157h | 44157h | EMC1 | Siemens | Rainer Liebhart | Rel-7 | Maurice |  | TSG |  |  |
| 546 | 10.1.1 | Service Requirements for IP-based emergency calls |  | 985d | 2000-09-18 A | 2004-06-25 A | 100% | 2000-09-18 | 2004-06-25 | 985d |  | finish no earlier than 2004-06-25 | S1 | 7880h | 7880h | EMC1 | Siemens | Rainer Liebhart | Rel-7 |  |  |  | CCaR | 1314 |
| 547 | 167.2 | Study on Stage 2 for IMS-level solution |  | 668d? | 2003-02-26 A | 2005-09-16 A | 100% | 2003-02-26 | 2005-09-16 | 668d? |  | finish no earlier than 2005-09-16 | S2 | 5344h | 5344h | EMC1 | Siemens | Rainer Liebhart | Rel-7 |  |  | TSG |  |  |
| 548 | 167.3 | Study on Stage 2 for GPRS-level solution |  | 301d? | 2004-10-14 A | 2005-12-08 A | 100% | 2004-10-14 | 2005-12-08 | 301d? |  | finish no earlier than 2005-12-08 | S2 | 2408h | 2408h | EMC1 | Siemens | Rainer Liebhart | Rel-7 |  |  |  |  |  |
| 549 | 167.4 | Stage 2 Specification Phase - IMS-level |  | 200d? | 2005-09-05 A | 2006-06-09 A | 100% | 2005-09-05 | 2006-06-09 | 200d? |  | finish no earlier than 2006-06-09 | S2 | 1600h | 1600h | EMC1 | Siemens | Rainer Liebhart | Rel-7 |  |  |  |  |  |
| 550 | 167.5 | Deleted - Stage 2 Specification Phase - GPRS-level | milestone | 0d? | 2007-03-02 A | 2007-03-02 A | 100% | 2007-03-02 | 2007-03-02 | 0d? |  | start no earlier than 2007-03-02 | S2 |  |  | EMC1 | Siemens | Rainer Liebhart | Rel-7 |  | SP-32 |  |  |  |

Notes:
- 526: WID approved SA#28. WID updated SA#32
- 527: Text3: 23.816
- 528: Text3: 22.228, 23.228, 23.203
- 529: CP#32 approved WID / Text3: 23.218, 24.229
- 530: Text3: 32.260, 32.298, 32.299
- 531: SP#29 approved WID
- 532: Abandoned
- 533: SP#29 approved WID / Text3: 22.228, 23.228, 23.218, 24.229
- 534: CP#32 approved WID / Text3: 24.229
- 536: Text3: 22.173
- 537: Text3: 24.173
- 538: Text3: 26.114
- 539: Text3: 22.173
- 540: UID_350047->350147. 05/08: Linked to Feature UID_7038 (MTSI). Status Report in RP-080284 / Text3: 34.123-1/2/3
- 541: Text3: 22.273 (ETSI TS 181 002 maintenance)
- 542: Text3: http://www.3gpp.org/specs/TISPAN-IMS-transfer.htm
- 543: Text3: 22.173
- 544: Text3: 23.406, 23.417, 23.508,23.509, 23.511
- 546: Text3: 22.976 (DB shows 04/2003 withdrawn Study on PS domain services and capabilities (az: belongs this TR really here ?!)
- 547: Text3: 23.867
- 548: Text3: 23.867
- 549: Text3: 23.167, 23.228, 23.060, 23.002, 23.271

| ID | WBS | Task | Type | Duration | Start | Finish | Complete | Baseline start | Baseline finish | Baseline duration | Constraint | Resources | Work | Actual work | Text1 | Text2 | Text4 | Text5 | Text6 | Text9 | Text3 | Text8 | Text12 | Text7 | Text10 |
| --- | --- | --- | --- | --- | --- | --- | --- | --- | --- | --- | --- | --- | --- | --- | --- | --- | --- | --- | --- | --- | --- | --- | --- | --- | --- |
| 551 | 10.1 | **Emergency Call Enhancements for IP& PS Based Calls – stage 3** |  | 375d | 2006-01-09 A | 2007-06-15 A | 100% | 2006-01-09 | 2007-06-15 | 375d |  | C1 | 12845h | 12845h | EMC1 | CCaR | Ericsson | alf.heidermark@ericsson.com | Rel-7 | 1653 |  |  |  |  |  |
| 552 | 10.1.2 | CT1 IMS aspects to support IMS Emergency sessions |  | 350.82d | 2006-01-09 A | 2007-06-15 A | 100% | 2006-01-09 | 2007-06-15 | 350.82d | finish no earlier than 2007-06-15 | C1 | 2806.57h | 2806.57h | EMC1 | CCaR | Ericsson | alf.heidermark@ericsson.com | Rel-7 | 1315 | 24.229 |  |  |  |  |
| 553 | 10.1.2 | Deleted - CT3 IMS aspects to support IMS Emergency sessions |  | 95d | 2006-05-08 A | 2006-09-15 A | 100% | 2006-05-08 | 2006-09-15 | 95d | finish no earlier than 2006-09-15 | C3 | 760h | 760h | EMC1 | CCaR | Ericsson | alf.heidermark@ericsson.com | Rel-7 | 1315 | 29.163 | Seung Don | CP-33 |  |  |
| 554 | 10.1.5 | Deleted - CT3 PS domain aspects to support IMS Emergency sessions |  | 95d | 2006-05-08 A | 2006-09-15 A | 100% | 2006-05-08 | 2006-09-15 | 95d | start no earlier than 2006-05-08 | C3 | 760h | 760h | EMC1 | CCaR | Ericsson | alf.heidermark@ericsson.com | Rel-7 | 1646 | 29.061 | Seung Don | CP-33 |  |  |
| 555 | 10.1.5 | CT1 PS domain aspects to support IMS Emergency sessions |  | 349.9d | 2006-01-09 A | 2007-06-15 A | 100% | 2006-01-09 | 2007-06-15 | 349.9d | finish no earlier than 2007-06-15 | C1 | 2799.2h | 2799.2h | EMC1 | CCaR | Ericsson | alf.heidermark@ericsson.com | Rel-7 | 1646 | 24.008, 24.234 |  |  |  |  |
| 556 | 10.1.5 | CT4 PS domain aspects to support IMS Emergency sessions |  | 365d | 2006-01-09 A | 2007-06-01 A | 100% | 2006-01-09 | 2007-06-01 | 365d | finish no earlier than 2007-06-01 | C4 | 2920h | 2920h | EMC1-GPRSc4 | CCaR | Ericsson | alf.heidermark@ericsson.com | Rel-7 | 1646 | 29.060 |  |  |  |  |
| 557 | 168 | IMS Support of Conferencing |  | 355d? | 2005-11-04 A | 2007-03-15 A | 100% | 2005-11-04 | 2007-03-15 | 355d? | finish no earlier than 2007-03-15 | C1 | 2840h | 2840h | IMSconf |  | Alcatel-Lucent | drage@alcatel-lucent.com | Rel-7 |  | 24.147, 24.229 | Frederic |  |  |  |
| 558 | 169 | Performance Characterization of VoIMS over HSDPA\EUL channels |  | 713d? | 2005-03-15 A | 2007-12-06 A | 100% | 2005-03-15 | 2007-12-06 | 713d? | finish no earlier than 2007-12-06 | S4 | 5704h | 5704h | VoIMS-PCVoIMS |  | Alcatel-Lucent | mcgowan@alcatel-lucent.com | Rel-7 |  | 26.935 | Paolo |  | TSG |  |
| 559 | 170 | **WLAN-UMTS Interworking Phase 2** |  | 371d? | 2004-01-05 A | 2005-06-07 A | 100% | 2004-01-05 | 2005-06-07 | 371d? |  | S1 | 3888h | 3888h | WLAN2 |  | Telenor | frederic.paint@telenor.com | Rel-7 |  | 33.234 (SP-36 SA3 CRs approved) | Michael |  | TSG |  |
| 560 | 170.1 | Stage 1 on Session Continuity |  | 115d? | 2004-01-05 A | 2004-06-11 A | 100% | 2004-01-05 | 2004-06-11 | 115d? | start no earlier than 2004-01-05 | S1 | 920h | 920h | WLAN-SC |  |  |  | Rel-7 |  | 22.234 |  |  |  | SP-24 |
| 561 | 170.2 | Stage 2 on Session Continuity: covered by SAE | milestone | 0d? | 2005-06-07 A | 2005-06-07 A | 100% | 2005-06-07 | 2005-06-07 | 0d? | finish no earlier than 2005-06-07 | S2 |  |  | WLAN-SC |  |  |  | Rel-7 |  |  |  |  |  |  |
| 562 | 171 | **WLAN Interworking – Private Network access from WLAN 3GPP IP Access** |  | 252d? | 2005-10-10 A | 2006-09-26 A | 100% | 2005-10-10 | 2006-09-26 | 252d? |  | S2,C1,C3,C4 | 8936h | 8936h | WLANPNA |  | NEC | Toshiyuki Tamura (tamurato@aj.jp.nec.com) | Rel-7 |  |  | Maurice |  |  |  |
| 563 | 171.1 | WLAN-PNA - Stage 2 |  | 185d? | 2005-10-10 A | 2006-06-23 A | 100% | 2005-10-10 | 2006-06-23 | 185d? | start no earlier than 2005-10-10 | S2 | 1480h | 1480h | WLANPNA-st2 |  | NEC | Toshiyuki Tamura (tamurato@aj.jp.nec.com) | Rel-7 |  | 23.234, 33.234 | Maurice |  |  |  |
| 564 | 171.2 | **WLAN-PNA - Stage 3** |  | 170d? | 2006-02-01 A | 2006-09-26 A | 100% | 2006-02-01 | 2006-09-26 | 170d? |  | C1,C3,C4 | 5440h | 5440h | WLANPNA-st3 |  | NEC | pierre-jean.muller@nectech.fr | Rel-7 |  |  | Frederic |  | TSG |  |
| 565 | 171.2.1 | CT1 aspets for WLAN-PNA |  | 170d? | 2006-02-01 A | 2006-09-26 A | 100% | 2006-02-01 | 2006-09-26 | 170d? | start no earlier than 2006-02-01 | C1 | 1360h | 1360h | WLANPNA-st3 |  | NEC | pierre-jean.muller@nectech.fr | Rel-7 |  | 24.234 | Frederic |  |  |  |
| 566 | 171.2.2 | CT3 aspets for WLAN-PNA |  | 170d? | 2006-02-01 A | 2006-09-26 A | 100% | 2006-02-01 | 2006-09-26 | 170d? | start no earlier than 2006-02-01 | C3 | 1360h | 1360h | WLANPNA-st3 |  | NEC | pierre-jean.muller@nectech.fr | Rel-7 |  | 29.161 | Frederic |  |  |  |
| 567 | 171.2.3 | Deleted - CT4 aspets for WLAN-PNA |  | 170d? | 2006-02-01 A | 2006-09-26 A | 100% | 2006-02-01 | 2006-09-26 | 170d? | start no earlier than 2006-02-01 | C4 | 1360h | 1360h | WLANPNA-st3 |  | NEC | pierre-jean.muller@nectech.fr | Rel-7 |  | 29.234 | Frederic | CP-32 |  |  |
| 568 | 172 | **Enhancements to support QoS provisioning over 3GPP/WLAN Interworking** |  | 520d? | 2005-03-14 A | 2007-03-09 A | 100% | 2005-03-14 | 2007-03-09 | 520d? |  | S2,C4,C1 | 8360h | 8360h | WLANQOS |  | Samsung | osok.song@samsung.com | Rel-7 |  |  | Maurice |  |  |  |
| 569 | 172.1 | Deleted - TR on support of QoS on WLAN |  | 232d? | 2005-03-14 A | 2006-01-31 A | 100% | 2005-03-14 | 2006-01-31 | 232d? | start no earlier than 2005-03-14 | S2 | 1856h | 1856h | WLANQOS |  | Samsung | osok.song@samsung.com | Rel-7 |  | 23.836 | Maurice | SP-32 |  |  |
| 570 | 172.2 | Stage 2 on support of QoS over 3GPP/WLAN interworking |  | 108d? | 2006-02-01 A | 2006-06-30 A | 100% | 2006-02-01 | 2006-06-30 | 108d? | start no earlier than 2006-02-01 | S2 | 864h | 864h | WLANQOS |  | Samsung | osok.song@samsung.com | Rel-7 |  | 23.234 | Maurice |  |  |  |
| 571 | 172.3 | Stage 3 CT4 on support of QoS over 3GPP/WLAN Interworking |  | 121d? | 2006-09-22 A | 2007-03-09 A | 100% | 2006-09-22 | 2007-03-09 | 121d? | finish no earlier than 2007-03-09 | C4 | 968h | 968h | WLANQOS |  | Huawei | zhang.peng@huawei.com | Rel-7 |  | 29.234, 23.008 | Kimmo |  |  |  |
| 572 | 172.4 | Stage 3 CT1 on support of QoS over 3GPP/WLAN Interworking |  | 64d? | 2006-09-04 A | 2006-11-30 A | 100% | 2006-09-04 | 2006-11-30 | 64d? | finish no earlier than 2006-11-30 | C1 | 512h | 512h | WLANQOS |  | Huawei | zhang.peng@huawei.com | Rel-7 |  | 24.234 | Frederic |  |  |  |
| 573 | 173 | **Location Services enhancements** |  | 906d? | 2004-06-28 A | 2007-12-17 A | 100% | 2004-06-28 | 2007-12-17 | 906d? |  | S1,S2,GP,C4,R2 | 46933.6h | 46933.6h | LCS3 |  |  |  | Rel-7 |  |  | Alain |  |  |  |
| 574 | 173.1 | Stage 2 for LCS3 (including IMS emergency location aspects) |  | 446d? | 2004-12-31 A | 2006-09-15 A | 100% | 2004-12-31 | 2006-09-15 | 446d? | finish no earlier than 2006-09-15 | S2 | 3568h | 3568h | LCS3 |  | SiRF | brodilitz@sirf.com | Rel-7 |  | 23.271 | Maurice |  | TSG |  |
| 575 | 173.2 | LCS Enhancements related to Location-Based Services |  | 695d? | 2005-01-03 A | 2007-08-31 A | 100% | 2005-01-03 | 2007-08-31 | 695d? | finish no earlier than 2007-08-31 | GP | 5560h | 5560h | LCS3-LBS |  | SiRF | kjudge@sirf.com | Rel-7 |  | 43.059, 44.031, 48.008, 49.031 | Paolo |  | TSG |  |
| 576 | 173.3 | CT4 aspects for LCS UEPos-LBS |  | 240d? | 2006-01-02 A | 2006-12-01 A | 100% | 2006-01-02 | 2006-12-01 | 240d? | finish no earlier than 2006-12-01 | C4 | 1920h | 1920h | LCS3-UEPos-LBS |  | SiRF | brodilitz@sirf.com | Rel-7 |  | 24.030, 24.080, 29.002 | Kimmo |  | TSG |  |
| 577 | 173.4 | UE positioning - Velocity |  | 394d? | 2005-03-15 A | 2006-09-15 A | 100% | 2005-03-15 | 2006-09-15 | 394d? | finish no earlier than 2006-09-15 | R2 | 3152h | 3152h | LCS3-UEPos-Velocity |  | SiRF | BRodilitz@SiRF.com | Rel-7 |  | 25.305, 25.331, 25.410, 25.413, 25.453 | Joern |  | TSG |  |
| 578 | 173.5 | Inclusion of Uplink TDOA UE positioning method in the UTRAN specifications |  | 849d? | 2004-09-15 A | 2007-12-17 A | 100% | 2004-09-15 | 2007-12-17 | 849d? | finish no earlier than 2007-12-17 | R2 | 6792h | 6792h | LCS3-UEPos-UTDOA |  | TruePosition | rlgross@trueposition.com | Rel-7 |  | 25.305, 25.453 | Joern |  | TSG |  |

Notes:
- 553: Cancelled for Rel-7 and there is now corresponding Rel-8 WI
- 554: Cancelled for Rel-7 and there is now corresponding Rel-8 WI
- 557: CP#35 revised WID
- 559: Created at TSG#27 by A. Sultan because of WLAN items belonging to Rel-7. az: This WI is an extension of the WLAN-UMTS Interworking Rel-6 (No new WID)
- 563: Approved at SP#29
- 564: Approved at CP#29
- 565: Approved at CP#29
- 566: Approved at CP#29
- 567: CT4#31; no impacts identified, therefore completed. CP-32 stopped
- 568: Moved from FS section Feb 06. SP-30 updated WID
- 569: SP-32 stopped
- 570: SP-30 updated WID
- 571: CP-32 approved WID
- 572: CP-32 approved WID
- 574: SP#27 approved WID.
- 577: Completed Sept 2006; Status Report in RP-060459
- 578: Completed Nov 2007; Status Report in RP-070797

| ID | WBS | Task | Type | Duration | Start | Finish | Complete | Baseline start | Baseline finish | Baseline duration | Constraint | Resources | Work | Actual work | Text1 | Text4 | Text5 | Text6 | Text7 | Text8 | Text12 |
| --- | --- | --- | --- | --- | --- | --- | --- | --- | --- | --- | --- | --- | --- | --- | --- | --- | --- | --- | --- | --- | --- |
| 579 | 173.6 | **LCS for 3GPP Interworking WLAN** |  | 700d? | 2004-06-28 A | 2007-03-02 A | 100% | 2004-06-28 | 2007-03-02 | 700d? |  | S1 | 11901.6h | 11901.6h | LCS3-IWLAN | Telcordia | Mike Loushine | Rel-7 | TSG | Alain |  |
| 580 | 173.6.1 | FS on 3GPP system to WLAN Interworking with LCS |  | 512.7d? | 2004-06-28 A | 2006-06-30 A | 100% | 2004-06-28 | 2006-06-30 | 512.7d? | finish no earlier than 2005-09-29 | S1 | 4101.6h | 4101.6h | LCS3-IWLAN-FSs1 | Telcordia | Mike Loushine, Vijay Varma | Rel-7 |  | Alain |  |
| 581 | 173.6.2 | Delete - Study of work on an LCS architecture for I-WLAN. |  | 180d? | 2006-06-26 A | 2007-03-02 A | 100% | 2006-06-26 | 2007-03-02 | 180d? | finish no earlier than 2007-03-02 | S2 | 1440h | 1440h | LCS3-IWLAN-FSs2 | LGE | dhshim@lge.com ; phede@lge.com | Rel-7 |  | Maurice | SP-35 |
| 582 | 173.6.3 | Stage 2 for LCS architecture for I-WLAN |  | 95d? | 2006-10-23 A | 2007-03-02 A | 100% | 2006-10-23 | 2007-03-02 | 95d? | finish no earlier than 2007-03-02 | S2 | 760h | 760h | LCS3-IWLAN | LGE | dhshim@lge.com ; phede@lge.com | Rel-7 |  | Maurice |  |
| 583 | 173.7 | Deleted - UE positioning Rel-7 |  | 849d? | 2004-09-15 A | 2007-12-17 A | 100% | 2004-09-15 | 2007-12-17 | 849d? |  | RP | 6792h | 6792h | LCS3-UEpos |  |  | Rel-7 | TSG |  | RP-38 |
| 584 | 173.8 | Deleted - RAN2 aspects for LBS | milestone | 0d? | 2005-06-15 A | 2005-06-15 A | 100% | 2005-06-15 | 2005-06-15 | 0d? | start no earlier than 2005-06-15 | R2 |  |  | LCS3-UEPos-LBS | Ben Rodilitz | BRodilitz@SiRF.com | Rel-7 | TSG | MCC_RAN | RP-31 |
| 585 | 174 | **MBMS Enhancements** |  | 625d? | 2005-07-11 A | 2007-11-30 A | 100% | 2005-07-11 | 2007-11-30 | 625d? |  | S1 | 10844.6h | 10844.6h | MBMSE | China Mobile | liuhongyfw@chinamobile.com | Rel-7 |  | Mike |  |
| 586 | 174.1 | Stage 1 of MBMSE |  | 109d? | 2005-07-11 A | 2005-12-08 A | 100% | 2005-07-11 | 2005-12-08 | 109d? | finish no earlier than 2005-12-08 | S1,R1,C3 | 872h | 872h | MBMSE | China Mobile | liuhongyfw@chinamobile.com | Rel-7 |  | Mike |  |
| 587 | 174.2 | MBMS FDD Physical layer Enhancements |  | 117.29d? | 2006-12-15 A | 2007-06-04 A | 100% | 2006-12-15 | 2007-06-04 | 117.29d? | finish no earlier than 2007-06-04 | R1 | 938.32h | 938.32h | MBMSE-RANPhysFDD | Ericsson | Lars.Lindbom@ericsson.com | Rel-7 |  | Patrick |  |
| 588 | 174.3 | MBMS TDD Physical layer Enhancements |  | 117.29d? | 2006-12-15 A | 2007-06-04 A | 100% | 2006-12-15 | 2007-06-04 | 117.29d? | finish no earlier than 2007-06-04 | R1 | 938.32h | 938.32h | MBMSE-RANPhysTDD | IPWireless | Nicholas Anderson | Rel-7 |  | Patrick |  |
| 589 | 174.4 | MBMS Low Chip Rate TDD Physical Layer Enhancement |  | 127d? | 2007-03-16 A | 2007-09-10 A | 100% | 2007-03-16 | 2007-09-10 | 127d? | finish no earlier than 2007-09-10 | R1 | 1016h | 1016h | MBMSE-RANPhysLCRTDD | RITT | Lin Hui | Rel-7 |  | Patrick |  |
| 590 | 174.5 | MBMS Mz interface |  | 260d? | 2006-12-04 A | 2007-11-30 A | 100% | 2006-12-04 | 2007-11-30 | 260d? | finish no earlier than 2007-05-11 | C3 | 2080h | 2080h | MBMSMz | Huawei | Deng Tingting (ttdeng@huawei.com) | Rel-7 |  | Seung Don |  |
| 591 | 175 | MBMS User Service Extensions |  | 392d? | 2005-12-07 A | 2007-06-07 A | 100% | 2005-12-07 | 2007-06-07 | 392d? | finish no earlier than 2007-06-07 | S4 | 3136h | 3136h | MBMSUSE | Ericsson | Thorsten.Lohmar@ericsson.com | Rel-7 |  | Paolo |  |
| 592 | 176 | **Advanced Global Navigation Satellite System (A-GNSS) concept** |  | 830d? | 2004-06-28 A | 2007-08-31 A | 100% | 2004-06-28 | 2007-08-31 | 830d? |  | S1,GP,R2 | 9553.6h | 9553.6h | LCS3-AGNSS | Alcatel | Michel.monnerat@space.alcatel.fr | Rel-7 | TSG | Michael |  |
| 593 | 176.1 | Towards A-GNSS Concept |  | 811.2d? | 2004-06-28 A | 2007-08-31 A | 100% | 2004-06-28 | 2007-08-31 | 811.2d? | finish no earlier than 2007-08-31 | GP | 6489.6h | 6489.6h | AGNSS-GP | Alcatel | richard.couty@space.alcatel.fr | Rel-7 | TSG | Paolo |  |
| 594 | 176.2 | Global Navigation Satellite System (GNSS) in UTRAN |  | 383d? | 2005-12-15 A | 2007-06-04 A | 100% | 2005-12-15 | 2007-06-04 | 383d? | finish no earlier than 2007-06-04 | R2 | 3064h | 3064h | LCS3-GNSS-UTRAN | France Telecom | alain.abinakhoul@francetelecom.com | Rel-7 |  | MCC_RAN |  |
| 595 | 176.3 | Deleted - Towards A-GNSS Concept | milestone | 0d? | 2007-02-16 A | 2007-02-16 A | 100% | 2007-02-16 | 2007-02-16 | 0d? | start no earlier than 2007-02-16 | S1 |  |  | GNSS | Alcatel | richard.couty@space.alcatel.fr | Rel-7 | TSG | Paolo | SP-34 |
| 596 | 177 | A-GPS Minimum Performance |  | 351d? | 2006-04-28 A | 2007-08-31 A | 100% | 2006-04-28 | 2007-08-31 | 351d? | finish no earlier than 2007-08-31 | GP | 2808h | 2808h | GAGR | Richard Catmur, Spirent Communications | richard.catmur@spirentcom.com | Rel-7 |  | Paolo |  |
| 597 | 178 | **USSD message delivery and transfer to USIM** |  | 376d? | 2004-03-05 A | 2005-08-12 A | 100% | 2004-03-05 | 2005-08-12 | 376d? |  | S1,C6 | 2762.4h | 2762.4h | USSD-USIM |  |  | Rel-7 | TSG | Michael |  |
| 598 | 178.1 | Stage 1 |  | 152d? | 2004-03-18 A | 2004-10-15 A | 100% | 2004-03-18 | 2004-10-15 | 152d? | start no earlier than 2004-03-18 | S1 | 1216h | 1216h | USSD-USIM |  |  | Rel-7 | TSG | Michael |  |
| 599 | 178.2 | Alignment with requirements regarding USSD usage |  | 193.3d? | 2004-03-05 A | 2005-08-12 A | 100% | 2004-03-05 | 2005-08-12 | 193.3d? | finish no earlier than 2005-08-12 | C6 | 1546.4h | 1546.4h | USSD-USIM | Axalto | Christophe Dubois (cdubois@axalto.com) | Rel-7 | TSG | Xavier |  |
| 600 | 179 | **Combinational Services** |  | 296d? | 2005-01-17 A | 2006-03-06 A | 100% | 2005-01-17 | 2006-03-06 | 296d? |  | S1,S2,C1,S4 | 5176h | 5176h | CSICS | TeliaSonera | Robert.Frank@teliasonera.com | Rel-7 | TSG | Michael |  |
| 601 | 179.1 | Stage 1 for CSICS |  | 104d? | 2005-01-17 A | 2005-06-09 A | 100% | 2005-01-17 | 2005-06-09 | 104d? | start no earlier than 2005-01-17 | S1 | 832h | 832h | CSICS | TeliaSonera | Robert.Frank@teliasonera.com | Rel-7 | TSG | Michael |  |
| 602 | 179.2 | Stage 2 for CSICS |  | 130d? | 2005-01-17 A | 2005-07-15 A | 100% | 2005-01-17 | 2005-07-15 | 130d? | start no earlier than 2005-01-17 | S2 | 1040h | 1040h | CSICS | TeliaSonera | Robert.Frank@teliasonera.com | Rel-7 |  | Maurice |  |
| 603 | 179.3 | Stage 3 for CSICS CN aspects |  | 221d? | 2005-05-02 A | 2006-03-06 A | 100% | 2005-05-02 | 2006-03-06 | 221d? | finish no earlier than 2006-03-06 | C1 | 1768h | 1768h | CSICS | Vodafone | Peter Dawes | Rel-7 | TSG | Frederic |  |
| 604 | 179.4 | Stage 3 for codec aspects |  | 192d? | 2005-03-15 A | 2005-12-07 A | 100% | 2005-03-15 | 2005-12-07 | 192d? | finish no earlier than 2005-12-07 | S4 | 1536h | 1536h | CSICS-Codec | Ericsson | Per.Frojdh@ericsson.com | Rel-7 | TSG | Paolo |  |

Notes:
- 579: Text3: 22.935
- 580: Text3: 22.935
- 581: Updated WID at SA#32 to change "stage 2" to "study" , duplicated UID 320017 deleted. SP#33 TR for Information. Exception Granted for Rel-7 until 03/07. Last mention SP-35 Mar 2007 (abandoned ?) / Text3: 23.837
- 582: WID at SA#55 / Text3: 23.234, 23.271, 23.167
- 584: Text3: 25.305, 25.331, 25.410, 25.413, 25.453
- 586: Structure created by MCC to include RAN aspects under SA1 Feature / Text3: 22.146, 22.246, 22.228
- 587: Completed May 2007; Status Report in RP-070290 / Text3: 25.211, 25.212, 25.213, 25.101, 25.104, 25.331, 25.433, 25.346, 25.306
- 588: Completed May 2007; Status Report in RP-070291 / Text3: 25.346, 25.221, 25.222, 25.223, 25.224, 25.306, 25.331, 25.402, 25.433, 25.102, 25.105, 25.123
- 589: Completed May 2007; Status Report in RP-070292 / Text3: 25.346, 25.221, 25.222, 25.223, 25.224, 25.306, 25.331, 25.402, 25.433, 25.102, 25.105, 25.123
- 590: Text3: 29.061
- 591: Text3: 26.346, 26.946
- 593: GP#36 completed
- 594: Completed Sept 2006; Status Report in RP-070482 / Text3: 25.305, 25.331, 25.306, 25.413, 25.423, 25.433, 25.453, 25.302, 25.215, 25.401, 25.402, 25.450, 25.452
- 596: Text3: 45.005, 51.010
- 597: Text3: 22.090
- 598: Text3: 22.090
- 601: Text3: 22.279
- 602: Text3: 23.279
- 603: Text3: 24.879, 24.279, 24.229, 24.008
- 604: Text3: 26.141, 26.235

| ID | WBS | Task | Type | Duration | Start | Finish | Complete | Baseline start | Baseline finish | Baseline duration | Constraint | Resources | Work | Actual work | Text1 | Text4 | Text5 | Text6 | Text7 | Text8 | Text3 | Text12 |
| --- | --- | --- | --- | --- | --- | --- | --- | --- | --- | --- | --- | --- | --- | --- | --- | --- | --- | --- | --- | --- | --- | --- |
| 605 | 180 | **CAMEL Trunk Triggers** |  | 251d? | 2004-12-17 A | 2005-12-05 A | 100% | 2004-12-17 | 2005-12-05 | 251d? |  | S1,C4 | 6024h | 6024h | TTCAMEL | Nortel | Amar Deol (deola@nortelnetworks.com) | Rel-7 | TSG | Michael |  |  |
| 606 | 180.1 | Stage 1 for CAMEL Trunk Triggers |  | 251d? | 2004-12-17 A | 2005-12-05 A | 100% | 2004-12-17 | 2005-12-05 | 251d? |  | S1 | 2008h | 2008h | TTCAMEL | Nortel | Amar Deol (deola@nortelnetworks.com) | Rel-7 | TSG | Michael | 22.078 |  |
| 607 | 180.2 | CAMEL Trunk Originated Trigger Detection Points |  | 251d? | 2004-12-17 A | 2005-12-05 A | 100% | 2004-12-17 | 2005-12-05 | 251d? | start no earlier than 2004-12-17 | C4 | 2008h | 2008h | CamelR7 | Nortel | David Hutton (dhutton@nortel.com) | Rel-7 | TSG | Kimmo |  |  |
| 608 | 181 | **IMS Service Brokering enhancements** |  | 69d? | 2005-12-07 A | 2006-03-13 A | 100% | 2005-12-07 | 2006-03-13 | 69d? |  | S1 | 1104h | 1104h | ISB | Telcordia | jbakker@telcordia.com | Rel-7 |  | Alain | 22.228 |  |
| 609 | 181.1 | Stage 1 for ISB |  | 69d? | 2005-12-07 A | 2006-03-13 A | 100% | 2005-12-07 | 2006-03-13 | 69d? | finish no earlier than 2006-03-13 | S1 | 552h | 552h | ISB-s1 | Telcordia | jbakker@telcordia.com | Rel-7 |  | Alain | 22.228 |  |
| 610 | 182 | **Enhancements of VGCS for public authority officials** |  | 731d? | 2004-08-27 A | 2007-06-15 A | 100% | 2004-08-27 | 2007-06-15 | 731d? |  | S1 | 25920h | 25920h | EVGCS | Siemens |  | Rel-7 | TSG | Frederic | 43.068, 44.068, 24.008, 29.002 |  |
| 611 | 182.1 | Stage 1 | milestone | 0d? | 2004-08-27 A | 2004-08-27 A | 100% | 2004-08-27 | 2004-08-27 | 0d? | finish no earlier than 2004-08-27 | S1 |  |  | EVGCS | Siemens | joerg.swetina@SIEMENS.COM | Rel-7 | TSG | Michael | 42.068, 43.068 |  |
| 612 | 182.2 | **Architecture and protocol aspects** |  | 731d? | 2004-08-27 A | 2007-06-15 A | 100% | 2004-08-27 | 2007-06-15 | 731d? |  | C1 | 14904h | 14904h | EVGCS | Robert Zaus (Siemens) |  | Rel-7 |  |  | 43.068, 44.068 |  |
| 613 | 182.2.1 | CT1 aspects of EVGCS |  | 731d? | 2004-08-27 A | 2007-06-15 A | 100% | 2004-08-27 | 2007-06-15 | 731d? | finish no earlier than 2006-09-15 | C1 | 5848h | 5848h | EVGCS | Siemens |  | Rel-7 |  |  | 43.068, 44.068, 24.008 |  |
| 614 | 182.2.2 | CT4 aspects of EVGCS |  | 401d? | 2004-08-27 A | 2006-03-10 A | 100% | 2004-08-27 | 2006-03-10 | 401d? | finish no earlier than 2006-03-10 | C4 | 3208h | 3208h | EVGCS-St23-c4 | Siemens |  | Rel-7 |  |  | 29.002 |  |
| 615 | 182.3 | GERAN2 aspects |  | 646d? | 2004-08-27 A | 2007-02-16 A | 100% | 2004-08-27 | 2007-02-16 | 646d? | finish no earlier than 2007-02-16 | G2 | 5168h | 5168h | EVGCS | Ken Isaacs (Siemens) | kenneth.isaacs@roke.co.uk | Rel-7 | TSG | Gert |  |  |
| 616 | 183 | **Improvements of VGCS for parallel use of services** |  | 523d? | 2005-03-15 A | 2007-03-15 A | 100% | 2005-03-15 | 2007-03-15 | 523d? |  | S1 | 12230.2h | 12230.2h | IVGCS |  |  | Rel-7 |  |  |  |  |
| 617 | 183.1 | Service Requirements for VGCS improvements |  | 62d? | 2005-03-15 A | 2005-06-08 A | 100% | 2005-03-15 | 2005-06-08 | 62d? | finish no earlier than 2005-06-08 | S1 | 496h | 496h | IVGCS | T-Mobile | kurt.bischinger@t-mobile.at | Rel-7 | TSG | Michael | 42.068 |  |
| 618 | 183.2 | Stage 2 modifications for VGCS improvements |  | 335d? | 2005-12-01 A | 2007-03-14 A | 100% | 2005-12-01 | 2007-03-14 | 335d? | start no earlier than 2005-12-01 | C1 | 2680h | 2680h | IVGCS | Kurt Bischinger (T-Mobile) | kurt.bischinger@t-mobile.at | Rel-7 | TSG |  | 43.068 |  |
| 619 | 183.3 | **Protocol aspects** |  | 336d? | 2005-12-01 A | 2007-03-15 A | 100% | 2005-12-01 | 2007-03-15 | 336d? |  | C1 | 5376h | 5376h | IVGCS | Dieter Jacobsohn (T-Mobile) |  | Rel-7 |  |  | 44.068 |  |
| 620 | 183.3.1 | CT1 aspects of IVGCS |  | 336d? | 2005-12-01 A | 2007-03-15 A | 100% | 2005-12-01 | 2007-03-15 | 336d? | finish no earlier than 2007-03-15 | C1 | 2688h | 2688h | IVGCS | T-Mobile |  | Rel-7 |  |  | 43.068, 44.068 |  |
| 621 | 183.3.2 | Deleted - CT4 aspects of IVGCS | milestone | 0d? | 2007-03-09 A | 2007-03-09 A | 100% | 2007-03-09 | 2007-03-09 | 0d? | finish no earlier than 2007-03-09 | C4 |  |  | IVGCS-St3-c4 | T-mobile |  | Rel-7 |  |  | 29.002 | CP-35 |
| 622 | 184 | **OSA Rel-7** |  | 584d? | 2005-03-15 A | 2007-06-08 A | 100% | 2005-03-15 | 2007-06-08 | 584d? |  | S1,C5 | 17920h | 17920h | OSA7 | AePONA | eamonn.murray@aepona.com | Rel-7 | TSG | Michael |  |  |
| 623 | 184.1 | Service Requirements for OSA Service Broker |  | 62d? | 2005-03-15 A | 2005-06-08 A | 100% | 2005-03-15 | 2005-06-08 | 62d? | finish no earlier than 2005-06-08 | S1 | 496h | 496h | OSA7-SB | AePONA | eamonn.murray@aepona.com | Rel-7 | TSG | Michael | 22.127 |  |
| 624 | 184.2 | Stage 2 OSA API Service Brokering |  | 156d? | 2006-04-28 A | 2006-12-01 A | 100% | 2006-04-28 | 2006-12-01 | 156d? |  | C5 | 1248h | 1248h | OSA7-SB | AePONA | damian.oneill@aepona.com | Rel-7 | TSG | Adrian | 23.198 |  |
| 625 | 184.3 | Stage 3 OSA API Service Brokering |  | 156d? | 2006-04-28 A | 2006-12-01 A | 100% | 2006-04-28 | 2006-12-01 | 156d? | finish no earlier than 2006-12-01 | C5 | 1248h | 1248h | OSA7-SB | AePONA | damian.oneill@aepona.com | Rel-7 |  |  | 29.198-16 |  |
| 626 | 184.4 | **OSA Stage 2/3 enhancements** |  | 291d? | 2006-04-28 A | 2007-06-08 A | 100% | 2006-04-28 | 2007-06-08 | 291d? |  | C5 | 10256h | 10256h | OSA7 | AePONA | damian.oneill@aepona.com | Rel-7 |  | Adrian | 29.198/9, 23.198 |  |
| 627 | 184.4.1 | Parlay X Message Broadcast Web Service |  | 156d? | 2006-04-28 A | 2006-12-01 A | 100% | 2006-04-28 | 2006-12-01 | 156d? | finish no earlier than 2006-12-01 | C5 | 1248h | 1248h | OSA7 | ETRI |  | Rel-7 |  |  | 29.199-15, 23.198 |  |
| 628 | 184.4.2 | Parlay X Geocoding Web Service |  | 156d? | 2006-04-28 A | 2006-12-01 A | 100% | 2006-04-28 | 2006-12-01 | 156d? | finish no earlier than 2006-12-01 | C5 | 1248h | 1248h | OSA7 | ETRI |  | Rel-7 |  |  | 29.199-16, 23.198 |  |
| 629 | 184.4.3 | Parlay X Application driven QoS Web Service |  | 226d? | 2006-04-28 A | 2007-03-09 A | 100% | 2006-04-28 | 2007-03-09 | 226d? | finish no earlier than 2007-03-09 | C5 | 1808h | 1808h | OSA7 | BT |  | Rel-7 |  |  | 29.199-17, 23.198 |  |
| 630 | 184.4.4 | Parlay-X Device Capabilities and Configuration |  | 162d? | 2006-10-26 A | 2007-06-08 A | 100% | 2006-10-26 | 2007-06-08 | 162d? | finish no earlier than 2007-06-09 | C5 | 1296h | 1296h | OSA7 | Telenor |  | Rel-7 |  |  | 29.199-18, 23.198 |  |
| 631 | 184.4.5 | Parlay-X Multimedia Streaming Session Management Web Service |  | 97d? | 2006-10-26 A | 2007-03-09 A | 100% | 2006-10-26 | 2007-03-09 | 97d? | start no earlier than 2006-10-26 | C5 | 776h | 776h | OSA7 | Telenor |  | Rel-7 |  |  | 29.199-19, 23.198 |  |
| 632 | 184.4.6 | Parlay-X Multimedia Multicast Control Web Service |  | 97d? | 2006-10-26 A | 2007-03-09 A | 100% | 2006-10-26 | 2007-03-09 | 97d? | start no earlier than 2006-10-26 | C5 | 776h | 776h | OSA7 | ETRI |  | Rel-7 |  |  | 29.199-20, 23.198 |  |
| 633 | 184.4.7 | OSA API Conference Call Control SCF |  | 97d? | 2006-10-26 A | 2007-03-09 A | 100% | 2006-10-26 | 2007-03-09 | 97d? | start no earlier than 2006-10-26 | C5 | 776h | 776h | OSA7 | Ericsson |  | Rel-7 |  |  | 29.198-04-5, 23.198 |  |

Notes:
- 608: No CR submitted in rel-8 (according to CR database).
- 609: No Rel-8 changes
- 617: "completeed" as from Chris S' e-mail
- 618: Updated by CT1 chair
- 619: Previous name (before CT32) was Architecture and protocol aspects
- 620: end date updated by CT1-chairman after CT#33
- 621: CT4#33 stage 2 solution is still open. ...
- 623: az: WID URL corrected
- 626: CT#34: WID updated. Completion 12/06 =>03/07

| ID | WBS | Task | Type | Duration | Start | Finish | Complete | Remaining | Baseline start | Baseline finish | Baseline duration | Total slack | Constraint | Resources | Work | Actual work | Text1 | Text4 | Text5 | Text6 | Text7 | Text8 | Text3 | Text12 |
| --- | --- | --- | --- | --- | --- | --- | --- | --- | --- | --- | --- | --- | --- | --- | --- | --- | --- | --- | --- | --- | --- | --- | --- | --- |
| 634 | 185 | **Selective Disabling of UE Capabilities** |  | 624.36d? | 2005-01-24 A | 2007-06-15 A | 100% |  | 2005-01-24 | 2007-06-15 | 624.36d? |  |  | S1,S2,C1 | 12351.7h | 12351.7h | SDoUE | Motorola | Nigel.Barnes@motorola.com | Rel-7 | TSG | Michael |  |  |
| 635 | 185.1 | Stage 1 of SDoUE |  | 393.6d? | 2005-01-24 A | 2006-12-08 A | 100% |  | 2005-01-24 | 2006-12-08 | 393.6d? |  | finish no earlier than 2006-12-08 | S1 | 3148.8h | 3148.8h | SDoUE-CRs | Motorola | Nigel.Barnes@motorola.com | Rel-7 | TSG | Michael | 22.011 |  |
| 636 | 185.2 | Deleted - TR on different possible architectures |  | 195d? | 2005-03-21 A | 2005-12-16 A | 100% |  | 2005-03-21 | 2005-12-16 | 195d? |  | finish no earlier than 2005-12-16 | S2 | 1560h | 1560h | SDoUE-FS | Vodafone | Gavin.Wong@vodafone.com | Rel-7 |  | Maurice | 23.805 abandonned at SP-30; descendant C1 24.305 | SP-30 |
| 637 | 185.3 | Stage 3 of SDoUE |  | 331d? | 2006-03-10 A | 2007-06-15 A | 100% |  | 2006-03-10 | 2007-06-15 | 331d? |  | finish no earlier than 2007-06-15 | C1 | 2648h | 2648h | SDoUE | Ericsson | christian.herrero@ericsson.com | Rel-7 |  | Frederic | 24.305 |  |
| 638 | 186 | **Network selection enhancements (NSP)** |  | 328d? | 2006-03-15 A | 2007-06-15 A | 100% |  | 2006-03-15 | 2007-06-15 | 328d? |  |  | S1 | 6320h | 6320h | NSP-CR | Chris Friel, O2 | chris.friel@o2.com | Rel-7 |  | Michael | 22.101, 22.011, 23.122, 24.008, 25.304, 31.102, 45.008 |  |
| 639 | 186.1 | Stage 1 of NSP |  | 191d? | 2006-03-15 A | 2006-12-06 A | 100% |  | 2006-03-15 | 2006-12-06 | 191d? |  | start no earlier than 2006-03-15 | S1 | 1528h | 1528h | NSP-TS | Chris Friel, O2 | chris.friel@o2.com | Rel-7 |  | Michael | 22.101, 22.011, 23.122, 24.008, 25.304, 31.102, 45.008 |  |
| 640 | 186.2 | Procedural aspects of NSP |  | 271d? | 2006-06-02 A | 2007-06-15 A | 100% |  | 2006-06-02 | 2007-06-15 | 271d? |  | finish no earlier than 2007-06-15 | C1 | 2168h | 2168h | NSP-CR | Andrew Howell (Motorola) | andrew.howell@motorola.com | Rel-7 |  | Frederic | 23.122, 24.008, 31.102 |  |
| 641 | 187 | Network selection enhancements (NSP) - UE Conformance Testing |  | 396d? | 2007-06-01 A | 2008-12-05 | 30% | 277.2d? | 2007-06-01 | 2008-12-05 | 396d? | 275d | finish no earlier than 2008-12-05 | R5 | 3168h | 950.4h | NSP-CR_UEConTest | Nokia | jarkko.hellsten@nokia.com | Rel-7 |  | Ingbert | 34.108, 34.123-1, 34.123-2, 34.123-3 |  |
| 642 | 188 | **Access Class Barring and Overload Protection** |  | 650d? | 2004-03-15 A | 2006-09-08 A | 100% |  | 2004-03-15 | 2006-09-08 | 650d? |  |  | S2,C1 | 3568h | 3568h | ACBOP | Vodafone | Chris Pudney | Rel-7 | TSG | Maurice | 23.898 |  |
| 643 | 188.1 | TR on Stage 2 |  | 274d? | 2004-03-15 A | 2005-03-31 A | 100% |  | 2004-03-15 | 2005-03-31 | 274d? |  | finish no earlier than 2005-03-31 | S2 | 2192h | 2192h | ACBOP | NTT DoCoMo | Jean-Jacques Davidian (davidian@docomo.fr) | Rel-7 | TSG |  | 23.898 |  |
| 644 | 188.2 | Stage 3 CN aspects of ACBOP |  | 172d? | 2005-06-06 A | 2006-01-31 A | 100% |  | 2005-06-06 | 2006-01-31 | 172d? |  | start no earlier than 2005-06-06 | C1 | 1376h | 1376h | ACBOP |  |  | Rel-7 |  |  | 24.008 |  |
| 645 | 188.3 | Deleted - Potential impact on Iu interface Overload functionality | milestone | 0d? | 2004-03-15 A | 2004-03-15 A | 100% |  | 2004-03-15 | 2004-03-15 | 0d? |  | finish no earlier than 2004-03-15 | RP |  |  | ACBOP |  |  | Rel-7 |  |  | 25.413 | RP-25 |
| 646 | 188.4 | Deleted - Extra ACBOP information in RAN | milestone | 0d? | 2004-03-15 A | 2004-03-15 A | 100% |  | 2004-03-15 | 2004-03-15 | 0d? |  | finish no earlier than 2004-03-15 | RP |  |  | ACBOP |  |  | Rel-7 |  |  | 25.331 | RP-25 |
| 647 | 188.5 | Deleted - Extra ACBOP information in GERAN | milestone | 0d? | 2006-09-08 A | 2006-09-08 A | 100% |  | 2006-09-08 | 2006-09-08 | 0d? |  | start no earlier than 2006-09-08 | GP |  |  | ACBOP |  |  | Rel-7 | TSG | Gert | 44.018 | RP-33 |
| 648 | 189 | **System enhancements for fixed broadband access to IMS** |  | 876d? | 2003-11-05 A | 2007-03-15 A | 100% |  | 2003-11-05 | 2007-03-15 | 876d? |  |  | S2,S3,S5,C1,C3,C4 | 36656h | 36656h | FBI |  |  | Rel-7 | TSG | Maurice |  |  |
| 649 | 189.1 | **TISPAN Rel 1 related aspects** |  | 873d? | 2003-11-05 A | 2007-03-09 A | 100% |  | 2003-11-05 | 2007-03-09 | 873d? |  |  | S2 | 31568h | 31568h | FBI-TIS1 |  |  | Rel-7 |  |  |  |  |
| 650 | 189.1.1 | Stage 2 of FBI for TISPAN R1 |  | 365d? | 2004-10-14 A | 2006-03-08 A | 100% |  | 2004-10-14 | 2006-03-08 | 365d? |  | start no earlier than 2004-10-14 | S2 | 2920h | 2920h | FBI-TIS1 |  |  | Rel-7 |  | Maurice |  |  |
| 651 | 189.1.2 | **Protocol impact of FBI for TISPAN R1** |  | 873d? | 2003-11-05 A | 2007-03-09 A | 100% |  | 2003-11-05 | 2007-03-09 | 873d? |  |  | C1 | 20720h | 20720h | FBI-TIS1 | Siemens | Peter Leis | Rel-7 | TSG | Frederic |  |  |
| 652 | 189.1.2.1 | CT1 aspects of FBI for TISPAN R1 |  | 802d? | 2003-11-05 A | 2006-11-30 A | 100% |  | 2003-11-05 | 2006-11-30 | 802d? |  | finish no earlier than 2006-11-30 | C1 | 6416h | 6416h | FBI-TIS1 | Siemens | Peter Leis | Rel-7 | TSG | Andrijana | 24.819, 24.229 |  |
| 653 | 189.1.2.2 | CT3 aspects of FBI for TISPAN R1 |  | 808d? | 2003-11-05 A | 2006-12-08 A | 100% |  | 2003-11-05 | 2006-12-08 | 808d? |  | finish no earlier than 2006-12-08 | C3 | 6464h | 6464h | FBI-TIS1 | Siemens | Peter Leis | Rel-7 | TSG | Andrijana | 29.163, 29.209 |  |
| 654 | 189.1.2.3 | CT4 aspects of FBI for TISPAN R1 |  | 301d? | 2006-01-13 A | 2007-03-09 A | 100% |  | 2006-01-13 | 2007-03-09 | 301d? |  | finish no earlier than 2007-03-09 | C4 | 2408h | 2408h | FBI-TIS1-st3-c4 | Siemens | Peter Leis | Rel-7 | TSG | Andrijana | 29.229 |  |
| 655 | 189.1.3 | Security Enhancements for FBI |  | 118d? | 2005-06-28 A | 2005-12-08 A | 100% |  | 2005-06-28 | 2005-12-08 | 118d? |  | start no earlier than 2005-06-28 | S3 | 944h | 944h | FBI-ISE | Ericsson | Bengt.Sahlin@ericsson.com | Rel-7 |  | Dionisio | 33.203 |  |
| 656 | 189.2 | **PacketCable Related aspects** |  | 291d? | 2006-02-01 A | 2007-03-15 A | 100% |  | 2006-02-01 | 2007-03-15 | 291d? |  |  | S2,S5,C1 | 5088h | 5088h | FBI-PCBL | CableLabs | Bernie McKibben | Rel-7 |  |  |  |  |
| 657 | 189.2.1 | Stage 1,2 of FBI for PacketCable |  | 228d? | 2006-02-01 A | 2006-12-15 A | 100% |  | 2006-02-01 | 2006-12-15 | 228d? |  | finish no earlier than 2006-12-15 | S2 | 1824h | 1824h | FBI-PCBL | CableLabs | Bernie McKibben | Rel-7 |  |  | 22.228, 23.228 |  |
| 658 | 189.2.2 | Protocol impact of FBI for PacketCable |  | 228d? | 2006-05-01 A | 2007-03-15 A | 100% |  | 2006-05-01 | 2007-03-15 | 228d? |  | finish no earlier than 2007-03-15 | C1 | 1824h | 1824h | FBI-PCBL |  |  | Rel-7 |  |  |  |  |
| 659 | 189.2.3 | SA5 Charging aspects of FBI for PacketCable |  | 180d? | 2006-03-31 A | 2006-12-07 A | 100% |  | 2006-03-31 | 2006-12-07 | 180d? |  | finish no earlier than 2006-12-07 | S5 | 1440h | 1440h | FBI-PCBL-CH | CableLabs | Bernie McKibben | Rel-7 |  | Adrian | 32.240, 32.260, 32.298, 32.299 |  |

Notes:
- 634: Moved from FS section Feb 06
- 635: Moved from FS section Feb 06
- 636: Moved from FS section Feb 06. Abandoned at SP-30
- 641: 05/08: Linked to Feature UID_7041 (NSP-CR). Status Report in RP-080286, WID in RP-080135
- 644: NEW - inserted on 2/9/2004
- 652: end date updated by CT1-chairman after CT#33
- 654: CT4#32: a set of CRs on FBI for cable labs
- 655: Duplicated entry ("ACCSEC2", "Access Security Enhancements", SP-040865) deleted by A.Sultan
- 659: 03/2006 SA#31 WID approved

| ID | WBS | Task | Type | Duration | Start | Finish | Complete | Baseline start | Baseline finish | Baseline duration | Constraint | Resources | Work | Actual work | Text1 | Text4 | Text5 | Text6 | Text7 | Text8 | Text3 | Text12 |
| --- | --- | --- | --- | --- | --- | --- | --- | --- | --- | --- | --- | --- | --- | --- | --- | --- | --- | --- | --- | --- | --- | --- |
| 660 | 190 | **Support of SMS over generic 3GPP IP access** |  | 696d? | 2004-10-14 A | 2007-06-15 A | 100% | 2004-10-14 | 2007-06-15 | 696d? |  | S2,C4,C1 | 12408h | 12408h | SMSIP | Huawei | zhangwenlin@huawei.com | Rel-7 | TSG | Maurice |  |  |
| 661 | 190.1 | FS on SMSIP |  | 173d? | 2004-10-14 A | 2005-06-13 A | 100% | 2004-10-14 | 2005-06-13 | 173d? | start no earlier than 2004-10-14 | S2 | 1384h | 1384h | SMSIP | Huawei | zhangwenlin@huawei.com | Rel-7 |  |  | 23.804 |  |
| 662 | 190.2 | Stage 2 for SMSIP |  | 333d? | 2005-06-08 A | 2006-09-15 A | 100% | 2005-06-08 | 2006-09-15 | 333d? | finish no earlier than 2006-09-15 | S2 | 2664h | 2664h | SMSIP | Huawei | zhangwenlin@huawei.com | Rel-7 |  |  | 23.204 |  |
| 663 | 190.3 | **Stage 3 for SMSIP** |  | 527d? | 2005-06-08 A | 2007-06-15 A | 100% | 2005-06-08 | 2007-06-15 | 527d? |  | C4,C1 | 8360h | 8360h | SMSIP-St3 | Nokia | jari.jansson@nokia.com | Rel-7 |  |  |  |  |
| 664 | 190.3.1 | CT1 aspects for SMSIP |  | 527d? | 2005-06-08 A | 2007-06-15 A | 100% | 2005-06-08 | 2007-06-15 | 527d? | finish no earlier than 2007-06-15 | C1 | 4216h | 4216h | SMSIP | Nokia | jari.jansson@nokia.com | Rel-7 |  |  | 23.040, 24.229 |  |
| 665 | 190.3.2 | CT4 aspects for SMSIP |  | 518d? | 2005-06-08 A | 2007-06-01 A | 100% | 2005-06-08 | 2007-06-01 | 518d? | finish no earlier than 2007-06-01 | C4 | 4144h | 4144h | SMSIP-St3-c4 | Nokia | jari.jansson@nokia.com | Rel-7 |  |  | 23.008, 29.002 |  |
| 666 | 191 | **Evolution of Policy Control and Charging** |  | 817d? | 2004-10-14 A | 2007-11-30 A | 100% | 2004-10-14 | 2007-11-30 | 817d? |  | S2,S5,C3,C1 | 30336h | 30336h | PCC | Nokia | balazs.bertenyi@nokia.com | Rel-7 | TSG | Maurice |  |  |
| 667 | 191.1 | Deleted - TR for PCC |  | 315d? | 2004-10-14 A | 2005-12-29 A | 100% | 2004-10-14 | 2005-12-29 | 315d? | finish no earlier than 2005-12-28 | S2 | 2520h | 2520h | PCC | Nokia | balazs.bertenyi@nokia.com | Rel-7 |  |  | 23.803 | SP-33 |
| 668 | 191.2 | Stage 2 for PCC |  | 315d? | 2005-07-04 A | 2006-09-15 A | 100% | 2005-07-04 | 2006-09-15 | 315d? | finish no earlier than 2006-09-15 | S2 | 2520h | 2520h | PCC | Nokia | balazs.bertenyi@nokia.com | Rel-7 |  |  | 23.203 |  |
| 669 | 191.3 | Evolution of policy control and flow based bearer level charging |  | 109d? | 2006-08-01 A | 2006-12-29 A | 100% | 2006-08-01 | 2006-12-29 | 109d? | start no earlier than 2006-08-01 | S2 | 872h | 872h | PCC | Nokia | balazs.bertenyi@nokia.com | Rel-7 |  |  | 23.207, 23.002, 23.228 |  |
| 670 | 191.4 | SA5 Charging aspects of PCC |  | 316d? | 2006-03-31 A | 2007-06-15 A | 100% | 2006-03-31 | 2007-06-15 | 316d? | finish no earlier than 2007-06-15 | S5 | 2528h | 2528h | PCC-CH | Orange | alain.bibas@orange-ft.com | Rel-7 |  | Adrian | 32.250, 32.251, 32.298, 32.299 |  |
| 671 | 191.5 | Gx reference point for Policy and Charging Control |  | 521d? | 2005-12-02 A | 2007-11-30 A | 100% | 2005-12-02 | 2007-11-30 | 521d? | finish no earlier than 2007-09-14 | C3 | 4168h | 4168h | PCC-Gx | Siemens | thomas.belling@siemens.com | Rel-7 |  | Seung Don | 29.212 (not progressed to Rel-7: 29.210, 29.207, 29.208) |  |
| 672 | 191.6 | **Rx reference point for PCC CT3 aspects** |  | 521d? | 2005-12-02 A | 2007-11-30 A | 100% | 2005-12-02 | 2007-11-30 | 521d? |  | C3,C1 | 11192h | 11192h | PCC-Rx | Ericsson | j.javier.pastor@ericsson.com | Rel-7 |  | Seung Don |  |  |
| 673 | 191.6.1 | PCC-Rx CT3 aspects |  | 521d? | 2005-12-02 A | 2007-11-30 A | 100% | 2005-12-02 | 2007-11-30 | 521d? | finish no earlier than 2007-09-14 | C3 | 4168h | 4168h | PCC-Rx-c3 | Ericsson | j.javier.pastor@ericsson.com | Rel-7 |  | Seung Don | 29.213, 29.214 (not progressed to Rel-7: 29.209, 29.211) |  |
| 674 | 191.6.2 | PCC-Rx CT1 aspects |  | 357d? | 2005-12-02 A | 2007-06-15 A | 100% | 2005-12-02 | 2007-06-15 | 357d? | finish no earlier than 2007-06-15 | C1 | 2856h | 2856h | PCC-Rx-Gx-c1 | Ericsson | j.javier.pastor@ericsson.com | Rel-7 |  |  | 24.229 |  |
| 675 | 192 | **Voice call continuity between CS and IMS (incl. I-WLAN)** |  | 641d? | 2004-12-31 A | 2007-06-15 A | 100% | 2004-12-31 | 2007-06-15 | 641d? |  | S2,S1,S5,C1,C4 | 12224h | 12224h | VCC | Alcatel-Lucent | andybennett@Alcatel-Lucent.com | Rel-7 |  | Maurice |  |  |
| 676 | 192.1 | TR for VCC |  | 245d? | 2004-12-31 A | 2005-12-08 A | 100% | 2004-12-31 | 2005-12-08 | 245d? | finish no earlier than 2005-12-08 | S2 | 1960h | 1960h | VCC | Alcatel-Lucent | andybennett@Alcatel-Lucent.com | Rel-7 |  |  | 23.806 |  |
| 677 | 192.2 | Stage 1 for VCC |  | 140d? | 2005-03-17 A | 2005-09-28 A | 100% | 2005-03-17 | 2005-09-28 | 140d? | finish no earlier than 2005-09-28 | S1 | 1120h | 1120h | VCC | Alcatel-Lucent | andybennett@Alcatel-Lucent.com | Rel-7 |  | Mike | 22.101 |  |
| 678 | 192.3 | Stage 2 for VCC |  | 264d? | 2005-09-06 A | 2006-09-08 A | 100% | 2005-09-06 | 2006-09-08 | 264d? | finish no earlier than 2006-09-08 | S2 | 2112h | 2112h | VCC | Alcatel-Lucent | andybennett@Alcatel-Lucent.com | Rel-7 |  |  | 23.206 |  |
| 679 | 192.4 | SA5 Charging aspects of VCC |  | 325d? | 2006-03-17 A | 2007-06-14 A | 100% | 2006-03-17 | 2007-06-14 | 325d? | finish no earlier than 2007-06-14 | S5 | 2600h | 2600h | VCC-CH | Orange | alain.bibas@orange-ft.com | Rel-7 |  | Adrian | 32.250, 32.260 |  |
| 680 | 192.5 | **Stage 3 for VCC** |  | 358d? | 2006-02-01 A | 2007-06-15 A | 100% | 2006-02-01 | 2007-06-15 | 358d? |  | C1,C4 | 4432h | 4432h | VCC | Alcatel-Lucent | drage@alcatel-lucent.com | Rel-7 |  |  |  |  |
| 681 | 192.5.1 | CT1 aspects of VCC |  | 358d? | 2006-02-01 A | 2007-06-15 A | 100% | 2006-02-01 | 2007-06-15 | 358d? | finish no earlier than 2007-06-15 | C1 | 2864h | 2864h | VCC | Alcatel-Lucent | drage@alcatel-lucent.com | Rel-7 |  | Frederic | 24.206, 24.216 |  |
| 682 | 192.5.2 | CT4 aspects of VCC |  | 196d? | 2006-06-09 A | 2007-03-09 A | 100% | 2006-06-09 | 2007-03-09 | 196d? | start no earlier than 2006-06-09 | C4 | 1568h | 1568h | VCC-St3-c4 | Alcatel-Lucent | drage@alcatel-ucent.com | Rel-7 |  | Kimmo | 23.003 |  |
| 683 | 192.5.3 | Deleted - CT3 aspects of VCC | milestone | 0d? | 2006-11-02 A | 2006-11-02 A | 100% | 2006-11-02 | 2006-11-02 | 0d? | finish no earlier than 2006-11-02 | C3 |  |  | VCC | Alcatel-Lucent | drage@lucent.com | Rel-7 |  |  | 29.163 | CP-33 |

Notes:
- 660: SP#33 updated WID (removed MMS)
- 661: SP#33 updated WID
- 662: SP#33 updated WID
- 663: CP#34 updated WID
- 664: CP#34 updated WID
- 665: CP#34 updated WID
- 666: SP-29 approved WID. SP-31 updated WID adding SA5 charging. 23.125 will be discontinued from Rel-7.
- 667: SP-30: S2 has no intention for TR completion
- 668: SP-29 approved WID. SP-31 updated WID. 23.125 will be discontinued from Rel-7.
- 669: SP-29 approved WID. SP-31 updated WID. 23.125 will be discontinued from Rel-7.
- 670: SP-31 updated WID with SA5 charging.
- 672: WID approved at CP#30, Revised at CP#31, Revised at CP#33
- 675: WID approved SA#27; updated SA#28; updated SA#32
- 679: 03/2006 SA#31 WID approved

| ID | WBS | Task | Type | Duration | Start | Finish | Complete | Baseline start | Baseline finish | Baseline duration | Constraint | Resources | Work | Actual work | Text1 | Text4 | Text5 | Text6 | Text8 | Text3 | Text7 | Text12 |
| --- | --- | --- | --- | --- | --- | --- | --- | --- | --- | --- | --- | --- | --- | --- | --- | --- | --- | --- | --- | --- | --- | --- |
| 684 | 193 | **One Tunnel solution for Optimisation of Packet Data Traffic** |  | 418d? | 2006-03-27 A | 2007-10-31 A | 100% | 2006-03-27 | 2007-10-31 | 418d? |  | S2 | 7048h | 7048h | OPTUNEL | Nokia | antti.j.pasanen@nokia.com | Rel-7 | Maurice |  |  |  |
| 685 | 193.1 | Deleted - Study on Stage 2 for One Tunnel solution |  | 125d? | 2006-03-27 A | 2006-09-15 A | 100% | 2006-03-27 | 2006-09-15 | 125d? | finish no earlier than 2005-09-12 | S2 | 1000h | 1000h | OPTUNEL-Study | Nokia | antti.j.pasanen@nokia.com | Rel-7 | Maurice | 23.809 | TSG | SP-34 |
| 686 | 193.2 | One Tunnel Deployment Guideline |  | 268d? | 2006-10-23 A | 2007-10-31 A | 100% | 2006-10-23 | 2007-10-31 | 268d? | finish no earlier than 2007-10-31 | S2 | 2144h | 2144h | OPTUNEL-Guide | Huawei | lan.liu@huawei.com | Rel-7 | Maurice | 23.919 | TSG |  |
| 687 | 193.3 | Stage 2 specification for One Tunnel solution |  | 70d? | 2006-09-11 A | 2006-12-15 A | 100% | 2006-09-11 | 2006-12-15 | 70d? | finish no earlier than 2006-12-15 | S2 | 560h | 560h | OPTUNEL-Stage2 | Nokia | antti.j.pasanen@nokia.com | Rel-7 | Maurice | 23.060 | TSG |  |
| 688 | 194 | **CSI Terminating Session handling** |  | 267d? | 2006-06-08 A | 2007-06-15 A | 100% | 2006-06-08 | 2007-06-15 | 267d? |  | S2,C1 | 4728h | 4728h | CSItermS | Samsung | Osok Song | Rel-7 | Maurice |  |  |  |
| 689 | 194.1 | Stage 2 of CStermS |  | 192d? | 2006-06-08 A | 2007-03-02 A | 100% | 2006-06-08 | 2007-03-02 | 192d? | start no earlier than 2006-06-08 | S2 | 1536h | 1536h | CSItermS | Samsung | Osok Song | Rel-7 | Maurice | 23.279 |  |  |
| 690 | 194.2 | Stage 3 of CStermS |  | 132d? | 2006-12-14 A | 2007-06-15 A | 100% | 2006-12-14 | 2007-06-15 | 132d? | finish no earlier than 2007-06-15 | C1 | 1056h | 1056h | CSItermS | Samsung | chenho.chin@samsung.com | Rel-7 | Frederic | 24.229, 24.279 |  |  |
| 691 | 194.3 | Deleted - duplicated with UID 340015 -Stage 3 CSI Terminating Session handling | milestone | 0d? | 2007-03-09 A | 2007-03-09 A | 100% | 2007-03-09 | 2007-03-09 | 0d? | start no earlier than 2007-03-09 | C1 |  |  | CSItermS | Samsung | chenho.chin@samsung.com | Rel-7 | Frederic | 24.229, 24.179, 24.279 |  | CP-34 |
| 692 | 195 | Liberty Alliance and 3GPP Security Interworking |  | 451d? | 2005-03-10 A | 2006-11-30 A | 100% | 2005-03-10 | 2006-11-30 | 451d? | finish no earlier than 2006-11-30 | S3 | 3608h | 3608h | LibSec | Nokia | Silke.Holtmanns@NOKIA.COM | Rel-7 | Maurice | 33.980 | TSG |  |
| 693 | 196 | Trust Requirements for Open Platforms in 3GPP |  | 499d? | 2005-01-03 A | 2006-11-30 A | 100% | 2005-01-03 | 2006-11-30 | 499d? | finish no earlier than 2006-11-30 | S3 | 3992h | 3992h | TrustOP | Nokia | Silke.Holtmanns@NOKIA.COM | Rel-7 | Michael | 33.905 | TSG |  |
| 694 | 197 | Development of UEA2 and UIA2 |  | 268d? | 2004-12-01 A | 2005-12-09 A | 100% | 2004-12-01 | 2005-12-09 | 268d? | finish no earlier than 2005-12-09 | S3 | 2144h | 2144h | AlgUEA2 | TeliaSonera | per.christoffersson@teliasonera.com | Rel-7 | Michael | 35.919, 35.215, 35.216, 35.217, 35.218 | TSG |  |
| 695 | 198 | Lawful Interception in the 3GPP Rel-7 architecture |  | 118d? | 2005-06-28 A | 2005-12-08 A | 100% | 2005-06-28 | 2005-12-08 | 118d? | start no earlier than 2005-06-28 | S3 | 944h | 944h | LI-7A | BMWI | berthold.wilhelm@regtp.de | Rel-7 | Mike | 33.106, 33.107, 33.108 |  |  |
| 696 | 199 | Key establishment between a UICC and a terminal |  | 201.45d? | 2005-12-07 A | 2006-09-28 A | 100% | 2005-12-07 | 2006-09-28 | 201.45d? | finish no earlier than 2006-09-28 | S3 | 1611.6h | 1611.6h | KeyEstUTerm | Gemalto | mireille.pauliac@gemplus.com | Rel-7 |  | 33.110 |  |  |
| 697 | 200 | NDS Authentication Framework Extension for Transport Layer Security |  | 50d? | 2006-09-28 A | 2006-12-06 A | 100% | 2006-09-28 | 2006-12-06 | 50d? | finish no earlier than 2006-09-28 | S3 | 400h | 400h | NDSAFTLS | Nokia | tiina.s.koskinen@nokia.com | Rel-7 | Michael | 33.310 |  |  |
| 698 | 201 | **Security enhancements** |  | 319d? | 2005-09-12 A | 2006-11-30 A | 100% | 2005-09-12 | 2006-11-30 | 319d? |  | S3,C1,C4 | 4856h | 4856h | SEC7 |  |  | Rel-7 |  |  |  |  |
| 699 | 201.1 | HTTPS connection between a UICC and a NAF |  | 1d? | 2005-09-12 A | 2005-09-12 A | 100% | 2005-09-12 | 2005-09-12 | 1d? | start no earlier than 2005-09-12 | S3,C1 | 8h | 8h | SEC7-HSUN | Gemalto | JSeif@axalto.com, mireille.pauliac@gemplus.com | Rel-7 |  | 33.918, 33.222, 24.109 |  |  |
| 700 | 201.2 | 2G GBA: 2G SIM usage in 3GPP GAA framework |  | 61d? | 2005-09-12 A | 2005-12-05 A | 100% | 2005-09-12 | 2005-12-05 | 61d? | finish no earlier than 2005-12-05 | S3 | 488h | 488h | SEC7-2GGBA | Nokia | Silke.Holtmanns@nokia.com | Rel-7 |  | 33.920, 33.220 |  |  |
| 701 | 201.3 | Generic Authentication Architecture usage extensions and optimisations |  | 319d? | 2005-09-12 A | 2006-11-30 A | 100% | 2005-09-12 | 2006-11-30 | 319d? | finish no earlier than 2006-11-30 | S3 | 2552h | 2552h | SEC7-GAA2 | Nokia | Silke.Holtmanns@nokia.com | Rel-7 |  | 33.220, 29.109, 24.109, (33.223 goes to R8) |  |  |
| 702 | 201.4 | **SS7 TCAP security Gateway** |  | 241d? | 2005-09-12 A | 2006-08-14 A | 100% | 2005-09-12 | 2006-08-14 | 241d? |  | S3,C4 | 1808h | 1808h | SEC7-NDS-TCAPsec | Siemens | marc.blommaert@siemens.com | Rel-7 |  |  |  |  |
| 703 | 201.4.1 | SA3 aspects of SEC7-NDS-TCAPsec |  | 130d? | 2005-09-12 A | 2006-03-10 A | 100% | 2005-09-12 | 2006-03-10 | 130d? | finish no earlier than 2006-03-10 | S3 | 1040h | 1040h | SEC7-NDS-TCAPsec-SA3 | Siemens | marc.blommaert@siemens.com | Rel-7 |  | 33.204 |  |  |
| 704 | 201.4.2 | TCAPsec Gateway |  | 96d? | 2006-04-03 A | 2006-08-14 A | 100% | 2006-04-03 | 2006-08-14 | 96d? | start no earlier than 2006-04-01 | C4 | 768h | 768h | SEC7-TCAP | Siemens | Ulrich.wiehe@gksag.de | Rel-7 | Kimmo | 29.204, 29.002 |  |  |
| 705 | 202 | IMS Stage 3 IETF Protocol alignment |  | 589d? | 2004-12-10 A | 2007-03-15 A | 100% | 2004-12-10 | 2007-03-15 | 589d? | finish no earlier than 2007-03-15 | C1 | 4712h | 4712h | IMSProtoc |  |  | Rel-7 |  | 24.930 |  |  |
| 706 | 203 | **Interoperability between VGCS/VBS and A/Gb flexibility** |  | 253d? | 2006-03-22 A | 2007-03-09 A | 100% | 2006-03-22 | 2007-03-09 | 253d? |  | C1,C4 | 3296h | 3296h | VGCSFlex | Siemens | robert.zaus@siemens.com | Rel-7 | Frederic |  |  |  |
| 707 | 203.1 | CT1 aspects of VGCSFlex |  | 159d? | 2006-03-22 A | 2006-10-30 A | 100% | 2006-03-22 | 2006-10-30 | 159d? | finish no earlier than 2006-10-30 | C1 | 1272h | 1272h | VGCSFlex | Siemens | robert.zaus@siemens.com | Rel-7 |  | 43.068, 43.069 |  |  |
| 708 | 203.2 | CT4 aspects of VGCSFlex |  | 253d? | 2006-03-22 A | 2007-03-09 A | 100% | 2006-03-22 | 2007-03-09 | 253d? | finish no earlier than 2007-03-09 | C4 | 2024h | 2024h | VGCSFlex-c4 | Siemens | robert.zaus@siemens.com | Rel-7 |  | 29.002 |  |  |
| 709 | 204 | DIAMETER on the GGSN Gi interface |  | 586d? | 2004-09-10 A | 2006-12-08 A | 100% | 2004-09-10 | 2006-12-08 | 586d? | finish no earlier than 2006-12-08 | C3 | 4688h | 4688h | DIAMGi | Vodafone | Nico.Gabriele@vodafone.com | Rel-7 | Seung Don | 29.061 | TSG |  |
| 710 | 205 | DIAMETER on the PDG Wi interface |  | 586d? | 2004-09-10 A | 2006-12-08 A | 100% | 2004-09-10 | 2006-12-08 | 586d? | finish no earlier than 2006-12-08 | C3 | 4688h | 4688h | DIAMWi | Vodafone | Nico.Gabriele@vodafone.com | Rel-7 | Seung Don | 29.161 | TSG |  |
| 711 | 206 | Interworking between the 3GPP CS domain with BICC or ISUP as signalling protocol and external SIP-I networks |  | 478d? | 2006-09-22 A | 2008-07-22 A | 100% | 2006-09-22 | 2008-07-22 | 478d? | finish no earlier than 2007-09-14 | C3 | 3824h | 3824h | ExtSIPI | Siemens | thomas.belling@SIEMENS.COM | Rel-7 | Seung Don | 29.164 |  |  |
| 712 | 207 | PDU multiplexing at Nb Interface with IP transport |  | 427d? | 2006-12-04 A | 2008-07-22 A | 100% | 2006-12-04 | 2008-07-22 | 427d? | start no earlier than 2006-12-04 | C3 | 3416h | 3416h | NbIPMux | Alcatel-Lucent | Jean.Rzeznik@alcatel-lucent.fr | Rel-7 | Seung Don | 29.414 |  |  |

Notes:
- 685: S2#52 CREATED. TR for Info SP-33. SP-34: S2 Report intention to discontinue TR
- 686: S2#55 CREATED: SP-34 Approved and exception request granted until 03/07
- 687: S2#52 CREATED
- 688: Triggered by the abandoned Study UID_32117
- 690: CP-34 approved WID. CP-35 updated WID
- 691: CP-34 approved WID
- 692: WID approved SA#27.
- 693: WID approved SA#26.
- 694: WID approved SA#26, Dependant on Funding Availability.
- 697: TLS profile is moved to Rel-8
- 701: 33.223 goes to R8
- 705: TR 24.930: Signalling flows for the session setup in the IM CN subsystem based on Session Initiation Protocol (SIP)
- 712: 08/03/2007 08:00

| ID | WBS | Task | Type | Duration | Start | Finish | Complete | Baseline start | Baseline finish | Baseline duration | Constraint | Resources | Work | Actual work | Text1 | Text4 | Text5 | Text6 | Text8 | Text12 | Text7 |
| --- | --- | --- | --- | --- | --- | --- | --- | --- | --- | --- | --- | --- | --- | --- | --- | --- | --- | --- | --- | --- | --- |
| 713 | 208 | **Mp (MRFC - MRFP) interface** |  | 345d? | 2006-02-13 A | 2007-06-08 A | 100% | 2006-02-13 | 2007-06-08 | 345d? |  | C4,C1 | 4384h | 4384h | Mp | Ericsson | philip.hodges@ericsson.com | Rel-7 | Kimmo |  |  |
| 714 | 208.1 | CT1 aspects of Mp |  | 1d | 2006-02-13 A | 2006-02-13 A | 100% | 2006-02-13 | 2006-02-13 | 1d | finish no earlier than 2006-02-13 | C1 | 8h | 8h | Mp | Ericsson | philip.hodges@ericsson.com | Rel-7 |  |  |  |
| 715 | 208.2 | Deleted - CT3 aspects of Mp |  | 1d | 2006-09-22 A | 2006-09-22 A | 100% | 2006-09-22 | 2006-09-22 | 1d | start no earlier than 2006-09-22 | C3 | 8h | 8h | Mp | Ericsson | philip.hodges@ericsson.com | Rel-7 |  | CP-33 |  |
| 716 | 208.3 | Procedures description |  | 201d? | 2006-06-02 A | 2007-03-09 A | 100% | 2006-06-02 | 2007-03-09 | 201d? | finish no earlier than 2007-03-09 | C4 | 1608h | 1608h | Mp-PROCc4 | Huawei | Chen Cheng | Rel-7 | Kimmo |  |  |
| 717 | 208.4 | Stage 3 |  | 345d | 2006-02-13 A | 2007-06-08 A | 100% | 2006-02-13 | 2007-06-08 | 345d | finish no earlier than 2007-06-08 | C4 | 2760h | 2760h | Mp-St3c4 | Ericsson | philip.hodges@ericsson.com | Rel-7 | Kimmo |  |  |
| 718 | 209 | Routeing of MT-SMs via the HPLMN |  | 71d? | 2006-12-01 A | 2007-03-09 A | 100% | 2006-12-01 | 2007-03-09 | 71d? | finish no earlier than 2007-03-09 | C4,C1 | 568h | 568h | SMSviaH | Vodafone | Nick.Russell@vodafone.com | Rel-7 | Kimmo |  |  |
| 719 | 210 | Mobile Termination whilst the MS is moving to another MSC |  | 60d? | 2007-03-09 A | 2007-05-31 A | 100% | 2007-03-09 | 2007-05-31 | 60d? | start no earlier than 2007-03-09 | C4 | 480h | 480h | MTmovMS | Alcatel-Lucent | bruno.landais@alcatel-lucent.fr | Rel-7 |  |  |  |
| 720 | 211 | ISIM API for Java Card |  | 620d? | 2005-03-14 A | 2007-07-27 A | 100% | 2005-03-14 | 2007-07-27 | 620d? | finish no earlier than 2007-07-27 | C6 | 4960h | 4960h | APIJAVA | Sun | Sebastian Hans | Rel-7 | Gaby |  |  |
| 721 | 212 | High speed interface between the UICC and the ME |  | 311d? | 2006-09-22 A | 2007-11-30 A | 100% | 2006-09-22 | 2007-11-30 | 311d? | finish no earlier than 2007-11-30 | C6 | 2488h | 2488h | HSI | Gemalto | jacques.seif@GEMALTO.COM | Rel-7 | Gaby |  |  |
| 722 | 213 | Video Codec Performance Requirements |  | 634d? | 2005-01-03 A | 2007-06-07 A | 100% | 2005-01-03 | 2007-06-07 | 634d? | finish no earlier than 2007-06-07 | S4 | 5072h | 5072h | VICPer | Siemens | juergen.pandel@siemens.com | Rel-7 | Paolo |  | TSG |
| 723 | 214 | Dynamic and Interactive Multimedia Scenes |  | 583d? | 2005-03-15 A | 2007-06-07 A | 100% | 2005-03-15 | 2007-06-07 | 583d? | finish no earlier than 2007-06-07 | S4 | 4664h | 4664h | DIMS | Streamezzo | gaelle.martin-cocher@streamezzo.com | Rel-7 | Paolo |  | TSG |
| 724 | 215 | 3G-324M Video Telephony Call Setup Times Improvements |  | 341d? | 2005-06-08 A | 2006-09-27 A | 100% | 2005-06-08 | 2006-09-27 | 341d? | finish no earlier than 2006-09-27 | S4 | 2728h | 2728h | VTCSTI | Vodafone | edward.hall@vodafone.co.uk | Rel-7 | Paolo |  |  |
| 725 | 216 | **Optimizations for Multimedia Telephony over IMS** |  | 0d? | 2005-09-28 A | 2005-09-28 A | 100% | 2005-09-28 | 2005-09-28 | 0d? |  | S4 |  |  | OMTIMS | Ericsson | olle.franceschi@ericsson.com | Rel-7 | Paolo |  |  |
| 726 | 216.1 | Deleted - Characterisation of Adaptive Jitter Management Performance for VoIP Services | milestone | 0d? | 2005-09-28 A | 2005-09-28 A | 100% | 2005-09-28 | 2005-09-28 | 0d? | start no earlier than 2007-03-15 | S4 |  |  | OMTIMS-CAJMP | Lucent | dhuo@lucent.com | Rel-7 | Paolo | SP-35 |  |
| 727 | 217 | End-to-End Multimedia Services Performance Metrics |  | 382d? | 2005-09-28 A | 2007-03-15 A | 100% | 2005-09-28 | 2007-03-15 | 382d? | finish no earlier than 2007-03-15 | S4 | 3056h | 3056h | E2EMSPM | China Mobile | zhangyanyf@chinamobile.com | Rel-7 | Paolo |  |  |
| 728 | 218 | Packet Switched Streaming Enhancements |  | 261d? | 2006-06-08 A | 2007-06-07 A | 100% | 2006-06-08 | 2007-06-07 | 261d? | finish no earlier than 2007-06-07 | S4 | 2088h | 2088h | PSSe | Ericsson | olle.franceschi@ericsson.com | Rel-7 | Paolo |  |  |
| 729 | 219 | **OAM&P** |  | 472.86d? | 2005-09-02 A | 2007-06-26 A | 100% | 2005-09-02 | 2007-06-26 | 472.86d? |  | S5 | 82725.8h | 82725.8h | OAM7 | Toche | Christian.Toche@huawei.com | Rel-7 | Adrian |  | TSG |
| 730 | 219.1 | **Network Infrastructure Management** |  | 465d? | 2005-09-02 A | 2007-06-14 A | 100% | 2005-09-02 | 2007-06-14 | 465d? |  | S5 | 41800h | 41800h | OAM7-NIM |  |  | Rel-7 |  |  |  |
| 731 | 219.1.1 | Enhance NRM to accommodate NGN (IMS as basis of the Next Generation Network) |  | 465d? | 2005-09-02 A | 2007-06-14 A | 100% | 2005-09-02 | 2007-06-14 | 465d? | finish no earlier than 2007-06-14 | S5 | 3720h | 3720h | OAM7-NIM | Motorola |  | Rel-7 |  |  |  |
| 732 | 219.1.2 | Co-operative Element Management interface (CO-OP) (Study + Implementation) |  | 400d? | 2005-09-02 A | 2007-03-15 A | 100% | 2005-09-02 | 2007-03-15 | 400d? | finish no earlier than 2007-03-15 | S5 | 3200h | 3200h | OAM7-NIM | Motorola |  | Rel-7 |  |  |  |
| 733 | 219.1.3 | Network Management (NM) Itf-N performance criteria |  | 465d? | 2005-09-02 A | 2007-06-14 A | 100% | 2005-09-02 | 2007-06-14 | 465d? | finish no earlier than 2007-06-14 | S5 | 3720h | 3720h | OAM7-NIM | China Mobile |  | Rel-7 |  |  |  |
| 734 | 219.1.4 | Delta synchronization between IRP Manager and IRP Agent (Study + Implementation) |  | 465d? | 2005-09-02 A | 2007-06-14 A | 100% | 2005-09-02 | 2007-06-14 | 465d? | finish no earlier than 2007-06-14 | S5 | 3720h | 3720h | OAM7-NIM | Siemens |  | Rel-7 |  |  |  |
| 735 | 219.1.5 | Subscription Management (SuM) IRP Solution Sets |  | 330d? | 2005-09-02 A | 2006-12-07 A | 100% | 2005-09-02 | 2006-12-07 | 330d? | finish no earlier than 2006-12-07 | S5 | 2640h | 2640h | OAM7-NIM | Ericsson |  | Rel-7 |  |  |  |
| 736 | 219.1.6 | Integration Reference Point (IRP) Security Management |  | 400d? | 2005-09-02 A | 2007-03-15 A | 100% | 2005-09-02 | 2007-03-15 | 400d? | finish no earlier than 2007-03-15 | S5 | 3200h | 3200h | OAM7-NIM | Huawei |  | Rel-7 |  |  |  |
| 737 | 219.1.7 | Partial suspension of Itf-N during maintenance/testing (Study + Implementation) |  | 465d? | 2005-09-02 A | 2007-06-14 A | 100% | 2005-09-02 | 2007-06-14 | 465d? | finish no earlier than 2007-06-14 | S5 | 3720h | 3720h | OAM7-NIM | Siemens |  | Rel-7 |  |  |  |
| 738 | 219.1.8 | Stopped - Management of Legacy Equipment |  | 336d? | 2005-09-02 A | 2006-12-15 A | 100% | 2005-09-02 | 2006-12-15 | 336d? | finish no earlier than 2006-12-15 | S5 | 2688h | 2688h | OAM7-NIM | Siemens |  | Rel-7 |  |  |  |
| 739 | 219.1.9 | Stopped - Rules for Vendor Specific Extensions |  | 400d? | 2005-09-02 A | 2007-03-15 A | 100% | 2005-09-02 | 2007-03-15 | 400d? | finish no earlier than 2007-03-15 | S5 | 3200h | 3200h | OAM7-NIM | Siemens |  | Rel-7 |  |  |  |
| 740 | 219.1.10 | Backward and Forward Compatibility of IRP systems |  | 465d? | 2005-09-02 A | 2007-06-14 A | 100% | 2005-09-02 | 2007-06-14 | 465d? | finish no earlier than 2007-06-14 | S5 | 3720h | 3720h | OAM7-NIM | Ericsson |  | Rel-7 |  |  |  |
| 741 | 219.1.11 | Repeater Network Resource Model (NRM) definition |  | 214d? | 2006-02-13 A | 2006-12-07 A | 100% | 2006-02-13 | 2006-12-07 | 214d? | finish no earlier than 2006-12-07 | S5 | 1712h | 1712h | OAM7-NIM | China Mobile |  | Rel-7 |  |  |  |
| 742 | 219.1.12 | UTRAN radio channel power monitoring |  | 284d? | 2006-02-13 A | 2007-03-15 A | 100% | 2006-02-13 | 2007-03-15 | 284d? | finish no earlier than 2007-03-15 | S5 | 2272h | 2272h | OAM7-NIM | China Mobile |  | Rel-7 |  |  |  |
| 743 | 219.1.13 | Notification XML Schema |  | 71d? | 2006-12-07 A | 2007-03-15 A | 100% | 2006-12-07 | 2007-03-15 | 71d? | finish no earlier than 2007-03-15 | S5 | 568h | 568h | OAM7-NIM | Huawei |  | Rel-7 |  |  |  |

Notes:
- 714: Text3: 24.229
- 715: CT#34: CT3 not involved in Mp interface definition / Text3: 29.162
- 716: Text3: 23.333
- 717: Text3: 29.333
- 718: WID approved in CT#34 / Text3: 23.040, 29.002
- 719: Text3: 23.008, 23.012, 23.018, 23.078, 23.079, 29.002
- 720: reported complete when checked after CT6#44 / Text3: 31.103, TS 102 241
- 721: Following ETSI publication of TS 102 600, expected to be completed at CT6#45 / Text3: 31.101
- 722: Text3: 26.234, 26.235, 26.346, 26.140, 26.902
- 723: Text3: 26.140, 26.142, 26.234, 26.244, 23.346
- 724: Text3: 26.911
- 725: Text3: 26.235, 26.236
- 726: SP-35 stopped
- 727: Text3: 26.944
- 728: Text3: 26.234, 26.244
- 731: Text3: 32.731/2/3/5, 32.631/2/3/5
- 732: Text3: TR 32.806/814, 32.101
- 733: Text3: TR 32.811
- 734: Text3: 32.391/2/3/5
- 735: Text3: 32.307/317/607/667/665, 32.101, 32.175
- 736: Text3: 32.372/3/5, 32.111,32.30x,32.32x,32.33x,32.34x,32.35x,32.36x,32.41x,32.60x,32.61x,32.66x
- 737: Text3: 32.381/2/3/5
- 738: Text3: new TS 32.xxx
- 739: Request to TSG#35 to STOP the WI / Text3: 32.62n; For n = 1 to 5
- 740: Submit Exception Sheet for TSG#35 Approval / Text3: TS 32.154
- 741: Text3: 32.721/2/3/5
- 742: Text3: 32.405, 32.64n; For n = 1 to 5
- 743: 12/2006 SA#34 WID approved / Text3: New TS 32.325/345/365/415, CR to 32.335/615/665

| ID | WBS | Task | Type | Duration | Start | Finish | Complete | Baseline start | Baseline finish | Baseline duration | Constraint | Resources | Work | Actual work | Text1 | Text6 | Text4 | Text7 | Text12 | Text5 | Text8 | Text9 |
| --- | --- | --- | --- | --- | --- | --- | --- | --- | --- | --- | --- | --- | --- | --- | --- | --- | --- | --- | --- | --- | --- | --- |
| 744 | 219.2 | **Performance Management** |  | 465d? | 2005-09-02 A | 2007-06-14 A | 100% | 2005-09-02 | 2007-06-14 | 465d? |  | S5 | 22992h | 22992h | OAM7-PM | Rel-7 |  |  |  |  |  |  |
| 745 | 219.2.1 | Performance measurements definition for CN CS |  | 400d? | 2005-09-02 A | 2007-03-15 A | 100% | 2005-09-02 | 2007-03-15 | 400d? | finish no earlier than 2007-03-15 | S5 | 3200h | 3200h | OAM7-PM | Rel-7 | China Mobile |  |  |  |  |  |
| 746 | 219.2.2 | Enhancement UTRAN performance measurements definition |  | 465d? | 2005-09-02 A | 2007-06-14 A | 100% | 2005-09-02 | 2007-06-14 | 465d? | finish no earlier than 2007-06-14 | S5 | 3720h | 3720h | OAM7-PM | Rel-7 | China Mobile |  |  |  |  |  |
| 747 | 219.2.3 | Add TDD specific counters in Performance measurement |  | 330d? | 2005-09-02 A | 2006-12-07 A | 100% | 2005-09-02 | 2006-12-07 | 330d? | finish no earlier than 2006-12-15 | S5 | 2640h | 2640h | OAM7-PM | Rel-7 | CATT |  |  |  |  |  |
| 748 | 219.2.4 | ATM bearer network Performance measurements |  | 400d? | 2005-09-02 A | 2007-03-15 A | 100% | 2005-09-02 | 2007-03-15 | 400d? | finish no earlier than 2007-03-15 | S5 | 3200h | 3200h | OAM7-PM | Rel-7 | ZTE |  |  |  |  |  |
| 749 | 219.2.5 | Performance measurements definition for IMS |  | 465d? | 2005-09-02 A | 2007-06-14 A | 100% | 2005-09-02 | 2007-06-14 | 465d? | finish no earlier than 2007-06-14 | S5 | 3720h | 3720h | OAM7-PM | Rel-7 | China Mobile |  |  |  |  |  |
| 750 | 219.2.6 | HSDPA performance measurements |  | 349d? | 2006-02-13 A | 2007-06-14 A | 100% | 2006-02-13 | 2007-06-14 | 349d? | finish no earlier than 2007-06-14 | S5 | 2792h | 2792h | OAM7-PM | Rel-7 | China Mobile |  |  |  |  |  |
| 751 | 44.5 | **Trace Management** |  | 472.86d? | 2005-09-02 A | 2007-06-26 A | 100% | 2005-09-02 | 2007-06-26 | 472.86d? |  | S5 | 14150.9h | 14150.9h | OAM7-Trace | Rel-7 | Vodafone | TSG |  |  |  |  |
| 752 | 219.3.1 | End-to-end Service Level tracing for IMS |  | 350d? | 2005-11-11 A | 2007-03-15 A | 100% | 2005-11-11 | 2007-03-15 | 350d? | finish no earlier than 2007-03-15 | S5 | 2800h | 2800h | OAM7-Trace | Rel-7 | Vodafone | TSG | SP-31 |  |  |  |
| 753 | 219.3.2 | Trace record content for UTRAN TDD |  | 330d? | 2005-09-02 A | 2006-12-07 A | 100% | 2005-09-02 | 2006-12-07 | 330d? | finish no earlier than 2006-12-07 | S5 | 2640h | 2640h | OAM7-Trace | Rel-7 | Nokia | TSG |  |  |  |  |
| 754 | 219.3.3 | IRP for Subscriber and Equipment Trace Management |  | 465d? | 2005-09-02 A | 2007-06-14 A | 100% | 2005-09-02 | 2007-06-14 | 465d? | finish no earlier than 2007-06-14 | S5 | 3720h | 3720h | OAM7-Trace | Rel-7 | Nokia | TSG |  |  |  |  |
| 755 | 219.3.4 | Deleted - SIP enhancements for trace | milestone | 0d? | 2007-06-15 A | 2007-06-26 A | 100% | 2007-06-15 | 2007-06-26 | 0d? | start no earlier than 2007-06-15 | C1 |  |  | OAM7-Trace | Rel-7 |  |  | CP-32 |  |  |  |
| 756 | 219.3.5 | Deleted - duplicated with UID 35063 - IRP for Subscriber and Equipment Trace Management |  | 336d? | 2005-09-02 A | 2006-12-15 A | 100% | 2005-09-02 | 2006-12-15 | 336d? | finish no earlier than 2006-12-15 | S5 | 2688h | 2688h | OAM7-Trace | Rel-7 | Nokia | TSG | SP-33 |  |  |  |
| 757 | 220 | **Charging Management small Enhancements Rel-7** |  | 279d? | 2006-05-22 A | 2007-06-14 A | 100% | 2006-05-22 | 2007-06-14 | 279d? |  | S5 | 5952h | 5952h | CH7 | Rel-7 | Orange |  |  | alain.bibas@francetelecom.com | Adrian |  |
| 758 | 220.1 | Alternate Charged Party (ACP) for IMS |  | 279d? | 2006-05-22 A | 2007-06-14 A | 100% | 2006-05-22 | 2007-06-14 | 279d? | finish no earlier than 2007-06-14 | S5 | 2232h | 2232h | CH7-IMS-ACP | Rel-7 | Lucent |  |  | njmazzarella@alcatel-lucent.com |  |  |
| 759 | 220.2 | Align 3GPP Charging with OMA PoC Enabler Release 2.0 |  | 186d? | 2006-09-28 A | 2007-06-14 A | 100% | 2006-09-28 | 2007-06-14 | 186d? | finish no earlier than 2007-06-14 | S5 | 1488h | 1488h | CH7-PoC | Rel-7 | Siemens |  |  | gerald.goermer@siemens.com | Adrian |  |
| 760 | 8.5 | **Multiple Input Multiple Output antennas (MIMO)** |  | 1177d? | 2003-03-14 A | 2007-09-17 A | 100% | 2003-03-14 | 2007-09-17 | 1177d? |  | R1 | 40272h | 40272h | MIMO | Rel-7 | Alcatel-Lucent | TSG |  | hchuang@Alcatel-Lucent.com | Patrick | 2468 |
| 761 | 221.1 | MIMO - Physical layer |  | 915d? | 2003-09-12 A | 2007-03-15 A | 100% | 2003-09-12 | 2007-03-15 | 915d? | finish no earlier than 2007-03-15 | R1 | 7320h | 7320h | MIMO-Phys | Rel-7 | ALU | TSG |  | hchuang@Alcatel-Lucent.com | Patrick |  |
| 762 | 221.2 | MIMO - Layer 2,3 aspects |  | 915d? | 2003-09-12 A | 2007-03-15 A | 100% | 2003-09-12 | 2007-03-15 | 915d? | finish no earlier than 2007-03-15 | R2 | 7320h | 7320h | MIMO-L23 | Rel-7 | ALU | TSG |  | hchuang@Alcatel-Lucent.com | Joern |  |
| 763 | 221.3 | MIMO - Iub/Iur Protocol Aspects |  | 1045d? | 2003-03-14 A | 2007-03-15 A | 100% | 2003-03-14 | 2007-03-15 | 1045d? | finish no earlier than 2007-03-15 | R3 | 8360h | 8360h | MIMO-IurIub | Rel-7 | ALU | TSG |  | hchuang@Alcatel-Lucent.com | Juergen |  |
| 764 | 221.4 | MIMO - RF Radio Transmission/Reception, System Performance Requirements and Conformance Testing |  | 982d? | 2003-12-12 A | 2007-09-17 A | 100% | 2003-12-12 | 2007-09-17 | 982d? | finish no earlier than 2007-09-17 | R4 | 7856h | 7856h | MIMO-RF | Rel-7 | ALU | TSG |  | ngm@Alcatel-Lucent.com | Stefania |  |
| 765 | 222 | **Rel-7 Improvements of the Radio Interface** |  | 709d? | 2004-09-15 A | 2007-06-04 A | 100% | 2004-09-15 | 2007-06-04 | 709d? |  | RP | 29696h | 29696h | RInImp | Rel-7 |  |  |  |  | Juergen |  |
| 766 | 222.1 | Extended UMTS 1.7/2.1 GHz |  | 198d? | 2006-03-15 A | 2006-12-15 A | 100% | 2006-03-15 | 2006-12-15 | 198d? | finish no earlier than 2006-12-15 | R4 | 1584h | 1584h | RInImp-UMTS1721Ext | Rel-7 | Ericsson |  |  | johan.skold@ericsson.com | Stefania |  |
| 767 | 222.2 | UMTS 2.6 GHz 7.68 Mcps TDD |  | 67d? | 2006-06-15 A | 2006-09-15 A | 100% | 2006-06-15 | 2006-09-15 | 67d? | finish no earlier than 2006-09-15 | R4 | 536h | 536h | RInImp-UMTS26VHCRTDD | Rel-7 | IPWireless |  |  | Shin Horng Wong (shwong@ipwireless.com) | Stefania |  |
| 768 | 222.3 | UMTS 2.6 GHz |  | 195d? | 2004-09-15 A | 2005-06-14 A | 100% | 2004-09-15 | 2005-06-14 | 195d? | finish no earlier than 2005-06-14 | R4 | 1560h | 1560h | RInImp-UMTS2600 | Rel-7 | Nokia | TSG |  | jussi.numminen@nokia.com | Stefania |  |
| 769 | 222.4 | UMTS 2.6 GHz TDD |  | 261d? | 2004-12-15 A | 2005-12-14 A | 100% | 2004-12-15 | 2005-12-14 | 261d? | finish no earlier than 2005-12-15 | R4 | 2088h | 2088h | RInImp-UMTS2600TDD | Rel-7 | IPWireless | TSG |  | Shin Horng Wong ( (shwong@IPWIRELESS.COM) | Stefania |  |
| 770 | 222.5 | UMTS 900 MHz |  | 261d? | 2004-12-15 A | 2005-12-14 A | 100% | 2004-12-15 | 2005-12-14 | 261d? | finish no earlier than 2005-12-15 | R4 | 2088h | 2088h | RInImp-UMTS900 | Rel-7 | Nortel | TSG |  | Yannick Li (yli@nortelnetworks.com) | Stefania |  |
| 771 | 222.6 | UMTS 1700 MHz |  | 197d? | 2005-03-15 A | 2005-12-14 A | 100% | 2005-03-15 | 2005-12-14 | 197d? | finish no earlier than 2005-12-15 | R4 | 1576h | 1576h | RInImp-UMTS1700 | Rel-7 | NTT DoCoMo | TSG |  | nakamurata@NTTDOCOMO.CO.JP | Stefania |  |
| 772 | 222.7 | UE Antenna Performance Evaluation Method and Requirements |  | 644d? | 2004-12-15 A | 2007-06-04 A | 100% | 2004-12-15 | 2007-06-04 | 644d? | finish no earlier than 2007-06-04 | R4 | 5152h | 5152h | RInImp-UEAnt | Rel-7 | TeliaSonera | TSG |  | Christian.Bergljung@TeliaSonera.com | Stefania |  |
| 773 | 222.8 | Improved Performance Requirements for HSDPA UE based on Rx Diversity (type 1) & LMMSE equalizer (type 2) | milestone | 0d? | 2005-03-15 A | 2005-03-15 A | 100% | 2005-03-15 | 2005-03-15 | 0d? | finish no earlier than 2005-03-15 | R4 |  |  | RInImp-HSPerf-Type3 | Rel-7 | Cingular | TSG |  | marc.grant@cingular.com | Stefania |  |

Notes:
- 745: Text3: 32.407, 32.408
- 746: Submit Exception Sheet for TSG#35 Approval / Text3: 32.405
- 747: Text3: 32.405
- 748: Text3: No impact on 32.404, 32.405, 32.406, 32.407
- 749: Submit Exception Sheet for TSG#35 Approval / Text3: 32.404,32.409,32.437, 32.632/3/4/5
- 750: Submit Exception Sheet for TSG#35 Approval / Text3: 32.405
- 752: 07/2005: OMA (Stage 1), Stage 2/3 SA5, CT1/3/4 / Text3: CR 32.101, 32.421/2/3.
- 753: Text3: CR 32.421/2/3.
- 754: Submit Exception Sheet for TSG#35 Approval / Text3: TS 32.441/2/3/5, CRs 32.632/3/5
- 755: combined with UID 11067
- 756: Text3: 32.421,32.422,32.423. 3 new TS 32.4x1,2,3
- 757: Text3: 32.2xy
- 758: Text3: 32.240, 32.260, 32.298, 32.299
- 759: 09/2006 SA#33 WID approved / Text3: 32.240, 32.272, 32.299, 32.298
- 760: Completed Sep 2007; Status Report in RP-070037and RP-070531 / Text3: 25.876, 25.996
- 761: Completed Sep 2007; Status Report in RP-070037 / Text3: 25.211, 25.212, 25.213, 25.214, 25.215, 25.221
- 762: Completed Sep 2007; Status Report in RP-070037 / Text3: 25.876
- 763: Completed Sep 2007; Status Report in RP-070037
- 764: Completed Sep 2007; Status Report in RP-070531
- 765: Generic feature
- 766: Completed Dec 2006; Status Report in RP-060681 / Text3: 25.806, 25.101, 25.104, 25.133, 24.141, 25.331, 25.306, 25.307, 25.423, 25.461, 25.463, 34.121
- 767: Completed Sep 2006; Status Report in RP-060451 / Text3: 25.102, 25.105, 25.123, 25.113, 25.142, 34.124
- 768: Completed Jun 2005, Status Report in RP-050184 / Text3: TS25.101, TS25.104, TS25.133, TS25.141, TS25.331, TS25.942, TS25.306, TS25.307, TS34.121
- 769: Completed Dec 2005, Status Report in RP-050661 / Text3: 25.102, 25.105, 25.113, 25.123, 25.142, 25.331, 25.942, 25.306, 25.307, 34.122, 34.124
- 770: Completed Dec 2005, Status Report in RP-050662 / Text3: 25.101, 25.104, 25.113, 25.133, 25.141, 25.331, 25.942, 25.306, 25.307, 34.121
- 771: Completed Dec 2005; Status Report in RP-050824 / Text3: 25.101, 25.104, 25.113, 25.133, 25.141, 25.306, 25.307, 25.331, 34.121
- 772: RAN#36 (May 2007) completed. Status Report in RP-070281 / Text3: 25.101, 25.963
- 773: Completed Mar 2006, Status Report in RP-060015 / Text3: 25.101

| ID | WBS | Task | Type | Duration | Start | Finish | Complete | Baseline start | Baseline finish | Baseline duration | Constraint | Resources | Work | Actual work | Text1 | Text4 | Text5 | Text6 | Text8 | Text7 | Text12 |
| --- | --- | --- | --- | --- | --- | --- | --- | --- | --- | --- | --- | --- | --- | --- | --- | --- | --- | --- | --- | --- | --- |
| 774 | 222.9 | **Additional minimum UE performance requirement for non-HSDPA channels based on type 1 enhanced receiver (Rx Diversity)** |  | 327d? | 2005-09-15 A | 2006-12-15 A | 100% | 2005-09-15 | 2006-12-15 | 327d? |  | R4 | 7344h | 7344h | RInImp-RxDiv | Qualcomm | Serge Willenegger (sergew@qualcomm.com) | Rel-7 | Stefania |  |  |
| 775 | 222.9.1 | Additional minimum UE performance requirement for DL physical channels in support of DCH/HS-DSCH operation based on type 1 enhanced receiver (RX-Diversity) |  | 195d? | 2005-09-15 A | 2006-06-14 A | 100% | 2005-09-15 | 2006-06-14 | 195d? | finish no earlier than 2006-06-15 | R4 | 1560h | 1560h | RInImp-RxDiv-DCH | Cingular | marc.grant@cingular.com | Rel-7 | Stefania | TSG |  |
| 776 | 222.9.2 | Additional minimum UE performance requirement for downlink physical channels in support of MTCH and MCCH operation based on type 1 enhanced receiver (Rx-Diversity) |  | 198d? | 2006-03-15 A | 2006-12-15 A | 100% | 2006-03-15 | 2006-12-15 | 198d? | finish no earlier than 2006-12-15 | R4 | 1584h | 1584h | RInImp-RxDiv-MBMS | Qualcomm | Serge Willenegger (sergew@qualcomm.com) | Rel-7 | Stefania |  |  |
| 777 | 222.9.3 | Additional minimum UE performance requirement for downlink physical channels in support of E-DCH operation based on type 1 enhanced receiver (Rx-Diversity) |  | 198d? | 2006-03-15 A | 2006-12-15 A | 100% | 2006-03-15 | 2006-12-15 | 198d? | finish no earlier than 2006-12-15 | R4 | 1584h | 1584h | RInImp-RxDiv-EDCH | Qualcomm | Serge Willenegger (sergew@qualcomm.com) | Rel-7 | Stefania |  |  |
| 778 | 222.10 | Deleted Improved support of gaming over HSDPA/EDCH |  | 262d? | 2005-12-15 A | 2006-12-15 A | 100% | 2005-12-15 | 2006-12-15 | 262d? | finish no earlier than 2006-12-15 | R2 | 2096h | 2096h | RInImp-Gaming | Cingular | don.zelmer@cingular.com | Rel-7 | MCC_RAN |  | RP-34 |
| 779 | 222.11 | Deleted (not approved at PCG) - UMTS 2.6 GHz FDD DL External | milestone | 0d? | 2005-09-15 A | 2005-09-15 A | 100% | 2005-09-15 | 2005-09-15 | 0d? | finish no earlier than 2005-09-15 | R4 |  |  | RInImp-UMTS2600Ext | T-mobile | han.van.bussel@t-mobile.de | Rel-7 | Stefania | TSG | RP-31 |
| 780 | 223 | **Rel-7 RAN improvements** |  | 653d? | 2004-12-15 A | 2007-06-15 A | 100% | 2004-12-15 | 2007-06-15 | 653d? |  | RP | 29920h | 29920h | RANimp |  |  | Rel-7 | Juergen | TSG |  |
| 781 | 223.1 | Optimisation of channelisation code utilisation for 1.28 Mcps TDD |  | 523d? | 2004-12-15 A | 2006-12-15 A | 100% | 2004-12-15 | 2006-12-15 | 523d? | finish no earlier than 2006-12-15 | R1 | 4184h | 4184h | RANimp-RABSE-CodOptLCRTDD | UTStarcom | Ka Leong Lo (kaleong.lo@UTSTAR.COM) | Rel-7 | Patrick | TSG |  |
| 782 | 223.2 | Delay optimisation for procedures applicable to CS and PS Connections |  | 394d? | 2005-03-15 A | 2006-09-15 A | 100% | 2005-03-15 | 2006-09-15 | 394d? | finish no earlier than 2006-09-15 | R2 | 3152h | 3152h | RANimp-DelayOpt | Nokia | juho.pirskanen@nokia.com | Rel-7 | Joern | TSG |  |
| 783 | 223.3 | Improved support of IMS Realtime Services using HSDPA/HSUPA |  | 197d? | 2005-03-15 A | 2005-12-14 A | 100% | 2005-03-15 | 2005-12-14 | 197d? | start no earlier than 2005-03-15 | R2 | 1576h | 1576h | RANimp-IMSRealTime | Cingular | don.zelmer@CINGULAR.COM | Rel-7 | Joern | TSG |  |
| 784 | 223.4 | UE Performance Requirements for MBMS (TDD) |  | 328d? | 2005-03-15 A | 2006-06-15 A | 100% | 2005-03-15 | 2006-06-15 | 328d? | finish no earlier than 2006-06-15 | R4 | 2624h | 2624h | MBMS-RAN-RF-TDD | IPwireless | shwong@ipwireless.com | Rel-7 | Stefania | TSG |  |
| 785 | 223.5 | Continuous connectivity for packet data users |  | 524d? | 2005-03-14 A | 2007-03-15 A | 100% | 2005-03-14 | 2007-03-15 | 524d? | finish no earlier than 2007-03-15 | R1 | 4192h | 4192h | RANimp-CPC | Siemens | Joern.Krause@siemens.com | Rel-7 | Patrick | TSG |  |
| 786 | 223.6 | Extended WCDMA Cell Range |  | 198d? | 2006-03-15 A | 2006-12-15 A | 100% | 2006-03-15 | 2006-12-15 | 198d? | finish no earlier than 2006-12-15 | R3 | 1584h | 1584h | RANimp-ExtCell | Ericsson | Muhammad Kazmi | Rel-7 | Juergen |  |  |
| 787 | 223.7 | 7.68 Mcps TDD Enhanced Uplink |  | 198d? | 2006-03-15 A | 2006-12-15 A | 100% | 2006-03-15 | 2006-12-15 | 198d? | finish no earlier than 2006-12-15 | R1 | 1584h | 1584h | RANimp-VHCRTDD-EDCH | IPwireless | nanderson@ipwireless.com | Rel-7 | Patrick |  |  |
| 788 | 223.8 | Enhanced CELL_FACH State in FDD |  | 181d? | 2006-09-25 A | 2007-06-04 A | 100% | 2006-09-25 | 2007-06-04 | 181d? | finish no earlier than 2007-06-04 | R2 | 1448h | 1448h | RANimp-EnhState | Nokia | juho.pirskanen@nokia.com | Rel-7 | Joern |  |  |
| 789 | 223.9 | 64QAM for HSDPA (FDD) |  | 110d? | 2006-12-15 A | 2007-06-04 A | 100% | 2006-12-15 | 2007-06-04 | 110d? | finish no earlier than 2007-06-04 | R1 | 880h | 880h | RANimp-64QamDownlink | Ericsson | Johan.Bergman@ericsson.com | Rel-7 | Patrick |  |  |
| 790 | 223.10 | Improved L2 support for high data rates |  | 122d? | 2006-12-15 A | 2007-06-04 A | 100% | 2006-12-15 | 2007-06-04 | 122d? | finish no earlier than 2007-06-04 | R2 | 976h | 976h | RANimp-L2DataRates | Ericsson | Janne.Peisa@ericsson.com | Rel-7 | Joern |  |  |
| 791 | 223.11 | Introduction of 16QAM in HSUPA (FDD) |  | 110d? | 2006-12-15 A | 2007-06-04 A | 100% | 2006-12-15 | 2007-06-04 | 110d? | finish no earlier than 2007-06-04 | R1 | 880h | 880h | RANimp-16QamUplink | Nokia | karri.ranta-aho@nokia.com | Rel-7 | Patrick |  |  |
| 792 | 223.12 | **Interface to control Tower Mounted Amplifiers (TMAs)** |  | 101d? | 2007-01-26 A | 2007-06-15 A | 100% | 2007-01-26 | 2007-06-15 | 101d? |  | R3 | 1616h | 1616h | RANImp-TMA | Vodafone | alexej.kulakov@vodafone.com | Rel-7 | Juergen |  |  |
| 793 | 223.12.1 | OAM aspects to Interface to control TMAs |  | 101d? | 2007-01-26 A | 2007-06-15 A | 100% | 2007-01-26 | 2007-06-15 | 101d? | finish no earlier than 2007-06-15 | S5 | 808h | 808h | RANImp-TMA-OAM | Adrian Neal, Vodafone | Adrian.Neal@vodafone.com | Rel-7 | Adrian |  |  |
| 794 | 224 | **7.68Mcps TDD option** |  | 457d? | 2004-09-15 A | 2006-06-15 A | 100% | 2004-09-15 | 2006-06-15 | 457d? |  | RP | 19824h | 19824h | VHCRTDD | IPwireless | mbeale@ipwireless.com | Rel-7 | Juergen | TSG |  |
| 795 | 224.1 | VHCRTDD: Stage 2 |  | 391d? | 2004-09-15 A | 2006-03-15 A | 100% | 2004-09-15 | 2006-03-15 | 391d? | finish no earlier than 2006-03-15 | R1 | 3128h | 3128h | VHCRTDD-Stage2 | Martin Beale, IPWireless | mbeale@ipwireless.com | Rel-7 | MCC_RAN | TSG |  |
| 796 | 224.2 | VHCRTDD: Physical Layer |  | 391d? | 2004-09-15 A | 2006-03-15 A | 100% | 2004-09-15 | 2006-03-15 | 391d? | finish no earlier than 2006-03-15 | R1 | 3128h | 3128h | VHCRTDD-Phys | Martin Beale, IPWireless | mbeale@ipwireless.com | Rel-7 | MCC_RAN | TSG |  |
| 797 | 224.3 | VHCRTDD: Layer 2 and layer 3 protocol aspects |  | 391d? | 2004-09-15 A | 2006-03-15 A | 100% | 2004-09-15 | 2006-03-15 | 391d? | finish no earlier than 2006-03-15 | R2 | 3128h | 3128h | VHCRTDD-L23 | Derek Richards, IPWireless | drichards@ipwireless.com | Rel-7 | MCC_RAN | TSG |  |
| 798 | 224.4 | VHCRTDD: UTRAN Iub/Iur Protocol Aspects |  | 391d? | 2004-09-15 A | 2006-03-15 A | 100% | 2004-09-15 | 2006-03-15 | 391d? | finish no earlier than 2006-03-15 | R3 | 3128h | 3128h | VHCRTDD-IurIub | Peter Legg, IPWireless | plegg@ipwireless.com | Rel-7 | MCC_RAN | TSG |  |
| 799 | 224.5 | VHCRTDD: RF Radio Transmission/ Reception, System Performance Requirements and Conformance Testing |  | 457d? | 2004-09-15 A | 2006-06-15 A | 100% | 2004-09-15 | 2006-06-15 | 457d? | finish no earlier than 2006-06-15 | R4 | 3656h | 3656h | VHCRTDD-RF | Shin Horng Wong | shwong@ipwireless.com | Rel-7 | MCC_RAN | TSG |  |

Notes:
- 774: BB contains 3 WTs / Text3: 25.101
- 775: Completed Jun 2006, Status Report in RP-060235 / Text3: 25.101
- 776: Completed Dec 2006, Status Report in RP-060678 / Text3: 25.101
- 777: Completed Dec 2006, Status Report in RP-060679 / Text3: 25.101
- 778: RAN#34 (Dec 2006) stopped. Status Report in RP-060680
- 779: This item was conditionnaly approved pending decision of PCG 16 who decided not to approve it / Text3: 25.101, 25.104, 25.133, 25.141, 25.331, 25.942, 25.306, 25.307, 34.121
- 780: Generic feature
- 781: Completed Dec 2006; Status Report in RP-060682
- 782: Completed Sep 2006; Status Report in RP-060453 / Text3: 25.815, TS25.321, TS25.322, TS25.331
- 783: Closed Dec 2005; Status Report in RP-050667
- 784: Completed Sep 2006; Status Report in RP-060477 / Text3: TS25.102, TS25.123
- 785: Completed at Mar 2007; Status Report in RP-070033 / Text3: 25.903, 25.201, 25.211, 25.212, 25.214, 25.308, 25.321, 25.331, 25.423, 25.433, 25.101, 25.133
- 786: Completed Dec 2006; Status Report in RP-060685 / Text3: 25.133, 25.423, 25.425, 25.433, 25.435, 25.453, 25.331
- 787: Completed Dec 2006; Status Report in RP-060684 / Text3: 25.201, 25.202, 25.221, 25.222, 25.223, 25.224, 25.225, 25.331, 23.321, 25.306, 25.302, 25.401, 25.420, 25.423, 25.427, 25.433, 25.102, 25.105, 25.142
- 788: Completed May 2007; Status Report in RP-070286 / Text3: 25.308, 25.304, 25.306, 25.321, 25.331, 25.433, 25.435, 25.423, 25.425,
- 789: Completed May 2007; Status Report in RP-070287 / Text3: 25.308, 25.211, 25.212, 25.213, 25.306, 25.331, 25.433, 25.435, 25.423, 25.425, 25.101, 25.104, 25.141
- 790: Completed May 2007; Status Report in RP-070289 / Text3: 25.301, 25.308,25.306, 25.321, 25.322, 25.331, 25.433, 25.435, 25.423, 25.425, 25.999
- 791: Completed May 2007; Status Report in RP-070288 / Text3: 25.319, 25.101, 25.104, 25.133, 25.141, 25.211, 25.212, 25.213, 25.214, 25.306, 25.321, 25.331, 25.423, 25.433
- 792: Completed Mar 2007; Status Report in RP-070140
- 793: SA#36 Jun 2007 completed / Text3: 32.642/3/5 – Align with RAN 25.466
- 794: Completed Dec 2006, Status Report in RP-060684
- 795: Feature completed and closed at RP#33 with the presentation of the test WI / Text3: TS25.202
- 796: Feature completed and closed at RP#33 with the presentation of the test WI / Text3: TS25.221, TS25.222, TS25.223, TS25.224,TS25.225
- 797: Feature completed and closed at RP#33 with the presentation of the test WI / Text3: TS25.301, TS25.302, TS25.305, TS25.306, TS25.321, TS25.331
- 798: Feature completed and closed at RP#33 with the presentation of the test WI / Text3: TS25.401, TS25.420, TS25.423, TS25.425, TS25.427, TS25.430, TS25.433, TS25.435
- 799: Feature completed and closed at RP#33 with the presentation of the test WI / Text3: TS25.102, TS25.105, TS25.123, TS25.133, TS25.142

| ID | WBS | Task | Type | Duration | Start | Finish | Complete | Baseline start | Baseline finish | Baseline duration | Total slack | Constraint | Resources | Work | Actual work | Text1 | Text4 | Text5 | Text6 | Text7 | Text8 | Text12 |
| --- | --- | --- | --- | --- | --- | --- | --- | --- | --- | --- | --- | --- | --- | --- | --- | --- | --- | --- | --- | --- | --- | --- |
| 800 | 225 | **3.84 Mcps TDD Enhanced Uplink** |  | 394d? | 2005-03-15 A | 2006-09-15 A | 100% | 2005-03-15 | 2006-09-15 | 394d? |  |  | RP | 18384h | 18384h | EDCHTDD | IPwireless | nanderson@ipwireless.com | Rel-7 | TSG | Juergen |  |
| 801 | 225.1 | EDCHTDD: Stage 2 |  | 328d? | 2005-03-15 A | 2006-06-15 A | 100% | 2005-03-15 | 2006-06-15 | 328d? |  | finish no earlier than 2006-06-15 | R2 | 2624h | 2624h | EDCHTDD-Stage2 | Nicholas Anderson | nanderson@ipwireless.com | Rel-7 | TSG | MCC_RAN |  |
| 802 | 225.2 | EDCHTDD: Physical Layer |  | 394d? | 2005-03-15 A | 2006-09-15 A | 100% | 2005-03-15 | 2006-09-15 | 394d? |  | finish no earlier than 2006-09-15 | R1 | 3152h | 3152h | EDCHTDD-Phys | Nicholas Anderson | nanderson@ipwireless.com | Rel-7 | TSG | MCC_RAN |  |
| 803 | 225.3 | EDCHTDD: Layer 2 and 3 Protocol Aspects |  | 394d? | 2005-03-15 A | 2006-09-15 A | 100% | 2005-03-15 | 2006-09-15 | 394d? |  | finish no earlier than 2006-09-15 | R2 | 3152h | 3152h | EDCHTDD-L23 | Derek Richards | drichards@ipwireless.com | Rel-7 | TSG | MCC_RAN |  |
| 804 | 225.4 | EDCHTDD: UTRAN Iub/Iur Protocol Aspects |  | 394d? | 2005-03-15 A | 2006-09-15 A | 100% | 2005-03-15 | 2006-09-15 | 394d? |  | finish no earlier than 2006-09-15 | R3 | 3152h | 3152h | EDCHTDD-IurIub | Jim Miller | jim.miller@interdigital.com | Rel-7 | TSG | MCC_RAN |  |
| 805 | 225.5 | EDCHTDD: RF Radio Transmission/ Reception, System Performance Requirements and Conformance Testing |  | 394d? | 2005-03-15 A | 2006-09-15 A | 100% | 2005-03-15 | 2006-09-15 | 394d? |  | finish no earlier than 2006-09-15 | R4 | 3152h | 3152h | EDCHTDD-RF | Shin Horng Wong | shwong@ipwireless.com | Rel-7 | TSG | MCC_RAN |  |
| 806 | 226 | **1.28 Mcps TDD Enhanced Uplink** |  | 328d? | 2006-03-15 A | 2007-06-15 A | 100% | 2006-03-15 | 2007-06-15 | 328d? |  |  | RP | 11536h | 11536h | LCRTDD-EDCH | CATT | Haijing Hu | Rel-7 |  | Juergen |  |
| 807 | 226.1 | 1.28 Mcps TDD Enhanced Uplink: Physical Layer |  | 262d? | 2006-03-15 A | 2007-03-15 A | 100% | 2006-03-15 | 2007-03-15 | 262d? |  | finish no earlier than 2007-03-15 | R1 | 2096h | 2096h | LCRTDD-EDCH-Phys | Ke Wang (CATT) |  | Rel-7 |  | MCC_RAN |  |
| 808 | 226.2 | 1.28 Mcps TDD Enhanced Uplink: Layer 2 and 3 Protocol Aspects |  | 262d? | 2006-03-15 A | 2007-03-15 A | 100% | 2006-03-15 | 2007-03-15 | 262d? |  | finish no earlier than 2007-03-15 | R2 | 2096h | 2096h | LCRTDD-EDCH-L23 | Haiyang Quan (CATT) |  | Rel-7 |  | MCC_RAN |  |
| 809 | 226.3 | 1.28 Mcps TDD Enhanced Uplink: UTRAN Iub/Iur Protocol Aspects |  | 262d? | 2006-03-15 A | 2007-03-15 A | 100% | 2006-03-15 | 2007-03-15 | 262d? |  | finish no earlier than 2007-03-15 | R3 | 2096h | 2096h | LCRTDD-EDCH-IubIur | Yincheng Zhang (CATT) |  | Rel-7 |  | MCC_RAN |  |
| 810 | 226.4 | 1.28 Mcps TDD Enhanced Uplink: RF Radio Transmission/ Reception, System Performance Requirements and Conformance Testing |  | 328d? | 2006-03-15 A | 2007-06-15 A | 100% | 2006-03-15 | 2007-06-15 | 328d? |  | finish no earlier than 2007-06-15 | R4 | 2624h | 2624h | LCRTDD-EDCH-RF | Yuexia Song (CATT) |  | Rel-7 |  | MCC_RAN |  |
| 811 | 227 | 1.28Mcps TDD Enhanced Uplink - UE Conformance Testing |  | 257d? | 2007-09-19 | 2008-09-11 |  | 2007-09-19 | 2008-09-11 | 257d? | 336d | finish no earlier than 2008-09-11 | R5 | 624h |  | LCRTDD-EDCH-UEConTest | CATT | chenxiaozhong@datangmobile.cn | Rel-7 |  | Ingbert |  |
| 812 | 228 | MS Antenna Performance Evaluation Method and Requirements |  | 731d? | 2005-01-28 A | 2007-11-16 A | 100% | 2005-01-28 | 2007-11-16 | 731d? |  | finish no earlier than 2007-11-16 | GP | 5848h | 5848h | APEMR | TeliaSonera | Ulf.Tegth@teliasonera.com | Rel-7 |  | Paolo |  |
| 813 | 229 | **Lower 700 MHz Inclusion in the GERAN Specifications** |  | 390d? | 2005-01-03 A | 2006-06-30 A | 100% | 2005-01-03 | 2006-06-30 | 390d? |  |  | GP | 7632h | 7632h | GSM710 | Dave Cotton (UTC) | dcotton@mtview.union-tel.com | Rel-7 | TSG | Paolo |  |
| 814 | 229.1 | Inclusion of the 698 – 746 MHz band into GERAN core specifications |  | 129d? | 2005-01-03 A | 2005-06-30 A | 100% | 2005-01-03 | 2005-06-30 | 129d? |  | finish no earlier than 2005-06-30 | G1 | 1032h | 1032h | GSM710-core |  |  | Rel-7 |  | Paolo |  |
| 815 | 229.2 | G1 aspects of GSM710 |  | 217.5d? | 2005-08-31 A | 2006-06-30 A | 100% | 2005-08-31 | 2006-06-30 | 217.5d? |  | finish no earlier than 2006-06-30 | G1 | 1740h | 1740h | GSM-710-test |  |  | Rel-7 |  | Paolo |  |
| 816 | 229.3 | G3 aspects of GSM710 |  | 217.5d? | 2005-08-31 A | 2006-06-30 A | 100% | 2005-08-31 | 2006-06-30 | 217.5d? |  | finish no earlier than 2006-06-30 | G3 | 1740h | 1740h | GSM-710-test |  |  | Rel-7 |  | Stoyan |  |
| 817 | 230 | **Support of Conversational Services in A/Gb mode via the PS domain** |  | 626d? | 2005-04-08 A | 2007-08-31 A | 100% | 2005-04-08 | 2007-08-31 | 626d? |  |  | GP | 15442.8h | 15442.8h | SCSAGB | Gunnar Hedby, Ericsson | gunnar.hedby@ericsson.com | Rel-7 |  | Paolo |  |
| 818 | 230.1 | Minimise the transfer delay between the SGSN and the MS |  | 604.95d? | 2005-04-08 A | 2007-08-31 A | 100% | 2005-04-08 | 2007-08-31 | 604.95d? |  | finish no earlier than 2007-08-31 | GP | 4839.6h | 4839.6h | SCSAGB-MTD | Gunnar Hedby, Ericsson |  | Rel-7 |  | Paolo |  |
| 819 | 230.2 | Definition of radio resource management functionality |  | 626d? | 2005-04-08 A | 2007-08-31 A | 100% | 2005-04-08 | 2007-08-31 | 626d? |  | finish no earlier than 2007-08-31 | G1 | 5008h | 5008h | SCSAGB-RRM | Gunnar Hedby, Ericsson | gunnar.hedby@ericsson.com | Rel-7 |  | Paolo |  |
| 820 | 230.3 | Support of Conversational Services in A/Gb mode via the PS domain – RLC Non-Persistent mode |  | 101d? | 2006-06-30 A | 2006-11-17 A | 100% | 2006-06-30 | 2006-11-17 | 101d? |  | finish no earlier than 2006-11-17 | G2 | 808h | 808h | SCSAGB-RLCNP | Gunnar Hedby, Ericsson | gunnar.hedby@ericsson.com | Rel-7 |  | Gert |  |
| 821 | 230.4 | Deleted- Radio Channel Support | milestone | 0d? | 2006-07-17 A | 2006-07-17 A | 100% | 2006-07-17 | 2006-07-17 | 0d? |  | start no earlier than 2006-07-17 | G2 |  |  | SCSAGB-RCHS | Gunnar Hedby, Ericsson | gunnar.hedby@ericsson.com | Rel-7 |  | Gert | SP-32 |
| 822 | 230.5 | Deleted- Modifications to FLO | milestone | 0d? | 2006-07-17 A | 2006-07-17 A | 100% | 2006-07-17 | 2006-07-17 | 0d? |  | start no earlier than 2006-07-17 | G2 |  |  | SCSAGB-FLO | Gunnar Hedby, Ericsson | gunnar.hedby@ericsson.com | Rel-7 |  | Gert | SP-32 |
| 823 | 231 | **Addition of new frequency band to GSM (T-GSM810)** |  | 626d? | 2005-04-08 A | 2007-08-31 A | 100% | 2005-04-08 | 2007-08-31 | 626d? |  |  | GP | 12112h | 12112h | TGSM810 | Chen De, Huawei | chende@huawei.com | Rel-7 |  | Paolo |  |
| 824 | 231.1 | Changes to core specification |  | 106d? | 2005-04-08 A | 2005-09-02 A | 100% | 2005-04-08 | 2005-09-02 | 106d? |  | finish no earlier than 2005-09-02 | GP | 848h | 848h | TGSM810-Core | Chen De, Huawei | chende@huawei.com | Rel-7 |  | Paolo |  |
| 825 | 231.2 | Changes to MS testing specification |  | 626d? | 2005-04-08 A | 2007-08-31 A | 100% | 2005-04-08 | 2007-08-31 | 626d? |  | finish no earlier than 2007-08-31 | G3 | 5008h | 5008h | TGSM810-MStest | Chen De, Huawei | chende@huawei.com | Rel-7 |  | Stoyan |  |
| 826 | 231.3 | Changes to BTS testing specification |  | 156d? | 2005-04-08 A | 2005-11-11 A | 100% | 2005-04-08 | 2005-11-11 | 156d? |  | finish no earlier than 2005-11-11 | G1 | 1248h | 1248h | TGSM810-BTStest | Chen De, Huawei | chende@huawei.com | Rel-7 |  | Paolo |  |

Notes:
- 800: Completed Sep 2006, Status Report in RP-060462
- 802: Text3: TS25.201, TS25.221,TS25.222, TS25.223, TS25.224, TS25.225
- 803: Text3: TS25.301, TS25.302, TS25.306, TS25.321, TS25.331
- 804: Text3: TS25.401, TS25.420, TS25.423, TS25.427, TS25.430, TS25.433, TS25.435
- 805: Text3: TS25.102, TS25.105, TS25.123, TS25.142
- 806: Completed May 2007; Status Report in RP-070038 and RP-070296
- 807: Text3: 25.201, 25.221, 25.222, 25.223, 25.224, 25.225
- 808: Text3: 25.301, 25.302, 25.306, 25.321, 25.331
- 809: Text3: 25.401, 25.420, 25.423, 25.425, 25.427, 25.430, 25.433, 25.435
- 810: Text3: 25.102, 25.105, 25.123, 25.142
- 811: UID_350046->350146. 05/08: Linked to Feature UID_20055 (LCRTDD-EDCH). Status Report in RP-080285 / Text3: 34.108, 34.122, 34.123-1/2/3
- 812: GP#36 completed for R7 / Text3: 25.914, 25.144, 45.005
- 813: Text3: 24.008, 43.022, 44.018, 44.118, 45, 001, 45.005, 51.010, 51.021
- 814: Completed / Text3: 24.008, 43.022, 44.018, 44.118, 45, 001, 45.005,
- 815: Text3: 51.021
- 816: Text3: 51.010
- 817: Originally started Nov. 2003 as GP-030443
- 820: Text3: 43.955, 43.064, 44.060, 45.001, 45.002, 45.003, 45.005, 45.010, 51.010, 51.021
- 823: Text3: 45.005, 45.050, 24.008, 45.008, 45.001, 43.022, 43.030, 44.018, 44.060, 51.010-1, 51.021
- 824: Text3: 45.005, 45.050, 24.008, 45.008, 45.001, 43.022, 43.030, 44.018, 44.060
- 825: Text3: 51010-1
- 826: Text3: 51021

| ID | WBS | Task | Duration | Start | Finish | Complete | Remaining | Baseline start | Baseline finish | Baseline duration | Total slack | Constraint | Resources | Work | Actual work | Text1 | Text4 | Text5 | Text6 | Text8 |
| --- | --- | --- | --- | --- | --- | --- | --- | --- | --- | --- | --- | --- | --- | --- | --- | --- | --- | --- | --- | --- |
| 827 | 232 | **Handover of dedicated and shared resources while in dual transfer mode** | 421d? | 2005-04-08 A | 2006-11-17 A | 100% |  | 2005-04-08 | 2006-11-17 | 421d? |  |  | GP | 12672h | 12672h | HODSRDTM | Rami Vaittinen, Nokia | rami.vaittinen@nokia.com | Rel-7 | Paolo |
| 828 | 232.1 | Handover of dedicated and shared resources while in dual transfer mode | 321d? | 2005-04-08 A | 2006-06-30 A | 100% |  | 2005-04-08 | 2006-06-30 | 321d? |  | finish no earlier than 2006-06-30 | G2 | 2568h | 2568h | HODSRDTM-G2 | Rami Vaittinen, Nokia | rami.vaittinen@nokia.com | Rel-7 | Gert |
| 829 | 232.2 | MS Conformance Testing | 421d? | 2005-04-08 A | 2006-11-17 A | 100% |  | 2005-04-08 | 2006-11-17 | 421d? |  | finish no earlier than 2006-11-17 | G3 | 3368h | 3368h | HODSRDTM-Mstest | Rami Vaittinen, Nokia | rami.vaittinen@nokia.com | Rel-7 | Stoyan |
| 830 | 232.3 | BTS conformance testing | 421d? | 2005-04-08 A | 2006-11-17 A | 100% |  | 2005-04-08 | 2006-11-17 | 421d? |  | finish no earlier than 2006-11-17 | G1 | 3368h | 3368h | HODSRDTM-BTStest | Rami Vaittinen, Nokia | rami.vaittinen@nokia.com | Rel-7 | Paolo |
| 831 | 233 | **Mobile Station Receive Diversity (DARP Phase II)** | 526d? | 2005-11-11 A | 2007-11-16 A | 100% |  | 2005-11-11 | 2007-11-16 | 526d? |  |  | GP | 16360h | 16360h | MSRD2 | Kent Pedersen, Nokia Corporation (ETSI) | kent.pedersen@nokia.com | Rel-7 | Paolo |
| 832 | 233.1 | Performance Requirements for Mobile Station Receive Diversity, DARP Phase II | 331d? | 2005-11-11 A | 2007-02-16 A | 100% |  | 2005-11-11 | 2007-02-16 | 331d? |  | finish no earlier than 2007-02-16 | GP | 2648h | 2648h | MSRD2-PerfReq | Kent Pedersen, Nokia Corporation (ETSI) | kent.pedersen@nokia.com | Rel-7 | Paolo |
| 833 | 233.2 | Capability signalling of Mobile Station Receive Diversity, DARP Phase II | 331d? | 2005-11-11 A | 2007-02-16 A | 100% |  | 2005-11-11 | 2007-02-16 | 331d? |  | finish no earlier than 2007-02-16 | GP | 2648h | 2648h | MSRD2-CapSig | Kent Pedersen, Nokia Corporation (ETSI) | kent.pedersen@nokia.com | Rel-7 | Paolo, Gert |
| 834 | 233.3 | Test Scenarios for Mobile Station Receive Diversity, DARP Phase II | 331d? | 2005-11-11 A | 2007-02-16 A | 100% |  | 2005-11-11 | 2007-02-16 | 331d? |  | finish no earlier than 2007-02-16 | GP | 2648h | 2648h | MSRD2-TestSc | Kent Pedersen, Nokia Corporation (ETSI) | kent.pedersen@nokia.com | Rel-7 | Paolo |
| 835 | 233.4 | MS conformance test of DARP Phase II (MSRD) | 526d? | 2005-11-11 A | 2007-11-16 A | 100% |  | 2005-11-11 | 2007-11-16 | 526d? |  | finish no earlier than 2007-11-16 | GP | 4208h | 4208h | MSRD2-Msconf | Kent Pedersen, Nokia Corporation (ETSI) | kent.pedersen@nokia.com | Rel-7 | Paolo, Stoyan |
| 836 | 234 | **Downlink Dual Carrier** | 741d? | 2006-01-20 A | 2008-11-21 | 69% | 226.89d? | 2006-01-20 | 2008-11-21 | 741d? | 285d |  | GP | 16152h | 9890.85h | GDCDL | Nokia Siemens Networks | leonardo.provvedi@roke.co.uk | Rel-7 | Paolo |
| 837 | 234.1 | Downlink Dual Carrier Stage 2 | 116d? | 2006-01-20 A | 2006-06-30 A | 100% |  | 2006-01-20 | 2006-06-30 | 116d? |  | finish no earlier than 2006-06-30 | G1 | 928h | 928h | GDCDL-Stage2 | Nokia Siemens Networks | leonardo.provvedi@roke.co.uk | Rel-7 | Paolo |
| 838 | 234.2 | Downlink Dual Carrier Stage 3 | 421d? | 2006-01-20 A | 2007-08-31 A | 100% |  | 2006-01-20 | 2007-08-31 | 421d? |  | finish no earlier than 2007-08-31 | G1 | 3368h | 3368h | GDCDL-Stage2 | Nokia Siemens Networks | leonardo.provvedi@roke.co.uk | Rel-7 | Paolo |
| 839 | 234.3 | Downlink Dual Carrier – MS Conformance Test | 370.5d? | 2006-01-20 A | 2008-11-21 | 25% | 277.88d? | 2006-01-20 | 2008-11-21 | 370.5d? | 285d | finish no earlier than 2008-11-21 | G2; G1 | 5928h | 1482h | GDCDL-Stage3 | Nokia Siemens Networks | leonardo.provvedi@roke.co.uk | Rel-7 | Ingbert |
| 840 | 235 | Support of SIGTRAN in GERAN | 116d? | 2006-01-20 A | 2006-06-30 A | 100% |  | 2006-01-20 | 2006-06-30 | 116d? |  | finish no earlier than 2006-06-30 | G3new | 928h | 928h | GDCDL-MStest | Peter Ostrup, Ericsson | peter.ostrup@ericsson.com | Rel-7 | Paolo |
| 841 | 236 | **Latency Reductions** | 306d? | 2006-06-30 A | 2007-08-31 A | 100% |  | 2006-06-30 | 2007-08-31 | 306d? |  |  | GP | 7344h | 7344h | LATRED | Håkan Persson, Ericsson | Hakan.Persson@Ericsson.com | Rel-7 | Paolo |
| 842 | 236.1 | Improved Ack/Nack reporting | 306d? | 2006-06-30 A | 2007-08-31 A | 100% |  | 2006-06-30 | 2007-08-31 | 306d? |  | finish no earlier than 2007-08-31 | G2 | 2448h | 2448h | LATRED-ACKNAR | Håkan Persson, Ericsson | Hakan.Persson@Ericsson.com | Rel-7 | Gert |
| 843 | 236.2 | Reduced TTI | 306d? | 2006-06-30 A | 2007-08-31 A | 100% |  | 2006-06-30 | 2007-08-31 | 306d? |  | finish no earlier than 2007-08-31 | G2 | 2448h | 2448h | LATRED-REDTTI | Håkan Persson, Ericsson | Hakan.Persson@Ericsson.com | Rel-7 | Gert |
| 844 | 237 | PS Handover between GERAN/UTRAN mode and GAN Mode | 166d? | 2006-06-30 A | 2007-02-16 A | 100% |  | 2006-06-30 | 2007-02-16 | 166d? |  | finish no earlier than 2007-02-16 | G2 | 1328h | 1328h | GUGAN | John Diachina, Ericsson | John.Diachina@Ericsson.com | Rel-7 | Gert |
| 845 | 238 | **Higher Uplink performance for GERAN Evolution** | 641d? | 2006-09-08 A | 2009-02-20 | 71% | 184.24d? | 2006-09-08 | 2009-02-20 | 641d? | 220d |  | GP | 26176h | 15149h | HUGE | NSN, Ericsson | eddie.riddington@nokia.com, stefan.g.eriksson@ericsson.com | Rel-7 | Paolo |
| 846 | 238.1 | Stage 2 of HUGE | 261d? | 2006-09-08 A | 2007-09-07 A | 100% |  | 2006-09-08 | 2007-09-07 | 261d? |  | finish no earlier than 2007-09-07 | G1 | 2088h | 2088h | HUGE-Stage2 | NSN, Ericsson | eddie.riddington@nokia.com, stefan.g.eriksson@ericsson.com | Rel-7 | Paolo |
| 847 | 238.2 | Layer 1 Support of HUGE | 381d? | 2006-09-08 A | 2008-02-22 A | 100% |  | 2006-09-08 | 2008-02-22 | 381d? |  | finish no earlier than 2008-02-22 | G1 | 3048h | 3048h | HUGE-Layer1 | NSN, Ericsson | eddie.riddington@nokia.com, stefan.g.eriksson@ericsson.com | Rel-7 | Paolo |
| 848 | 238.3 | Layer 2/3 Support of HUGE | 256d? | 2006-09-08 A | 2007-08-31 A | 100% |  | 2006-09-08 | 2007-08-31 | 256d? |  | finish no earlier than 2007-08-31 | G2 | 2048h | 2048h | HUGE-Layer23 | NSN, Ericsson | eddie.riddington@nokia.com, stefan.g.eriksson@ericsson.com | Rel-7 | Gert |
| 849 | 238.4 | Performance requirements | 516d? | 2006-09-08 A | 2008-08-29 A | 100% |  | 2006-09-08 | 2008-08-29 | 516d? |  | finish no earlier than 2008-08-29 | G1 | 4128h | 4128h | HUGE-Perfreq | NSN, Ericsson | eddie.riddington@nokia.com, stefan.g.eriksson@ericsson.com | Rel-7 | Paolo |
| 850 | 238.5 | MS Conformance Test | 641d? | 2006-09-08 | 2009-02-20 |  |  | 2006-09-08 | 2009-02-20 | 641d? | 220d | finish no earlier than 2009-02-20 | G3new | 5128h |  | HUGE-Mstest | NSN, Ericsson | eddie.riddington@nokia.com, stefan.g.eriksson@ericsson.com | Rel-7 | Ingbert |
| 851 | 238.6 | BTS Conformance Test | 576d? | 2006-09-08 A | 2008-11-21 | 80% | 115.2d? | 2006-09-08 | 2008-11-21 | 576d? | 285d | finish no earlier than 2008-11-21 | G1 | 4608h | 3686.4h | HUGE-BTStest | NSN, Ericsson | eddie.riddington@nokia.com, stefan.g.eriksson@ericsson.com | Rel-7 | Paolo |

Notes:
- 827: Started at GERAN#24
- 828: Started at GERAN#24 / Text3: 43.055, 44.018, 44.060
- 829: Stopped, no work done / Text3: 51-010
- 830: Stopped, no work done / Text3: 51.026
- 831: GP#37 completed. / Text3: 24.008, 45.005, 51.010
- 832: Text3: 45.005
- 833: Text3: 24.008
- 834: Text3: 45.005
- 835: Text3: 51.010
- 836: GP#30 completed / Text3: 24.008, 43.055, 43.064, 44.018, 44.060, 45.001, 45.002, 45.005, 45.008, 51.010
- 837: GP#35 completed / Text3: 43.055, 43.064
- 838: Text3: 24.008, 44.018, 44.060, 45.001, 45.002, 45.005, 45.008
- 839: Text3: 51.010
- 840: Text3: 48.001, 48.006, 43.059, 49.031
- 841: Text3: 45.001, 45.002, 45.003, 45.005, 45.010, 43.055, 43.064, 44.060, 51.010-1, 51.021
- 842: Text3: 45.001, 45.002, 45.003, 45.005, 45.010, 43.055, 43.064, 44.060, 51.010-1, 51.021
- 843: Text3: 45.001, 45.002, 45.003, 45.005, 45.010, 43.055, 43.064, 44.060, 51.010-1, 51.021
- 844: Text3: 43.318, 44.318, 43.129, 25.306, 24.008, 44.060, 25.331, 51.010
- 845: Exception sheet in GP-071567 / Text3: 24.008, 43.055, 43.064, 44.018, 44.060, 45.001, 45.002, 45.003, 45.004, 45.005, 45.008, 45.010, 51.010, 51.021
- 846: GP#35 completed / Text3: 43.055, 43.064
- 847: GP#37 completed / Text3: 45.001, 45.002, 45.003, 45.004, 45.008
- 848: GP#35 completed / Text3: 24.008, 44.018, 44.060
- 849: GP#39 completed / Text3: 45.005
- 850: 05/08=>02/09 / Text3: 51.010
- 851: 05/08=>11/08 / Text3: 51.021

| ID | WBS | Task | Type | Duration | Start | Finish | Complete | Remaining | Baseline start | Baseline finish | Baseline duration | Total slack | Constraint | Resources | Work | Actual work | Text1 | Text4 | Text5 | Text6 | Text8 | Text12 | Text7 |
| --- | --- | --- | --- | --- | --- | --- | --- | --- | --- | --- | --- | --- | --- | --- | --- | --- | --- | --- | --- | --- | --- | --- | --- |
| 852 | 239 | **REduced symbol Duration, Higher Order modulation and Turbo coding (RED HOT) for downlink** |  | 591d? | 2006-11-17 A | 2009-02-20 | 61% | 230.99d? | 2006-11-17 | 2009-02-20 | 591d? | 220d |  | GP | 18440h | 8408.27h | REDHOT | Ericsson, NSN, Marvell | stefan.g.eriksson@ericsson.com | Rel-7 | Paolo |  |  |
| 853 | 239.1 | Stage 2 for REDHOT |  | 206d? | 2006-11-17 A | 2007-08-31 A | 100% |  | 2006-11-17 | 2007-08-31 | 206d? |  | finish no earlier than 2007-08-31 | G1 | 1648h | 1648h | REDHOT-Stage2 | Ericsson, NSN, Marvell | stefan.g.eriksson@ericsson.com | Rel-7 | Paolo |  |  |
| 854 | 239.2 | Stage 3 for REDHOT |  | 391d? | 2006-11-17 A | 2008-05-16 A | 100% |  | 2006-11-17 | 2008-05-16 | 391d? |  | finish no earlier than 2008-05-16 | G1 | 3128h | 3128h | REDHOT-Stage3 | Ericsson, NSN, Marvell | stefan.g.eriksson@ericsson.com | Rel-7 | Paolo |  |  |
| 855 | 239.3 | MS Conformance Tests |  | 591d? | 2006-11-17 | 2009-02-20 |  |  | 2006-11-17 | 2009-02-20 | 591d? | 220d | finish no earlier than 2009-02-20 | G3new | 4728h |  | REDHOT-Mstest | Ericsson | stefan.g.eriksson@ericsson.com | Rel-7 | Ingbert |  |  |
| 856 | 239.4 | BTS Conformance Tests |  | 526d? | 2006-11-17 A | 2008-11-21 | 85% | 78.9d? | 2006-11-17 | 2008-11-21 | 526d? | 285d | finish no earlier than 2008-11-21 | G1 | 4208h | 3576.8h | REDHOT-BTStest | Ericsson, NSN, Marvell | stefan.g.eriksson@ericsson.com | Rel-7 | Paolo |  |  |
| 857 | 240 | (Small) Technical Enhancements and Improvements for Rel-7 | milestone | 0d? | 2007-03-26 A | 2007-03-26 A | 100% |  | 2007-03-26 | 2007-03-26 | 0d? |  | start no earlier than 2007-03-26 | All |  |  | TEI7 |  |  | Rel-7 |  |  |  |
| 858 | 241 | **Deleted - PS domain and IMS support for IMS Emergency sessions** |  | 63.69d? | 2006-06-23 A | 2006-09-21 A | 100% |  | 2006-06-23 | 2006-09-21 | 63.69d? |  |  | S2 |  |  | IMS-EMER | Curt Wong (Nokia) | curt.c.wong@nokia.com | Rel-7 | Maurice | SP-30 |  |
| 859 | 241.1 | Deleted - IMS aspects to support IMS Emergency sessions | milestone | 0d? | 2006-06-23 A | 2006-09-21 A | 100% |  | 2006-06-23 | 2006-09-21 | 0d? |  | start no earlier than 2006-06-23 | S2 |  |  | IMS-EMER | Curt Wong (Nokia) | curt.c.wong@nokia.com | Rel-7 | Maurice | SP-30 | TSG |
| 860 | 241.2 | Deleted - PS domain aspects to support IMS Emergency sessions | milestone | 0d? | 2006-06-23 A | 2006-09-21 A | 100% |  | 2006-06-23 | 2006-09-21 | 0d? |  | start no earlier than 2006-06-23 | S2 |  |  | IMS-EMER | Curt Wong (Nokia) | curt.c.wong@nokia.com | Rel-7 | Maurice | SP-30 | TSG |
| 861 | 242 | Deleted - Covered by SI - Personal Network (PN) and Personal Area Network (PAN) | milestone | 0d? | 2005-12-08 A | 2005-12-20 A | 100% |  | 2005-12-08 | 2005-12-20 | 0d? |  | start no earlier than 2005-12-08 | S1 |  |  | PNPAN | Armin Toepfer, Vodafone | armin.toepfer@vodafone.com | Rel-7 | Mike | SP-30 |  |
| 862 | 243 | Deleted - Covered by SI - Multimedia Telephony Capabilities for IMS | milestone | 0d? | 2005-12-08 A | 2005-12-20 A | 100% |  | 2005-12-08 | 2005-12-20 | 0d? |  | start no earlier than 2005-12-08 | S1 |  |  | MITE | Peter Bleckert, Ericsson | peter.bleckert @ericsson.com | Rel-7 | Mike | SP-30 |  |
| 863 | 244 | Deleted - Covered by SI - Transferring of emergency Call data | milestone | 0d? | 2005-12-08 A | 2005-12-08 A | 100% |  | 2005-12-08 | 2005-12-08 | 0d? |  | start no earlier than 2005-12-08 | S1 |  |  | eCALL | Steve Vardy, (Motorola S.A.S) | steven.vardy@motorola.com | Rel-7 | Mike | SP-30 |  |
| 864 | 245 | Deleted - Covered by SI - MBMS Enhancements | milestone | 0d? | 2005-12-08 A | 2005-12-08 A | 100% |  | 2005-12-08 | 2005-12-08 | 0d? |  | start no earlier than 2005-12-08 | S1 |  |  | MBMSE | Liu Hong, China Mobile | liuhongyfw@chinamobile.com | Rel-7 | Mike | SP-30 |  |
| 865 | 246 | **Deleted - VoIMS bearer related enhancements** |  | 0d? | 2006-07-21 A | 2006-07-21 A | 100% |  | 2006-07-21 | 2006-07-21 | 0d? |  |  | S2 |  |  | VoIMS |  |  | Rel-7 | Maurice | SP-32 |  |
| 866 | 246.1 | Deleted - FS on enhancement of radio performance for VoIMS | milestone | 0d? | 2006-07-21 A | 2006-07-21 A | 100% |  | 2006-07-21 | 2006-07-21 | 0d? |  | start no earlier than 2006-07-21 | S2 |  |  | VoIMS | Laurence Lautier, Nortel Networks | lautierl@nortel.com | Rel-7 | Maurice | SP-32 |  |
| 867 | 247 | Release 7 Feasibility Studies |  | 1d? | 2000-01-03 | 2000-01-03 |  |  | 2000-01-03 | 2000-01-03 | 1d? | 2604d |  | CP,GP, RP,SP | 8h |  |  |  |  | Rel-7 |  |  |  |
| 868 | 248 | **Study on Multimedia Telephony Capabilities for IMS** |  | 276d? | 2005-07-11 A | 2006-07-31 A | 100% |  | 2005-07-11 | 2006-07-31 | 276d? |  |  | S1 | 4353.6h | 4353.6h | MITE | Ericsson | peter.bleckert @ericsson.com | Rel-7 | Alain |  |  |
| 869 | 248.1 | Deleted covered by UID_31082 - Study of (MITe) - IMS Multimedia Telephony Communication Enabler and supplementary services |  | 276d? | 2005-07-11 A | 2006-07-31 A | 100% |  | 2005-07-11 | 2006-07-31 | 276d? |  | start no earlier than 2005-07-11 | S1 | 2208h | 2208h | MITE | Ericsson | peter.bleckert @ericsson.com | Rel-7 | Alain | SP-28 |  |
| 870 | 249 | Study on Behaviour of Multi system UEs |  | 384d? | 2004-06-28 A | 2005-12-15 A | 100% |  | 2004-06-28 | 2005-12-15 | 384d? |  | start no earlier than 2004-06-28 | S1 | 3072h | 3072h | BMSU | Qualcomm | dwilliams@qualcomm.com | Rel-7 | Alain |  | TSG |
| 871 | 250 | Study on Combining CS calls and IMS sessions |  | 189d? | 2004-06-28 A | 2005-03-17 A | 100% |  | 2004-06-28 | 2005-03-17 | 189d? |  | start no earlier than 2004-06-28 | S1 | 1512h | 1512h | IRTSD-CS_IMS |  | FRANK, Robert | Rel-7 | Alain |  | TSG |
| 872 | 251 | Study on All-IP Network |  | 188d? | 2004-06-28 A | 2005-03-16 A | 100% |  | 2004-06-28 | 2005-03-16 | 188d? |  | start no earlier than 2004-06-28 | S1 | 1504h | 1504h | FS_AIPN | NTT DoCoMo | c.masyu@nttdocomo.co.jp | Rel-7 | Alain |  | TSG |
| 873 | 252 | Study on Videotelephony teleservice |  | 231d? | 2005-03-01 A | 2006-01-17 A | 100% |  | 2005-03-01 | 2006-01-17 | 231d? |  |  | S1 | 1848h | 1848h | VidTel | T-Mobile | kurt.bischinger@t-mobile.at | Rel-7 | Alain |  | TSG |
| 874 | 253 | Study on Network Selection Principles |  | 193d? | 2005-03-15 A | 2005-12-08 A | 100% |  | 2005-03-15 | 2005-12-08 | 193d? |  |  | S1 | 1544h | 1544h | NetSel | O2 | chris.friel@o2.com | Rel-7 | Alain |  | TSG |
| 875 | 254 | Study on Multimedia Priority Service |  | 851d? | 2003-03-28 A | 2006-06-30 A | 100% |  | 2003-03-28 | 2006-06-30 | 851d? |  | finish no earlier than 2005-12-16 | S1 | 6808h | 6808h | PRIOR-MM | Telcordia | jgarraha@telcordia.com | Rel-7 | Alain |  |  |
| 876 | 255 | Study on Transferring of emergency Call data |  | 190d? | 2005-07-11 A | 2006-03-31 A | 100% |  | 2005-07-11 | 2006-03-31 | 190d? |  | finish no earlier than 2005-12-08 | S1 | 1520h | 1520h | eCALL | Motorola | steven.vardy@motorola.com | Rel-7 | Mike |  |  |
| 877 | 256 | Study on Enhancement of E2E QoS |  | 281.4d? | 2004-06-28 A | 2005-09-15 A | 100% |  | 2004-06-28 | 2005-09-15 | 281.4d? |  | finish no earlier than 2005-12-01 | S2 | 2251.2h | 2251.2h | QoS7 | Huawei | Robert Jaksa | Rel-7 | Maurice |  | TSG |
| 878 | 257 | Study on Bandwidth Saving at Nb Interface with IP transport |  | 261d? | 2006-03-10 A | 2007-03-09 A | 100% |  | 2006-03-10 | 2007-03-09 | 261d? |  | finish no earlier than 2007-03-09 | C3 | 2088h | 2088h | BSNbIP | Siemens | thomas.belling@siemens.com | Rel-7 | Seung Don |  |  |
| 879 | 258 | Study on Routeing of MT-SMs via the HPLMN |  | 301d? | 2005-10-07 A | 2006-12-01 A | 100% |  | 2005-10-07 | 2006-12-01 | 301d? |  | finish no earlier than 2006-12-01 | C4 | 2408h | 2408h | SMS7 | Vodafone | Nick.Russell@vodafone.com | Rel-7 | Kimmo |  |  |
| 880 | 259 | Study on the TCAPsec Gateway concept |  | 96d? | 2005-10-28 A | 2006-03-10 A | 100% |  | 2005-10-28 | 2006-03-10 | 96d? |  | finish no earlier than 2006-03-10 | C4 | 768h | 768h | SEC7-TCAP | Siemens | Ulrich.wiehe@gksag.de | Rel-7 | Kimmo |  |  |
| 881 | 260 | Study on using M2PA in 3GPP network |  | 318d? | 2006-03-22 A | 2007-06-08 A | 100% |  | 2006-03-22 | 2007-06-08 | 318d? |  | finish no earlier than 2007-06-08 | C4 | 2544h | 2544h | FS-M2PA | China Mobile | zhaoyuyi@chinamobile.com | Rel-7 | Kimmo |  |  |

Notes:
- 852: Exception sheet in GP-071565 / Text3: 24.008, 43.064, 43.055, 44.018, 44.060, 45.001, 45.002, 45.003, 45.004, 45.005, 45.008, 51.010, 51.021
- 853: GP#35 completed / Text3: 43.055, 43.064
- 854: GP#38 completed / Text3: 24.008, 44.018, 44.060, 45.001, 45.002, 45.003, 45.004, 45.005, 45.008
- 855: 08/08=>02/09 / Text3: 51.010
- 856: 05/08=>11/08 / Text3: 51.021
- 857: Text3: CP-070260
- 858: Approved at SP#29 / Text3: 23.867, TS 23.abc, 23.060, 23.002, 23.271
- 859: Approved at SP#29 / Text3: 23.867, TS 23.abc, 23.060, 23.002, 23.271
- 860: Approved at SP#29 / Text3: 23.867, TS 23.abc, 23.060, 23.002, 23.271
- 865: Created by MCC to group all VoIMS related items, after consultation of chairs
- 866: WID approved SA#28: SA2#52: CLOSED - To be removed from the work plan / Text3: 23.807
- 868: Spin-off Feature UID_7038 (MTSI) / Text3: 22.973
- 869: Duplicate entry with 31082 / Text3: 22.973
- 870: Text3: 22.936
- 871: Text3: 22.979
- 872: 25/07/08 Moved as FS to Rel-7 out of the stopped Rel-8 Feature UID_31067 Deleted - All-IP Network (AIPN) / Text3: 22.978
- 873: Text3: 22.903
- 874: Spin-off Feature Network selection enhancements (NSP-CR) UID_7041 / Text3: 22.811
- 875: Spin-off Feature PRIOR UID_340044 / Text3: 22.953
- 876: Text3: 22.967
- 877: Text3: 23.802
- 878: Moved to FS at CT32 (in line with slides) / Text3: 29.814
- 879: Previously known as "Study of a SMS Centre for MT SMS" / Text3: 23.840
- 880: TR 29.800 content moved to TS 29.204 under implementation WI UID_310005 TCAPsec Gateway / Text3: 29.800
- 881: Text3: 29.801

| ID | WBS | Task | Type | Duration | Start | Finish | Complete | Baseline start | Baseline finish | Baseline duration | Total slack | Constraint | Resources | Work | Actual work | Text1 | Text3 | Text4 | Text5 | Text6 | Text8 | Text7 | Text12 |
| --- | --- | --- | --- | --- | --- | --- | --- | --- | --- | --- | --- | --- | --- | --- | --- | --- | --- | --- | --- | --- | --- | --- | --- |
| 882 | 261 | **Study on Support of (G)MSC-S - (G)MSC-S Nc Interface based on the SIP-I protocol** |  | 350d? | 2006-05-15 A | 2007-09-14 A | 100% | 2006-05-15 | 2007-09-14 | 350d? |  |  | C4 | 7800h | 7800h | NcSIP | 29.802 | Vodafone | david.hutton@vodafone.com | Rel-7 | Kimmo |  |  |
| 883 | 261.1 | CT4 aspects of NcSIP |  | 275d? | 2006-05-15 A | 2007-06-01 A | 100% | 2006-05-15 | 2007-06-01 | 275d? |  | finish no earlier than 2007-06-01 | C4 | 2200h | 2200h | NcSIP | 29.802 | Vodafone | david.hutton@vodafone.com | Rel-7 | Kimmo |  |  |
| 884 | 261.2 | CT3 aspects of NcSIP |  | 350d? | 2006-05-15 A | 2007-09-14 A | 100% | 2006-05-15 | 2007-09-14 | 350d? |  | finish no earlier than 2007-09-14 | C3 | 2800h | 2800h | NcSIP | 29.802 | Ericsson | ragnar.huslende@ericsson.com | Rel-7 |  |  |  |
| 885 | 262 | Study on SOAP/HTTP IRP Solution Sets |  | 330d? | 2005-09-02 A | 2006-12-07 A | 100% | 2005-09-02 | 2006-12-07 | 330d? |  | finish no earlier than 2006-12-07 | S5 | 2640h | 2640h | OAM7-NIM-XML ( | 32.809 | Nortel |  | Rel-7 | Adrian |  |  |
| 886 | 263 | Study on Itf-N Implementation Conformance Statement (ICS) template |  | 400d? | 2005-09-02 A | 2007-03-15 A | 100% | 2005-09-02 | 2007-03-15 | 400d? |  | finish no earlier than 2007-03-15 | S5 | 3200h | 3200h | OAM7-NIM-ICS | 32.812 | China Mobile |  | Rel-7 | Adrian |  |  |
| 887 | 264 | Study on IRP Information Model |  | 400d? | 2005-09-02 A | 2007-03-15 A | 100% | 2005-09-02 | 2007-03-15 | 400d? |  | finish no earlier than 2007-03-15 | S5 | 3200h | 3200h | OAM7-NIM-IM | 32.810 | Motorola |  | Rel-7 | Adrian |  |  |
| 888 | 265 | Study on Evolved UTRA and UTRAN |  | 458d? | 2004-12-15 A | 2006-09-15 A | 100% | 2004-12-15 | 2006-09-15 | 458d? |  | finish no earlier than 2006-09-15 | RP | 3664h | 3664h | RANFS-Evo | 25.912 | NTT DoCoMo | nakamurata@NTTDOCOMO.CO.JP | Rel-7 | Juergen | TSG |  |
| 889 | 266 | Study on Performance Evaluation of the UE behaviour in high speed trains with speeds up to 350 kmph |  | 328d? | 2005-03-15 A | 2006-06-15 A | 100% | 2005-03-15 | 2006-06-15 | 328d? |  | finish no earlier than 2006-06-15 | R4 | 2624h | 2624h | RANFS-HSTrains | none | Vodafone | Mike.vogel@vodafone.com,tim.frost@vodafone.com | Rel-7 | Stefania | TSG |  |
| 890 | 267 | Study on UTRA Tower Mounted Amplifier (FDD) |  | 195d? | 2005-06-15 A | 2006-03-14 A | 100% | 2005-06-15 | 2006-03-14 | 195d? |  | finish no earlier than 2006-03-15 | R4 | 1560h | 1560h | RANFS-TMA | 25.818 | Klas Sjerling | Klas.Sjerling@ericsson.com | Rel-7 | Stefania | TSG |  |
| 891 | 268 | Study on Continuous connectivity for packet data users |  | 132d? | 2005-03-15 A | 2005-09-15 A | 100% | 2005-03-15 | 2005-09-15 | 132d? |  | finish no earlier than 2005-09-15 | R1 | 1056h | 1056h | RANFS-cont-packet | none | Siemens | joerg.gustrau@siemens.com | Rel-7 | Patrick | TSG |  |
| 892 | 269 | Study on Improvement of the Multimedia Broadcast Multicast Service (MBMS) in UTRAN |  | 262d? | 2005-12-15 A | 2006-12-15 A | 100% | 2005-12-15 | 2006-12-15 | 262d? |  | finish no earlier than 2006-12-15 | R2 | 2096h | 2096h | RANFS-MBMSImp | 25.905 | LG Electronics | leego@lge.com | Rel-7 | Joern |  |  |
| 893 | 270 | Study on Performance Improvements in Small Cells using HSDPA/EDCH |  | 131d? | 2005-12-15 A | 2006-06-15 A | 100% | 2005-12-15 | 2006-06-15 | 131d? |  | finish no earlier than 2006-06-15 | R4 | 1048h | 1048h | SMALLCELLS | none | Cingular | marc.grant@cingular.com | Rel-7 | Stefania |  |  |
| 894 | 271 | Study on Further Improved Performance Requirements for UMTS/HSDPA UE (FDD) |  | 383d? | 2005-12-15 A | 2007-06-04 A | 100% | 2005-12-15 | 2007-06-04 | 383d? |  | finish no earlier than 2007-06-04 | R4 | 3064h | 3064h | RANFS-IC | 25.963 | Cingular | marc.grant@cingular.com | Rel-7 | Stefania |  |  |
| 895 | 272 | Study on Scope of future FDD HSPA Evolution |  | 394d? | 2006-03-15 A | 2007-09-17 A | 100% | 2006-03-15 | 2007-09-17 | 394d? |  | finish no earlier than 2007-09-17 | RP | 3152h | 3152h | RANFS-HSPAEvo | 25.999 | Cingular | don.zelmer@cingular.com | Rel-7 | Juergen |  |  |
| 896 | 273 | Study on Dynamically reconfiguring a FDD UE receiver to reduce power consumption when desired Quality of Service is met | milestone | 0d? | 2007-06-22 A | 2007-06-22 A | 100% | 2007-06-22 | 2007-06-22 | 0d? |  |  | R4 |  |  | FSUEPow | 25.906 | Nokia | Chris.callender@nokia.com, tiina.s.koskinen@nokia.com | Rel-7 | Stefania |  |  |
| 897 | 274 | Study on Future GERAN Evolution |  | 486d? | 2005-04-08 A | 2007-02-16 A | 100% | 2005-04-08 | 2007-02-16 | 486d? |  | finish no earlier than 2007-02-16 | GP | 3888h | 3888h | FGE | 45.912 | Nokia | eddie.riddington@nokia.com | Rel-7 | Paolo |  |  |
| 898 | 275 | Study on GAN Enhancements | milestone | 0d? | 2007-08-31 A | 2007-08-31 A | 100% | 2007-08-31 | 2007-08-31 | 0d? |  | start no earlier than 2007-08-31 | GP |  |  | EGAN | 43.902 | Janne Linkola (T-Mobile) | janne.linkola@t-mobile.com | Rel-7 | Paolo |  |  |
| 899 | 276 | Deleted - covered by UID33027 - IMS security extensions | milestone | 0d? | 2005-12-08 A | 2005-12-08 A | 100% | 2005-12-08 | 2005-12-08 | 0d? |  | start no earlier than 2005-12-08 | S3 |  |  | IMS-SE |  | Ericsson | Bengt.Sahlin@ericsson.com | Rel-7 | Mike |  | SP-30 |
| 900 | 277 | Deleted - covered by 32108 - Study of work on an LCS architecture for I-WLAN | milestone | 0d? | 2006-12-08 A | 2006-12-08 A | 100% | 2006-12-08 | 2006-12-08 | 0d? |  | start no earlier than 2006-12-08 | S2 |  |  | IMS-SE |  | Donghee Shim (LG Electronics Inc.) | dhshim@lge.com ; phede@lge.com | Rel-7 | Maurice |  | SP-33 |
| 901 | 278 | **Deleted: Study on applicability of GALILEO for LCS** |  | 0d? | 2005-06-30 A | 2005-06-30 A | 100% | 2005-06-30 | 2005-06-30 | 0d? |  |  | S2 |  |  | Galileo |  |  |  | Rel-7 |  |  | SP-25 |
| 902 | 278.1 | Deleted - TR on Stage 2 | milestone | 0d? | 2005-06-30 A | 2005-06-30 A | 100% | 2005-06-30 | 2005-06-30 | 0d? |  | finish no earlier than 2005-06-30 | S2 |  |  | Galileo |  |  |  | Rel-7 |  |  | SP-25 |
| 903 | 278.2 | Deleted - GERAN review of the TR | milestone | 0d? | 2005-06-30 A | 2005-06-30 A | 100% | 2005-06-30 | 2005-06-30 | 0d? |  | start no earlier than 2005-06-30 | GP |  |  | Galileo |  |  |  | Rel-7 |  |  | SP-26 |
| 904 | 16.7 | **Deleted - IMS Local services** |  | 0d? | 2006-01-06 A | 2006-01-06 A | 100% | 2006-01-06 | 2006-01-06 | 0d? |  |  | S2 |  |  | IMSLocal | 23.228 |  |  | Rel-7 |  |  | SP-28 |
| 905 | 16.7.1 | Deleted - Stage 2 | milestone | 0d | 2006-01-06 A | 2006-01-06 A | 100% | 2006-01-06 | 2006-01-06 | 0d |  | start no earlier than 2006-01-06 | S2 |  |  | IMSLocal |  |  |  | Rel-7 |  |  | SP-26 |
| 906 | 279.2 | Deleted - Stage 3 for IMS Local services | milestone | 0d? | 2006-01-06 A | 2006-01-06 A | 100% | 2006-01-06 | 2006-01-06 | 0d? |  | finish no earlier than 2006-01-06 | C1 |  |  | IMSLocal |  | Keith Drage, Lucent | drage@lucent.com | Rel-7 |  |  | SP-25 |
| 907 | 280 | Deleted - IMS Phase 3 | milestone | 0d? | 2006-01-06 A | 2006-01-06 A | 100% | 2006-01-06 | 2006-01-06 | 0d? |  | start no earlier than 2006-01-06 | S2 |  |  |  |  |  |  | Rel-7 |  |  | SP-25 |
| 908 | 281 | Deleted - Improvements of Radio Interface | milestone | 0d? | 2004-09-15 A | 2004-09-15 A | 100% | 2004-09-15 | 2004-09-15 | 0d? |  | start no earlier than 2004-09-15 | RP |  |  | RInImp |  |  | Rel-7 | Rel-7 | Claude | TSG | SP-24 |
| 909 | 282 | Deleted: Generic User Profile Phase 2 | milestone | 0d | 2005-08-08 A | 2006-06-30 A | 100% | 2005-08-08 | 2006-06-30 | 0d |  |  | C4 |  |  |  |  |  |  | Rel-7 | Gaby |  | SP-27 |
| 910 | 30.4 | Deleted - Stage 3 - Common objects | milestone | 0d | 2005-08-08 A | 2006-06-30 A | 100% | 2005-08-08 | 2006-06-30 | 0d |  | finish no earlier than 2006-06-30 | C4 |  |  |  | 24.241 |  |  | Rel-7 | Gaby | TSG | SP-27 |
| 911 | 284 | Delete was duplicated- Study of Customised Alerting Tone (CAT) Requirements | milestone | 0d? | 2006-06-30 A | 2006-06-30 A | 100% | 2006-06-30 | 2006-06-30 | 0d? |  | start no earlier than 2006-06-30 | S1 |  |  | CAT |  |  |  | Rel-7 |  |  | SP-31 |
| 912 | 285 | Deleted - FS of enhanced support of Video Telephony | milestone | 0d? | 2006-06-30 A | 2006-06-30 A | 100% | 2006-06-30 | 2006-06-30 | 0d? |  | start no earlier than 2006-06-30 | GP |  |  | VIDGER |  | Stefan Eriksson, Ericsson | stefan.g.eriksson@ericsson.com | Rel-7 | Paolo | TSG | SP-32 |
| 913 | 286 | Deleted (moved to Rel8) - Study on Transferring of emergency call data – in-band modem solution | milestone | 0d? | 2007-06-22 A | 2007-06-22 A | 100% | 2007-06-22 | 2007-06-22 | 0d? |  | start no earlier than 2007-06-22 | S4 |  |  | eCALLIBMS | 26.967 | Airbiquity | lhong@airbiquity.com | Rel-7 | Paolo |  | SP-38 |
| 914 | 287 | Deleted - covered by UID 20053 - Study on Interference Cancellation for UTRA FDD UE |  | 1d? | 2007-03-28 A | 2007-03-28 A | 100% | 2007-03-28 | 2007-03-28 | 1d? |  | start no earlier than 2007-03-28 | R4 | 8h | 8h | RANFS-InterfCanc |  |  |  | Rel-7 |  |  | SP-38 |
| 915 | 288 | Deleted - Study of Personal Network and Personal Area Network | milestone | 0d? | 2006-10-20 A | 2006-10-20 A | 100% | 2006-10-20 | 2006-10-20 | 0d? |  | finish no earlier than 2006-10-20 | S1 |  |  | PNPAN |  |  |  | Rel-7 |  |  | SP-31 |
| 916 | 289 | Deleted - Study on IMS with real time services deployment |  | 316d? | 2004-06-28 A | 2005-09-12 A | 100% | 2004-06-28 | 2005-09-12 | 316d? |  |  | S1 | 2528h | 2528h | IRTSD |  |  |  | Rel-7 | Alain | TSG | SP-30 |
| 917 | 290 | Deleted - Study on Stage 2 (IMS services using CS bearers) |  | 316d? | 2004-06-28 A | 2005-09-12 A | 100% | 2004-06-28 | 2005-09-12 | 316d? |  | finish no earlier than 2005-09-12 | S2 | 2528h | 2528h | IRTSD-IMSCS | 23.899 | Nortel | Mark Watson | Rel-7 | Maurice | TSG | SP-30 |
| 918 | 291 | Deleted - Study on IMS enhancements and optimisations for real time communication. |  | 430d? | 2005-10-10 A | 2007-06-01 A | 100% | 2005-10-10 | 2007-06-01 | 430d? |  | finish no earlier than 2007-06-01 | S2 | 3440h | 3440h | IMS-RT | 23.818 | Stephen Terrill (Ericsson) | stephen.terrill@ericsson.com | Rel-7 | Maurice |  | SP-35 |
| 919 | 292 | Deleted - Study on Terminating Session handling |  | 255d? | 2006-01-09 A | 2006-12-29 A | 100% | 2006-01-09 | 2006-12-29 | 255d? |  | finish no earlier than 2006-12-29 | S2 | 2040h | 2040h | CSIterm | 23.819 | Samsung | osok.song@samsung.com | Rel-7 | Maurice |  | SP-32 |
| 920 | 293 | Deleted - Study on IRP usage scenarios |  | 330d? | 2005-09-02 A | 2006-12-07 A | 100% | 2005-09-02 | 2006-12-07 | 330d? |  | finish no earlier than 2006-12-07 | S5 | 2640h | 2640h | OAM-Study | 32.8xy | Lucent |  | Rel-7 | Adrian |  | SP-32 |
| 921 | 294 | Release 6 Features |  | 1d? | 2000-01-03 | 2000-01-03 |  | 2000-01-03 | 2000-01-03 | 1d? | 2604d |  | CP,GP, RP,SP,TP | 8h |  |  |  |  |  | Rel-6 |  |  |  |

Notes:
- 885: SP#34 completed
- 886: SP#35 completed
- 887: SP#35 completed
- 888: RAN#33 (Sep 2006) completed. Status Report in RP-060472
- 889: RAN#32 (Jun 2006) completed. Status Report in RP-060412
- 890: RAN#31 (Mar 2006) completed. Status Report in RP-060035
- 891: RAN#29 (Sep 2006) completed. Status report in RP-050427
- 892: RAN#34 (Dec 2006) completed. Status Report in RP-060692
- 893: RAN#32 (Jun 2006) closed (no progress). Status Report in RP-060263
- 894: RAN#36 (May 2007) completed. Status Report in RP-070499
- 895: RAN#37 (Sep 2007) completed. Status Report in RP-070533
- 896: RAN#37 (Sep 2007) completed. Status Report in RP-070534
- 898: GP#35 completed
- 900: S2#52: Entry created
- 905: DAB - Not yet required in SA2 as it exists in previous releases
- 908: Stage 2 description of Interim conclusion
- 909: Created at TSG#27 by A. Sultan because of the move to Rel-7 of "Common Objects".
- 910: No progress in CN4#26. This have to be moved to Rel-7. It was deleted from WID
- 911: Awaiting MCC SA3 input
- 912: FS CLOSED at G#28 (no input)
- 913: SP-38 stopped
- 914: Deleted. Same as FS on Further Improved Performance Requirements for UMTS/HSDPA UE (FDD)
- 915: Moved from FS section Feb 06
- 917: SP-30: S2 has no intention for TR completion
- 918: abandoned at 65%
- 919: SA#32 Jun 2006 Study abandoned => spin-off Implementation work UID_320029

| ID | WBS | Task | Duration | Start | Finish | Complete | Baseline start | Baseline finish | Baseline duration | Constraint | Resources | Work | Actual work | Text1 | Text6 | Text7 | Text8 | Text4 | Text5 | Text3 | Text9 | Text11 | Text2 | Text10 |
| --- | --- | --- | --- | --- | --- | --- | --- | --- | --- | --- | --- | --- | --- | --- | --- | --- | --- | --- | --- | --- | --- | --- | --- | --- |
| 922 | 8 | **Rel-6 Improvements of Radio Interface** | 1393d? | 2000-08-14 A | 2005-12-14 A | 100% | 2000-08-14 | 2005-12-14 | 1393d? |  | RP | 38664h | 38664h | RInImp | Rel-6 | TSG | Cesar |  |  |  |  |  |  |  |
| 923 | 295.1 | Improved support of IMS Realtime Services using HSDPA/EDCH | 197d? | 2005-03-15 A | 2005-12-14 A | 100% | 2005-03-15 | 2005-12-14 | 197d? | finish no earlier than 2005-12-14 | R2 | 1576h | 1576h | RInImp-IMSRealTime | Rel-6 | TSG | MCC_RAN | Don Zelmer | don.zelmer@CINGULAR.COM |  |  |  |  |  |
| 924 | 295.2 | Improving Receiver Performance Requirements for the FDD UE | 401d | 2002-03-08 A | 2003-09-19 A | 100% | 2002-03-08 | 2003-09-19 | 401d | start no earlier than 2002-03-08 | R4 | 3208h | 3208h | RInImp-UERecPerf | Rel-6 | TSG |  | Shimon Moshavi, Intel | shimon.moshavi@INTEL.COM | TS25.101 | BB | Active |  |  |
| 925 | 8.2 | **Base station classification** | 603d | 2000-08-14 A | 2002-12-04 A | 100% | 2000-08-14 | 2002-12-04 | 603d |  | R4 | 9648h | 9648h | RInImp-BSClass | Rel-6 | TSG |  |  |  |  |  |  |  |  |
| 926 | 8.2.1 | FDD Base station classification | 603d | 2000-08-14 A | 2002-12-04 A | 100% | 2000-08-14 | 2002-12-04 | 603d | finish no earlier than 2002-12-04 | R4 | 4824h | 4824h | RInImp-BSClass-FDD | Rel-6 | TSG |  | A. Toskala, Nokia |  | TS25.104, TS25.141 | 1476 |  | BaAs |  |
| 927 | 295.4 | UMTS-850 | 266d | 2002-12-06 A | 2003-12-12 A | 100% | 2002-12-06 | 2003-12-12 | 266d | finish no earlier than 2003-12-15 | R4 | 2128h | 2128h | RInImp-UMTS850 | Rel-6 | TSG | MCC_RAN | Don Zelmer, Cingular | don.zelmer@cingular.com | TS25.101, 25.104, 25.133, 25.141, 25.307, 25.331, TR25.942 | BB | Active |  |  |
| 928 | 295.5 | DS-CDMA introduction in the 800 MHz band | 196d | 2003-03-14 A | 2003-12-12 A | 100% | 2003-03-14 | 2003-12-12 | 196d | finish no earlier than 2003-12-15 | R4 | 1568h | 1568h | RInImp-UMTS800 | Rel-6 | TSG | MCC_RAN | Takehiro Nakamura, NTT DoCoMo | takehiro@wsp.yrp.nttdocomo.co.jp | TS25.101, 25.104, 25.133, 25.141, 25.307, 25.331 | BB | Active |  |  |
| 929 | 295.6 | UMTS 1.7/2.1 GHz | 261d | 2003-03-14 A | 2004-03-12 A | 100% | 2003-03-14 | 2004-03-12 | 261d | finish no earlier than 2004-03-15 | R4 | 2088h | 2088h | RInImp-UMTS1721 | Rel-6 | TSG | MCC RAN | Jussi Numminen, Nokia | jussi.numminen@NOKIA.COM | TS25.101, 25.104, 25.133, 25.141, 25.307, 25.331 | BB | Active |  |  |
| 930 | 295.7 | **Improved Receiver Performance Requirements for HSDPA** | 392d? | 2003-12-15 A | 2005-06-14 A | 100% | 2003-12-15 | 2005-06-14 | 392d? |  | R4 | 7304h | 7304h | RInImp-HSPerf | Rel-6 | TSG | MCC RAN | Jussi Numminen, Nokia | jussi.numminen@NOKIA.COM |  |  |  |  |  |
| 931 | 295.7.1 | Improved Minimum Performance Requirements for HSDPA UE categories 7 and 8 | 195d? | 2004-09-15 A | 2005-06-14 A | 100% | 2004-09-15 | 2005-06-14 | 195d? | finish no earlier than 2005-06-14 | R4 | 1560h | 1560h | RInImp-HSPerf-10code | Rel-6 | TSG | MCC_RAN | Jussi Numminen, Nokia | jussi.numminen@nokia.com | TS25.101 |  |  |  |  |
| 932 | 295.7.2 | Performance Requirements of Receive Diversity for HSDPA | 326d | 2003-12-15 A | 2005-03-14 A | 100% | 2003-12-15 | 2005-03-14 | 326d | finish no earlier than 2005-03-14 | R4 | 2608h | 2608h | RInImp-HSPerf-RxDiv | Rel-6 | TSG | MCC RAN | Takehiro Nakamura (NTT DoCoMo) | takehiro@wsp.yrp.nttdocomo.co.jp | TS25.101 |  |  |  |  |
| 933 | 296 | **Rel-6 RAN Feasibility Studies** | 1196d? | 2000-08-14 A | 2005-03-14 A | 100% | 2000-08-14 | 2005-03-14 | 1196d? |  | RP | 43048h | 43048h |  | Rel-6 |  | Cesar |  |  |  |  |  |  |  |
| 934 | 296.1 | FS of the improved access to UE measurement data for CRNC to support TDD RRM | 270d? | 2002-12-06 A | 2003-12-18 A | 100% | 2002-12-06 | 2003-12-18 | 270d? | finish no earlier than 2003-09-19 | R3 | 2160h | 2160h | RANimp-RRMopt-FSUEMsD | Rel-6 | TSG |  | Jim Miller, Interdigital | jim.miller@interdigital.com |  |  |  |  | SP-24 |
| 935 | 296.2 | FS on Radio link performance enhancements | 1067d | 2000-08-14 A | 2004-09-14 A | 100% | 2000-08-14 | 2004-09-14 | 1067d | finish no earlier than 2004-09-14 | R1 | 8536h | 8536h | RInImp-Rlperf | Rel-6 | TSG | MCC_RAN | Antti Toskala, Nokia Networks | antti.toskala@nokia.com | TR25.899 | SI | Active |  |  |
| 936 | 296.3 | FS on Improvement of inter-frequency and inter-system measurements for 1.28 Mcps TDD | 461d | 2001-12-14 A | 2003-09-19 A | 100% | 2001-12-14 | 2003-09-19 | 461d | start no earlier than 2001-12-14 | R1 | 3688h | 3688h | RInImp-IfIsMLCR | Rel-6 | TSG |  | Li Xiao Qiang, SAMSUNG | xqli@samsung.co.kr | TR25.888 | SI | Active |  |  |
| 937 | 296.4 | FS for the analysis of OFDM for UTRAN enhancement | 526d | 2002-06-10 A | 2004-06-14 A | 100% | 2002-06-10 | 2004-06-14 | 526d | start no earlier than 2002-06-10 | R1 | 4208h | 4208h | RInImp-FSOFDM | Rel-6 | TSG | MCC_RAN | Sarah Boumendil, Nortel | boumendi@nortelnetworks.com | TR25.892 | SI | Active |  |  |
| 938 | 296.5 | FS on Uplink Enhancements for Dedicated Transport Channels | 396d | 2002-09-06 A | 2004-03-12 A | 100% | 2002-09-06 | 2004-03-12 | 396d | finish no earlier than 2004-03-12 | R1 | 3168h | 3168h | RInImp-FSUpDTrCh | Rel-6 | TSG | MCC_RAN | Karri Ranta-aho, Nokia | Karri.Ranta-aho@nokia.com | TR25.896 | SI | Active |  |  |
| 939 | 296.6 | FS on Analysis on Higher Chip Rates for UTRA TDD evolutions | 528d | 2002-09-06 A | 2004-09-14 A | 100% | 2002-09-06 | 2004-09-14 | 528d | finish no earlier than 2004-09-14 | R1 | 4224h | 4224h | RInImp-FSVHCRTDD | Rel-6 | TSG | MCC_RAN | Tim Wilkinson, IPWireless | mbeale@ipwireless.com | TR25.895 | SI | Active |  |  |
| 940 | 296.7 | FS on Low Output Powers for general purpose FDD BSs | 128d | 2003-06-13 A | 2004-03-12 A | 100% | 2003-06-13 | 2004-03-12 | 128d | finish no earlier than 2004-03-12 | R3 | 1024h | 1024h | RInImp-FSLoPw | Rel-6 | TSG | MCC_RAN | Ana Burgos, Telefonica | burgos_a@tsm.es | TR25.807 | SI | Active |  |  |
| 941 | 296.8 | FS on Uplink enhancements for UTRA TDD | 462d | 2003-06-06 A | 2005-03-14 A | 100% | 2003-06-06 | 2005-03-14 | 462d | finish no earlier than 2005-03-14 | R1 | 3696h | 3696h | RInImp-FSUpEnhTDD | Rel-6 | TSG | MCC_RAN | Marian Rudolf, Interdigital | Marian.Rudolf@InterDigital.com | TR25.804 | SI | Active |  |  |
| 942 | 8.8 | FS on UE antenna efficiency test methods performance requirements (2) | 131d | 2002-03-08 A | 2002-09-06 A | 100% | 2002-03-08 | 2002-09-06 | 131d | finish no earlier than 2002-09-06 | R4 | 1048h | 1048h | RInImp-UEAnTM2 | Rel-6 | TSG |  | Alf Ahlström, Allgon |  |  |  |  |  |  |
| 943 | 9.4 | Deleted - FS on the evolution of the UTRAN architecture | 592d | 2002-09-09 A | 2004-12-15 A | 100% | 2002-09-09 | 2004-12-15 | 592d | finish no earlier than 2004-12-15 | R3 | 4736h | 4736h | RANimp-FSEvo | Rel-6 | TSG | MCC_RAN | Woonhee Hwang, Nokia | Antti.Toskala@nokia.com |  |  |  |  |  |
| 944 | 297 | **FDD Enhanced Uplink** | 393d | 2004-03-15 A | 2005-09-15 A | 100% | 2004-03-15 | 2005-09-15 | 393d |  | RP | 14128h | 14128h | EDCH | Rel-6 | TSG | Cesar | Joakim Bergström (Ericsson) |  |  | Feat | Active |  |  |
| 945 | 297.1 | FDD Enhanced Uplink - Stage 2 | 197d | 2004-03-15 A | 2004-12-14 A | 100% | 2004-03-15 | 2004-12-14 | 197d | finish no earlier than 2004-12-14 | R2 | 1576h | 1576h | EDCH-Stage2 | Rel-6 | TSG |  |  |  | TS 25.309 |  |  |  |  |
| 946 | 297.2 | FDD Enhanced Uplink - Physical Layer | 261d | 2004-03-15 A | 2005-03-14 A | 100% | 2004-03-15 | 2005-03-14 | 261d | finish no earlier than 2005-03-14 | R1 | 2088h | 2088h | EDCH-Phys | Rel-6 | TSG | MCC RAN | Karri Ranta-aho (Nokia) |  | TS25.211, 25.212, 25.213, 25.214, 25.215 | BB | Active |  |  |
| 947 | 297.3 | FDD Enhanced Uplink - Layer 2 and 3 Protocol Aspects | 261d | 2004-03-15 A | 2005-03-14 A | 100% | 2004-03-15 | 2005-03-14 | 261d | finish no earlier than 2005-03-14 | R2 | 2088h | 2088h | EDCH-L23 | Rel-6 | TSG | MCC RAN | Joakim Bergström (Ericsson) |  | TS25.301, 25.302, 25.306, 25.321, 25.331 | BB | Active |  |  |
| 948 | 297.4 | FDD Enhanced Uplink - UTRAN Iub/Iur Protocol Aspects | 261d | 2004-03-15 A | 2005-03-14 A | 100% | 2004-03-15 | 2005-03-14 | 261d | finish no earlier than 2005-03-14 | R3 | 2088h | 2088h | EDCH-IurIub | Rel-6 | TSG | MCC RAN | Saso Stojanovski (Nortel) |  | TS25.401, 25.420, 25.423, 25.430, 25.433 | BB | Active |  |  |
| 949 | 297.5 | FDD Enhanced Uplink - RF Radio Transmission/ Reception, System Performance Requirements and Conformance Testing | 393d | 2004-03-15 A | 2005-09-15 A | 100% | 2004-03-15 | 2005-09-15 | 393d | finish no earlier than 2005-09-15 | R4 | 3144h | 3144h | EDCH-RF | Rel-6 | TSG | MCC RAN | Thomas Unshelm (Ericsson) | thomas.unshelm@ERICSSON.COM | TS25.101, 25.104, 25.133, 25.141 | BB | Active |  |  |

Notes:
- 922: This is a generic feature without particular end date
- 931: Approved at RP#25 as RP-040375
- 935: Study finished at RP#25
- 939: Study finished at RP#25
- 942: The RInImp-UEAnTM FS was re-opened at TSG RAN#15 upon request from WG4
- 943: Study Closed, work will continue within the FS on evolved UTRA and UTRAN

| ID | WBS | Task | Type | Duration | Start | Finish | Complete | Baseline start | Baseline finish | Baseline duration | Constraint | Resources | Work | Actual work | Text1 | Text6 | Text7 | Text8 | Text2 | Text3 | Text4 | Text5 | Text9 | Text11 | Text12 | Text10 |
| --- | --- | --- | --- | --- | --- | --- | --- | --- | --- | --- | --- | --- | --- | --- | --- | --- | --- | --- | --- | --- | --- | --- | --- | --- | --- | --- |
| 950 | 298 | **Rel-6 RAN improvements** |  | 656d? | 2002-09-09 A | 2005-03-14 A | 100% | 2002-09-09 | 2005-03-14 | 656d? |  | RP | 28312h | 28312h | RANimp | Rel-6 | TSG | Cesar |  |  |  |  |  |  |  |  |
| 951 | 9.2 | **RAB support enhancement** |  | 522d? | 2003-03-14 A | 2005-03-14 A | 100% | 2003-03-14 | 2005-03-14 | 522d? |  | R2 | 9360h | 9360h | RANimp-RABSE | Rel-6 | TSG | MCC RAN | BaAS | TR 25.862 | Juha Mikola, Nokia | juha.mikola@nokia.com | 624 |  |  |  |
| 952 | 298.1.1 | Optimisation of downlink channelisation code utilisation |  | 262d | 2004-03-12 A | 2005-03-14 A | 100% | 2004-03-12 | 2005-03-14 | 262d | finish no earlier than 2005-03-14 | R1 | 2096h | 2096h | RANimp-RABSE-CodeOptFDD | Rel-6 | TSG | MCC RAN |  |  | Sarah Boumendil (Nortel Networks) | boumendi@nortelnetworks.com | WT | Active |  |  |
| 953 | 298.1.2 | Optimisation of channelisation code utilisation for 3.84 Mcps TDD |  | 261d | 2004-03-15 A | 2005-03-14 A | 100% | 2004-03-15 | 2005-03-14 | 261d | finish no earlier than 2005-03-15 | R1 | 2088h | 2088h | RANimp-RABSE-CodOptTDD | Rel-6 | TSG | MCC RAN |  |  | Nicholas Anderson (IPWireless) |  | WT | Active |  |  |
| 954 | 298.1.3 | HS-DPCCH ACK/NACK Enhancement |  | 65d? | 2004-09-15 A | 2004-12-14 A | 100% | 2004-09-15 | 2004-12-14 | 65d? | finish no earlier than 2004-12-15 | R1 | 520h | 520h | RANimp-RABSE-ACKNACK | Rel-6 | TSG | MCC_RAN |  | TS25.212, TS25.214, TS24.331, TS25.433 | Jussi Kähtävä, Nokia |  |  |  |  |  |
| 955 | 298.1.4 | Deleted - Iu enhancements for IMS support in RAN |  | 320d? | 2003-03-14 A | 2004-06-03 A | 100% | 2003-03-14 | 2004-06-03 | 320d? | start no earlier than 2003-03-14 | R3 | 2560h | 2560h | RANimp-RABSE-IuEnhIMS | Rel-6 | TSG | MCC RAN |  |  | Phillipe Godin, Nortel | Philippe.Godin@nortelnetworks.com |  |  |  |  |
| 956 | 298.1.5 | Deleted - Improvement of RRM across RNS and RNS/BSS | milestone | 0d? | 2003-12-05 A | 2003-12-05 A | 100% | 2003-12-05 | 2003-12-05 | 0d? | finish no earlier than 2003-12-05 | R3 |  |  | RANimp-RRM1 | Rel-6 |  |  |  |  | Antti Toskala, Nokia |  |  |  | RP-23 |  |
| 957 | 9.1 | Beamforming Enhancements |  | 66d | 2003-09-19 A | 2003-12-19 A | 100% | 2003-09-19 | 2003-12-19 | 66d | finish no earlier than 2004-03-12 | R1 | 528h | 528h | RANimp-BFE | Rel-6 | TSG | MCC_RAN |  | TS24.215, 25.423, 25.425, 25.433, 25.435 | Jussi Kähtävä, Nokia | jussi.kahtava@nokia.com |  |  |  |  |
| 958 | 298.3 | **Rel6 RRM optimization for Iur and Iub** |  | 126d | 2003-09-19 A | 2004-03-12 A | 100% | 2003-09-19 | 2004-03-12 | 126d |  | R3 | 2016h | 2016h | RANimp-RRMopt | Rel-6 | TSG | MCC_RAN | BaAS |  | Gert-Jan van Lieshout, Ericsson | Gert-Jan.van.Lieshout@eln.ericsson.se |  |  |  |  |
| 959 | 298.3.1 | Improved access to UE measurement data for CRNC to support TDD RRM |  | 126d | 2003-09-19 A | 2004-03-12 A | 100% | 2003-09-19 | 2004-03-12 | 126d | finish no earlier than 2004-03-15 | R3 | 1008h | 1008h | RANimp-RRMopt-UEMsD | Rel-6 | TSG | MCC RAN |  | TS25.423 | Jim Miller, Interdigital | jim.miller@interdigital.com | WT | Active | RP-22 |  |
| 960 | 298.4 | **Remote Control of Electrical Tilting Antennas** |  | 395d? | 2003-03-14 A | 2004-09-16 A | 100% | 2003-03-14 | 2004-09-16 | 395d? |  | R3 | 7464h | 7464h | RANimp-TiltAnt | Rel-6 | TSG | MCC_RAN |  |  | Andreas Hauser, Vodafone | Andreas.Hauser@vodafone.com |  |  |  |  |
| 961 | 298.4.1 | Tilting Antenna - RAN aspects |  | 393d? | 2003-03-14 A | 2004-09-14 A | 100% | 2003-03-14 | 2004-09-14 | 393d? | finish no earlier than 2004-09-14 | R3 | 3144h | 3144h | RANimp-TiltAnt | Rel-6 | TSG | MCC_RAN |  | TS25.460, 25.461, 25.462, 25.463 | Andreas Hauser, Vodafone | Andreas.Hauser@vodafone.com |  |  |  |  |
| 962 | 298.4.2 | OAM&P impacts |  | 145d | 2004-02-27 A | 2004-09-16 A | 100% | 2004-02-27 | 2004-09-16 | 145d | finish no earlier than 2004-09-16 | S5 | 1160h | 1160h | RANimp-TiltAnt-OAM | Rel-6 | WG | Adrian |  | 32.804, 32.64x | Adrian.Neal@vodafone.com | Adrian.Neal@vodafone.com |  |  |  | SP-24 |
| 963 | 298.5 | Network Assisted Cell Change (NACC) from UTRAN to GERAN - network-side aspects |  | 462d? | 2002-09-09 A | 2004-06-15 A | 100% | 2002-09-09 | 2004-06-15 | 462d? | finish no earlier than 2004-06-15 | R3 | 3696h | 3696h | RANimp-NACC | Rel-6 | TSG | MCC_RAN |  |  | Brendan McWilliams, Vodafone | Brendan.McWilliams@gb.vodafone.co.uk |  |  |  |  |
| 964 | 12 | **Location Services enhancements 2** |  | 1024d? | 2001-01-15 A | 2004-12-16 A | 100% | 2001-01-15 | 2004-12-16 | 1024d? |  | S2 | 77352h | 77352h | LCS2 | Rel-6 | TSG | Sang-Ui |  | 23.271 |  |  |  |  |  |  |
| 965 | 12.1 | **Improvement on Le interface** |  | 653d? | 2002-06-17 A | 2004-12-15 A | 100% | 2002-06-17 | 2004-12-15 | 653d? |  | S2 | 9872h | 9872h |  | Rel-6 | TSG |  |  |  |  |  |  |  |  |  |
| 966 | 299.1.1 | Stage 2 |  | 331d? | 2002-06-17 A | 2003-09-22 A | 100% | 2002-06-17 | 2003-09-22 | 331d? | start no earlier than 2002-06-17 | S2 | 2648h | 2648h |  | Rel-6 |  |  |  |  |  |  |  |  |  |  |
| 967 | 299.1.2 | Stage 3 - impacts MLP (Mobile Location Protocol) |  | 250d? | 2004-01-01 A | 2004-12-15 A | 100% | 2004-01-01 | 2004-12-15 | 250d? | finish no earlier than 2004-12-15 | OMA | 2000h | 2000h |  | Rel-6 |  |  |  |  |  | OMA-LIAISON@mail.openmobilealliance.org |  |  |  |  |
| 968 | 12.2 | **Enhanced support for anonymity and user privacy** |  | 638d? | 2002-07-08 A | 2004-12-15 A | 100% | 2002-07-08 | 2004-12-15 | 638d? |  | S2 | 9144h | 9144h |  | Rel-6 | TSG |  |  |  |  |  |  |  |  |  |
| 969 | 299.2.1 | Stage 2 |  | 255d? | 2002-07-08 A | 2003-06-27 A | 100% | 2002-07-08 | 2003-06-27 | 255d? | finish no earlier than 2003-06-27 | S2 | 2040h | 2040h |  | Rel-6 |  |  |  |  |  |  |  |  |  |  |
| 970 | 299.2.2 | Stage 3 - impacts MLP and RLP |  | 250d? | 2004-01-01 A | 2004-12-15 A | 100% | 2004-01-01 | 2004-12-15 | 250d? | finish no earlier than 2004-12-15 | OMA | 2000h | 2000h |  | Rel-6 |  |  |  |  |  | OMA-LIAISON@mail.openmobilealliance.org |  |  |  |  |
| 971 | 12.3 | **Enhanced inter-GMLC interface** |  | 648d? | 2002-06-24 A | 2004-12-15 A | 100% | 2002-06-24 | 2004-12-15 | 648d? |  | S2 | 9704h | 9704h |  | Rel-6 | TSG |  |  |  |  |  |  |  |  |  |
| 972 | 299.3.1 | Stage 2 |  | 315d? | 2002-06-24 A | 2003-09-05 A | 100% | 2002-06-24 | 2003-09-05 | 315d? | finish no earlier than 2003-09-05 | S2 | 2520h | 2520h |  | Rel-6 |  |  |  |  |  |  |  |  |  |  |
| 973 | 299.3.2 | Stage 3 - definition of RLP and PCP |  | 250d? | 2004-01-01 A | 2004-12-15 A | 100% | 2004-01-01 | 2004-12-15 | 250d? | finish no earlier than 2004-12-15 | OMA | 2000h | 2000h |  | Rel-6 |  |  |  |  |  | OMA-LIAISON@mail.openmobilealliance.org |  |  |  |  |

Notes:
- 950: Generic feature
- 951: This is a building block without particular end date
- 953: WIDS modified in RP#26, RP-040551
- 954: Approved at RP#25 as RP-040390
- 955: Closed RAN#24 due to the lack of progress
- 956: abandoned RP-23
- 961: Finished at RP#25
- 962: SA#25 09/2004 completed
- 967: Updated according to SP-040232
- 970: Updated according to SP-040232
- 973: Updated according to SP-040232

| ID | WBS | Task | Type | Duration | Start | Finish | Complete | Remaining | Baseline start | Baseline finish | Baseline duration | Total slack | Constraint | Resources | Work | Actual work | Text6 | Text7 | Text5 | Text1 | Text8 | Text4 | Text9 | Text12 | Text2 |
| --- | --- | --- | --- | --- | --- | --- | --- | --- | --- | --- | --- | --- | --- | --- | --- | --- | --- | --- | --- | --- | --- | --- | --- | --- | --- |
| 974 | 12.4 | **Location Services support for IMS public identities** |  | 473d? | 2003-02-24 A | 2004-12-15 A | 100% |  | 2003-02-24 | 2004-12-15 | 473d? |  |  | S2 | 7704h | 7704h | Rel-6 | TSG |  |  |  |  |  |  |  |
| 975 | 299.4.1 | Stage 2 |  | 240d? | 2003-02-24 A | 2004-01-23 A | 100% |  | 2003-02-24 | 2004-01-23 | 240d? |  | finish no earlier than 2004-01-23 | S2 | 1920h | 1920h | Rel-6 |  |  |  |  |  |  |  |  |
| 976 | 299.4.2 | Stage 3 - impacts MLP, RLP and PCP |  | 250d? | 2004-01-01 A | 2004-12-15 A | 100% |  | 2004-01-01 | 2004-12-15 | 250d? |  | finish no earlier than 2004-12-15 | OMA | 2000h | 2000h | Rel-6 |  | OMA-LIAISON@mail.openmobilealliance.org |  |  |  |  |  |  |
| 977 | 12.5 | **New area event for location service triggering reports** |  | 663d? | 2002-06-03 A | 2004-12-15 A | 100% |  | 2002-06-03 | 2004-12-15 | 663d? |  |  | S2 | 11416h | 11416h | Rel-6 | TSG |  |  |  |  |  |  |  |
| 978 | 299.5.1 | Stage 2 |  | 280d? | 2002-06-03 A | 2003-06-27 A | 100% |  | 2002-06-03 | 2003-06-27 | 280d? |  | finish no earlier than 2003-06-27 | S2 | 2240h | 2240h | Rel-6 |  |  |  |  |  |  |  |  |
| 979 | 299.5.2 | Stage 3 for UE-CN signalling |  | 234d? | 2003-10-09 A | 2004-08-31 A | 100% |  | 2003-10-09 | 2004-08-31 | 234d? |  | start no earlier than 2003-10-09 | N4 | 1872h | 1872h | Rel-6 |  |  |  |  |  |  |  |  |
| 980 | 299.5.3 | Stage 3 - impacts MLP, RLP and PCP |  | 250d? | 2004-01-01 A | 2004-12-15 A | 100% |  | 2004-01-01 | 2004-12-15 | 250d? |  | finish no earlier than 2004-12-15 | OMA | 2000h | 2000h | Rel-6 |  | OMA-LIAISON@mail.openmobilealliance.org |  |  |  |  |  |  |
| 981 | 12.7 | **UE positioning** |  | 957d? | 2001-01-15 A | 2004-09-14 A | 100% |  | 2001-01-15 | 2004-09-14 | 957d? |  |  | RP | 18480h | 18480h | Rel-6 | TSG |  | LCS2-UEpos | MCC_RAN |  |  |  |  |
| 982 | 12.8 | Open SMLC-SRNC Interface within the UTRAN to support UTRAN Rel4 positioning methods |  | 700d? | 2001-01-15 A | 2003-09-19 A | 100% |  | 2001-01-15 | 2003-09-19 | 700d? |  | finish no earlier than 2003-09-19 | R2 | 5600h | 5600h | Rel-6 | TSG | Meik.Kottkamp@siemens.com | LCS-Rel4Pos |  | Meik Kottkamp, Siemens | 2475 |  |  |
| 983 | 299.6.2 | A-GPS minimum performance specification |  | 333d? | 2003-06-06 A | 2004-09-14 A | 100% |  | 2003-06-06 | 2004-09-14 | 333d? |  | finish no earlier than 2004-09-14 | R4 | 2664h | 2664h | Rel-6 | TSG | donglin.shen@attws.com | LCS-UEPos-AGPSPerf | MCC_RAN | Donglin Shen, AT&T Wireless Services |  |  |  |
| 984 | 12.7.2 | FS on Enhancements to OTDOA Positioning using advanced blanking methods |  | 320d | 2002-07-01 A | 2003-09-19 A | 100% |  | 2002-07-01 | 2003-09-19 | 320d |  | finish no earlier than 2003-09-19 | R2 | 2560h | 2560h | Rel-6 | TSG | david.bartlett@cursor-system.com | LCS2-UEpos-FSBlank |  | David Bartlett, Cambridge Positioning Systems |  |  |  |
| 985 | 299.6.4 | Deleted - UE positioning enhancements - other methods | milestone | 0d? | 2003-09-26 A | 2003-09-26 A | 100% |  | 2003-09-26 | 2003-09-26 | 0d? |  | finish no earlier than 2003-09-26 | R2 |  |  | Rel-6 |  |  | LCS2-UEpos-enh |  | Meik Kottkamp, Siemens |  | RP-24 |  |
| 986 | 299.7 | LCS charging |  | 455d? | 2003-03-21 A | 2004-12-16 A | 100% |  | 2003-03-21 | 2004-12-16 | 455d? |  | start no earlier than 2003-03-21 | S5 | 3640h | 3640h | Rel-6 | TSG | alain.bibas@francetelecom.com | LCS2-CH | Adrian | alain.bibas@francetelecom.com |  |  |  |
| 987 | 14 | **Rel-6 Security enhancements** |  | 1018d? | 2001-01-03 A | 2004-11-26 | 75% | 250.03d? | 2001-01-03 | 2004-11-26 | 1018d? | 1325d |  | S3 | 28824h | 20775.7h | Rel-6 | TSG | Peter.Howard@vodafone.com | SEC1 | Maurice | Peter Howard, Vodafone |  |  |  |
| 988 | 14.1 | **Enhanced HE control of security (including positive authentication reporting)** |  | 712d | 2001-01-03 A | 2003-09-25 | 47% | 378d | 2001-01-03 | 2003-09-25 | 712d | 1631d |  | S3 | 14064h | 8016h | Rel-6 |  | Peter.Howard@vodafone.com |  |  | Peter Howard, Vodafone | 2026 |  |  |
| 989 | 14.1.1 | Stage 2 |  | 378d | 2001-01-03 | 2002-06-14 |  |  | 2001-01-03 | 2002-06-14 | 378d | 1965d | finish no earlier than 2002-06-14 | S3 | 3024h |  | Rel-6 |  |  |  |  |  | 2027 |  |  |
| 990 | 14.1.3 | **Network domain security** |  | 334d | 2002-06-17 A | 2003-09-25 A | 100% |  | 2002-06-17 | 2003-09-25 | 334d |  |  | S3 | 5344h | 5344h | Rel-6 | TSG | Geir-myrdahl.koien@telenor.com | SEC1-NDS |  | Geir M. Køien, Telenor |  |  | Sec |
| 991 | 14.1.3.1 | IP network layer security (NDS/IP) |  | 334d | 2002-06-17 A | 2003-09-25 A | 100% |  | 2002-06-17 | 2003-09-25 | 334d |  | finish no earlier than 2003-09-25 | S3 | 2672h | 2672h | Rel-6 | WG |  | SEC1-NDS-IP |  |  |  |  |  |
| 992 | 300.2 | Network Domain Security; Authentication Framework (NDS/AF) |  | 521d? | 2002-02-15 A | 2004-02-13 A | 100% |  | 2002-02-15 | 2004-02-13 | 521d? |  | finish no earlier than 2004-02-13 | S3 | 4168h | 4168h | Rel-6 | TSG | tommi.viitanen@nokia.com | SEC1-NDS-AF |  | Tommi Viitanen, Nokia |  |  |  |
| 993 | 300.3 | Key Management of group keys for Voice Group Call Services |  | 306d | 2003-09-26 A | 2004-11-26 A | 100% |  | 2003-09-26 | 2004-11-26 | 306d |  | finish no earlier than 2004-11-26 | S3 | 2448h | 2448h | Rel-6 | TSG | benno.tietz@vodafone.com | SECGKYV | Maurice | Benno Tietz, Vodafone D2 |  |  |  |
| 994 | 16 | **IMS Phase 2** |  | 1395d? | 2000-08-28 A | 2005-12-30 A | 100% |  | 2000-08-28 | 2005-12-30 | 1395d? |  |  | S1 | 126048h | 126048h | Rel-6 | TSG |  | IMS2 | Sang-Ui |  |  |  |  |
| 995 | 301.1 | Enhancements to the Cx and Sh interfaces |  | 323d? | 2003-06-06 A | 2004-08-31 A | 100% |  | 2003-06-06 | 2004-08-31 | 323d? |  | finish no earlier than 2004-08-31 | N4 | 2584h | 2584h | Rel-6 | WG |  | IMS2-CCR |  |  |  |  |  |
| 996 | 16.12 | **IMS Group Management** |  | 715d? | 2002-03-14 A | 2004-12-08 A | 100% |  | 2002-03-14 | 2004-12-08 | 715d? |  |  | S1 | 12680h | 12680h | Rel-6 | TSG | juha.kalliokulju@nokia.com | IMSGM |  | Juha Kalliokulju (Nokia) |  |  |  |
| 997 | 16.12.1 | Stage 1 - TS on IMS group management |  | 193d | 2002-03-14 A | 2002-12-09 A | 100% |  | 2002-03-14 | 2002-12-09 | 193d |  | finish no earlier than 2002-12-09 | S1 | 1544h | 1544h | Rel-6 | TSG | juha.kalliokulju@nokia.com |  |  | Juha Kalliokulju (Nokia) |  |  |  |
| 998 | 301.2.2 | Stage 2 |  | 158d? | 2003-05-26 A | 2003-12-31 A | 100% |  | 2003-05-26 | 2003-12-31 | 158d? |  | finish no earlier than 2003-12-31 | S2 | 1264h | 1264h | Rel-6 |  |  |  |  |  |  |  |  |
| 999 | 301.2.3 | Stage 3 for IMS Group management (e.g. chat) |  | 519d? | 2002-12-13 A | 2004-12-08 A | 100% |  | 2002-12-13 | 2004-12-08 | 519d? |  | finish no earlier than 2004-12-08 | N1 | 4152h | 4152h | Rel-6 |  | drage@lucent.com |  |  | Keith Drage, Lucent |  |  |  |

Notes:
- 976: Updated according to SP-040232
- 979: 31/10/2003 work has started. Current stage 3 fullfills the requirements of stage 2. ......
- 980: Updated according to SP-040232
- 982: Text3: TS25.305, 25.401, 25.450, 25.452, 25.453
- 983: Finished at RP#25 / Text3: TS25.171
- 985: This is a building block without particular end date
- 986: SA#26 12/2004 completed / Text3: 32.271
- 987: Added BB UE authentication and rapporteur added.
- 988: Added by SP-000575 without any dates. 18/10/00: Change of WI title, added hyperlink rapporteur new end date 03/01. New end date and correct Release to be decided S3#18
- 989: New end date and correct Release to be decided S3#18
- 990: WID approved for Rel-6 at SA#17. Completed 2004-12
- 991: Should be complete after SA3#27. Completed 2004-12 / Text3: TS 33.210
- 992: WID approved SA#19. Work started after FS approved SA#18
- 993: Approved TSG#21. Completed 2004-12 / Text3: 42.068, 43.068, 44.068, 42.069, 43.069, 44.069, 31.102, 24.008, 48.008, 42.009, 43.020
- 994: Not yet available: verbally approved at SA15, actual WID to be provided at SA16 by Lucent / Text3: 23.228
- 995: Shared public user identities need to be solved. If email approval CR is accepted. Work 100% done....
- 999: Depends on CN decision on CPCP in Rel-6. Complete, if unresolved IETF dependencies are dropped (-> LS to CN plenary)

| ID | WBS | Task | Type | Duration | Start | Finish | Complete | Baseline start | Baseline finish | Baseline duration | Constraint | Resources | Work | Actual work | Text6 | Text4 | Text5 | Text1 | Text7 | Text3 | Text2 | Text9 | Text12 |
| --- | --- | --- | --- | --- | --- | --- | --- | --- | --- | --- | --- | --- | --- | --- | --- | --- | --- | --- | --- | --- | --- | --- | --- |
| 1000 | 301.3 | **IMS Conferencing** |  | 548d? | 2002-11-04 A | 2004-12-08 A | 100% | 2002-11-04 | 2004-12-08 | 548d? |  | N1 | 10960h | 10960h | Rel-6 |  |  |  |  |  |  |  |  |
| 1001 | 301.3.1 | Stage 2 |  | 303d? | 2002-11-04 A | 2003-12-31 A | 100% | 2002-11-04 | 2003-12-31 | 303d? | finish no earlier than 2003-12-31 | S2 | 2424h | 2424h | Rel-6 |  |  |  |  |  |  |  |  |
| 1002 | 301.3.2 | Stage 3 |  | 519d? | 2002-12-13 A | 2004-12-08 A | 100% | 2002-12-13 | 2004-12-08 | 519d? | finish no earlier than 2004-12-08 | N1 | 4152h | 4152h | Rel-6 | Keith Drage, Lucent | drage@lucent.com |  |  |  |  |  |  |
| 1003 | 16.11 | **IMS Messaging** |  | 992d? | 2002-03-14 A | 2005-12-30 A | 100% | 2002-03-14 | 2005-12-30 | 992d? |  | S1 | 23912h | 23912h | Rel-6 | Juha Kalliokulju (Nokia) | juha.kalliokulju@nokia.com | IMSM | TSG |  |  |  |  |
| 1004 | 16.11.1 | TR on support of messaging in the IMS |  | 193d | 2002-03-14 A | 2002-12-09 A | 100% | 2002-03-14 | 2002-12-09 | 193d | finish no earlier than 2002-12-09 | S1 | 1544h | 1544h | Rel-6 | Juha Kalliokulju (Nokia) | juha.kalliokulju@nokia.com | IMSM-TR | TSG |  |  |  |  |
| 1005 | 301.4.2 | Stage 1 22.340 |  | 23d? | 2002-11-11 A | 2002-12-11 A | 100% | 2002-11-11 | 2002-12-11 | 23d? | finish no earlier than 2002-12-11 | S1 | 184h | 184h | Rel-6 | Juha Kalliokulju (Nokia) | juha.kalliokulju@nokia.com | IMSM-TS | TSG | 22.340 |  |  |  |
| 1006 | 301.4.3 | CRs to 22.140 & 22.228 |  | 263d? | 2002-03-14 A | 2003-03-17 A | 100% | 2002-03-14 | 2003-03-17 | 263d? | finish no earlier than 2003-03-17 | S1 | 2104h | 2104h | Rel-6 | Juha Kalliokulju (Nokia) | juha.kalliokulju@nokia.com | IMSM-CR | TSG | 22.140,22.228 |  |  |  |
| 1007 | 16.11.3 | Stage 2 |  | 477d | 2002-11-04 A | 2004-08-31 A | 100% | 2002-11-04 | 2004-08-31 | 477d | finish no earlier than 2004-08-31 | S2 | 3816h | 3816h | Rel-6 |  |  |  |  |  |  |  |  |
| 1008 | 301.4.5 | Stage 3 for IMS Messaging |  | 519d? | 2002-12-13 A | 2004-12-08 A | 100% | 2002-12-13 | 2004-12-08 | 519d? | finish no earlier than 2004-12-08 | N1 | 4152h | 4152h | Rel-6 | Keith Drage, Lucent | drage@lucent.com |  |  |  |  |  |  |
| 1009 | 301.4.6 | SIP/SIMPLE Instant messaging |  | 522d? | 2004-01-01 A | 2005-12-30 A | 100% | 2004-01-01 | 2005-12-30 | 522d? | finish no earlier than 2005-06-30 | OMA | 4176h | 4176h | Rel-6 |  | OMA-LIAISON@mail.openmobilealliance.org |  | n/a |  |  |  |  |
| 1010 | 301.5 | **Additional SIP Capabilities support not covered by Rel-5** |  | 680d? | 2002-11-11 A | 2005-06-17 A | 100% | 2002-11-11 | 2005-06-17 | 680d? |  | N1 | 13392h | 13392h | Rel-6 |  |  |  |  |  |  |  |  |
| 1011 | 301.5.1 | Stage 2 for add SIP cap (e.g. forking) |  | 335d? | 2002-11-11 A | 2004-02-20 A | 100% | 2002-11-11 | 2004-02-20 | 335d? | finish no earlier than 2004-02-20 | S2 | 2680h | 2680h | Rel-6 |  |  |  |  |  |  |  |  |
| 1012 | 301.5.2 | Stage 3 for Additional SIP Capabilities |  | 454d? | 2002-12-13 A | 2004-09-08 A | 100% | 2002-12-13 | 2004-09-08 | 454d? | finish no earlier than 2004-09-08 | N1 | 3632h | 3632h | Rel-6 | Keith Drage, Lucent | drage@lucent.com |  |  |  |  |  |  |
| 1013 | 301.5.3 | Procedured associated with IMS-ALG |  | 205d? | 2004-09-06 A | 2005-06-17 A | 100% | 2004-09-06 | 2005-06-17 | 205d? | start no earlier than 2004-09-06 | N1 | 1640h | 1640h | Rel-6 |  |  |  |  |  |  |  |  |
| 1014 | 301.6 | Review additional SIP Capabilities against IMS |  | 454d? | 2002-12-13 A | 2004-09-08 A | 100% | 2002-12-13 | 2004-09-08 | 454d? | finish no earlier than 2004-09-08 | N1 | 3632h | 3632h | Rel-6 | Keith Drage, Lucent | drage@lucent.com |  |  |  |  |  |  |
| 1015 | 16.5 | **Interworking between IMS and IP networks** |  | 1118d? | 2000-08-28 A | 2004-12-08 A | 100% | 2000-08-28 | 2004-12-08 | 1118d? |  | N3 | 31712h | 31712h | Rel-6 | Nigel Holland, BT | nigel.holland@bt.com | IMS-CCR-IWIP | TSG | 23.821, 29.061, 29.162 | BaAS | 2048 |  |
| 1016 | 16.5.1 | Interworking for 3GPP_SIP and IETF_SIP |  | 730d | 2000-08-28 A | 2003-06-13 A | 100% | 2000-08-28 | 2003-06-13 | 730d | finish no earlier than 2003-06-13 | N3 | 5840h | 5840h | Rel-6 | Thomas Belling, Siemens |  |  |  | New TR 29.962 |  |  |  |
| 1017 | 16.5.2 | Interworking for IPv6 to IPv4 |  | 1118d | 2000-08-28 A | 2004-12-08 A | 100% | 2000-08-28 | 2004-12-08 | 1118d | finish no earlier than 2004-12-08 | N3 | 8944h | 8944h | Rel-6 |  |  |  |  | 29.163 |  |  |  |
| 1018 | 301.7.3 | Interworking for IPv6 to IPv4 (SIP / SDP aspects) |  | 87d? | 2004-05-11 A | 2004-09-08 A | 100% | 2004-05-11 | 2004-09-08 | 87d? | finish no earlier than 2004-09-08 | N1 | 696h | 696h | Rel-6 |  |  |  |  |  |  |  |  |
| 1019 | 16.8.1 | stage 3 of interworking with non-IMS IP networks |  | 911d | 2001-03-14 A | 2004-09-08 A | 100% | 2001-03-14 | 2004-09-08 | 911d | finish no earlier than 2004-09-08 | N1 | 7288h | 7288h | Rel-6 |  |  |  |  |  |  |  |  |
| 1020 | 16.6.1 | Interworking between IMS and CS networks |  | 929d? | 2000-08-28 A | 2004-03-18 A | 100% | 2000-08-28 | 2004-03-18 | 929d? | finish no earlier than 2004-03-18 | N3 | 7432h | 7432h | Rel-6 | Brendan Mc Williams, Vodafone | brendan.mcwilliams@vf.vodafone.co.uk | IMS-CCR-IWCS | TSG | 29.163, 29.061, 24.228, and new CN4 specification | CCaR |  |  |
| 1021 | 16.10 | Mn interface (IM-MGW to MGCF) enhancements (CN4 Part) |  | 418d | 2001-08-07 A | 2004-09-01 A | 100% | 2001-08-07 | 2004-09-01 | 418d | finish no earlier than 2004-09-01 | N4 | 3344h | 3344h | Rel-6 |  |  | IMS-CCR-Mn |  |  |  |  |  |
| 1022 | 301.10 | Study of subscriber and operators relationship in IMS and related ISIM requirements for Rel 6” |  | 20d? | 2002-11-15 A | 2002-12-12 A | 100% | 2002-11-15 | 2002-12-12 | 20d? | finish no earlier than 2002-12-12 | S1 | 160h | 160h | Rel-6 | Juha Kalliokulju (Nokia) | juha.kalliokulju@nokia.com |  |  |  |  |  |  |
| 1023 | 301.11 | Lawful Interception in the 3GPP Rel-6 architecture |  | 269d? | 2002-12-09 A | 2003-12-18 A | 100% | 2002-12-09 | 2003-12-18 | 269d? | finish no earlier than 2003-12-18 | S3 | 2152h | 2152h | Rel-6 | Berthold Wilhelm | Berthold.Wilhelm@REGTP.DE | SEC1-LI | TSG | 33.106, 33.107, 33.108 |  |  |  |
| 1024 | 301.12 | IMS Subscription and access scenarios |  | 130d? | 2002-12-16 A | 2003-06-13 A | 100% | 2002-12-16 | 2003-06-13 | 130d? | start no earlier than 2002-12-16 | S1 | 1040h | 1040h | Rel-6 |  |  |  |  | 22.800 |  |  |  |
| 1025 | 301.13 | IMS charging |  | 455d? | 2003-03-21 A | 2004-12-16 A | 100% | 2003-03-21 | 2004-12-16 | 455d? | finish no earlier than 2004-12-16 | S5 | 3640h | 3640h | Rel-6 |  |  | IMS2-CH | TSG | 32.260 |  |  |  |
| 1026 | 301.14 | IMS Management objects |  | 306d? | 2004-09-03 A | 2005-11-05 A | 100% | 2004-09-03 | 2005-11-05 | 306d? | finish no earlier than 2005-03-04 | N1 | 2448h | 2448h | Rel-6 |  |  |  | WG | TS 24.167 |  |  |  |
| 1027 | 301.15 | Deleted - Stage 2 of IMS Phase 2 | milestone | 0d? | 2003-09-19 A | 2003-09-19 A | 100% | 2003-09-19 | 2003-09-19 | 0d? | finish no earlier than 2003-09-19 | S2 |  |  | Rel-6 |  |  |  |  |  |  |  | SP-24 |

Notes:
- 1002: Depends on CN decision on IETF dependencies in Rel-6. Higher figure if CPCP is dropped (-> LS to CN plenary)
- 1009: Updated according to SP-040232
- 1015: [DAB 14.02.02] - end date pushed back to March 2003
- 1016: [DAB - 20.08.03] - CN Part of TR Complete @ CN#20
- 1020: [DAB - 25.05.04] - CN3 consider this work to be complete
- 1021: TISPAN issue is open
- 1025: SA#26 12/2004 completed

| ID | WBS | Task | Type | Duration | Start | Finish | Complete | Baseline start | Baseline finish | Baseline duration | Constraint | Resources | Work | Actual work | Text1 | Text3 | Text4 | Text6 | Text7 | Text8 | Text10 | Text5 | Text2 | Text9 |
| --- | --- | --- | --- | --- | --- | --- | --- | --- | --- | --- | --- | --- | --- | --- | --- | --- | --- | --- | --- | --- | --- | --- | --- | --- |
| 1028 | 302 | **3GPP Enablers for services like Push to Talk over Cellular (PoC)** |  | 459d? | 2003-09-08 A | 2005-06-09 A | 100% | 2003-09-08 | 2005-06-09 | 459d? |  | S2 | 10696h | 10696h | PoC | 23.979 | Shabnam Sultana, Ericsson | Rel-6 | TSG | Sang-Ui |  |  |  |  |
| 1029 | 302.1 | Feasibility Study |  | 322d? | 2003-09-08 A | 2004-11-30 A | 100% | 2003-09-08 | 2004-11-30 | 322d? | finish no earlier than 2004-11-30 | S2 | 2576h | 2576h | PoC | 23.979 | Shabnam Sultana, Ericsson | Rel-6 |  |  | SP-24 |  |  |  |
| 1030 | 302.2 | Dependencies on OMA PoC |  | 303d? | 2004-01-01 A | 2005-02-28 A | 100% | 2004-01-01 | 2005-02-28 | 303d? | finish no earlier than 2004-12-30 | OMA | 2424h | 2424h | PoC |  |  | Rel-6 | n/a |  | SP-24 | OMA-LIAISON@mail.openmobilealliance.org |  |  |
| 1031 | 302.3 | Selection of one or more PoC codec(s) for PoC |  | 69d? | 2004-09-13 A | 2004-12-16 A | 100% | 2004-09-13 | 2004-12-16 | 69d? | start no earlier than 2004-09-13 | S4 | 552h | 552h | PoC | 26.235, 26.236 |  | Rel-6 | TSG | Paolo | SP-25 |  |  |  |
| 1032 | 302.4 | PoC charging |  | 184d? | 2004-09-27 A | 2005-06-09 A | 100% | 2004-09-27 | 2005-06-09 | 184d? | finish no earlier than 2005-06-09 | S5 | 1472h | 1472h | PoC-CH | 32.272 |  | Rel-6 | TSG |  |  |  |  |  |
| 1033 | 303 | Interworking aspects and migration scenarios for IPv4 based IMS Implementations (Study) |  | 210d? | 2003-09-08 A | 2004-06-25 A | 100% | 2003-09-08 | 2004-06-25 | 210d? | finish no earlier than 2004-06-25 | S2 | 1680h | 1680h | IPv4IMS | 23.881 | Alexander Milinski, Siemens | Rel-6 |  | Sang-Ui |  |  |  |  |
| 1034 | 16.3 | **Interoperability and Commonality between IMS using different "IP-connectivity Networks"** |  | 325d? | 2002-09-16 A | 2003-12-12 A | 100% | 2002-09-16 | 2003-12-12 | 325d? |  | S2 | 9176h | 9176h | IMSCOOP | 23.864 |  | Rel-6 | TSG | Sang-Ui |  |  |  |  |
| 1035 | 16.3.1 | Stage 2 for Interoperability |  | 272d | 2002-09-16 A | 2003-09-30 A | 100% | 2002-09-16 | 2003-09-30 | 272d | finish no earlier than 2003-09-30 | S2 | 2176h | 2176h |  | 23.864 | Balazs Beternyi, Nokia | Rel-6 |  |  |  |  |  |  |
| 1036 | 304.2 | Stage 2 for commonality |  | 265d? | 2002-09-16 A | 2003-09-19 A | 100% | 2002-09-16 | 2003-09-19 | 265d? | start no earlier than 2002-09-16 | S2 | 2120h | 2120h |  | 23.864 | Balazs Beternyi, Nokia | Rel-6 |  |  |  |  |  |  |
| 1037 | 16.3.2 | Stage 3 |  | 305d | 2002-10-14 A | 2003-12-12 A | 100% | 2002-10-14 | 2003-12-12 | 305d | finish no earlier than 2003-12-12 | N1 | 2440h | 2440h |  |  | Keith Drage, Lucent | Rel-6 |  |  |  | drage@lucent.com |  |  |
| 1038 | 17 | **Support of Push Services** |  | 823d | 2001-01-03 A | 2004-02-27 A | 100% | 2001-01-03 | 2004-02-27 | 823d |  | S1 | 11390.6h | 11390.6h | PUSH | 23.976 | Yoshinori Kitada, NTT Comware | Rel-6 | TSG | Sang-Ui |  |  | CCaR | 1365 |
| 1039 | 17.1 | Stage 1 |  | 378d | 2001-01-03 A | 2002-06-14 A | 100% | 2001-01-03 | 2002-06-14 | 378d | finish no earlier than 2002-06-14 | S1 | 3024h | 3024h |  |  |  | Rel-6 |  |  |  |  |  |  |
| 1040 | 17.3 | TR 23.976 on Push Architecture |  | 340d | 2002-11-11 A | 2004-02-27 A | 100% | 2002-11-11 | 2004-02-27 | 340d | finish no earlier than 2004-02-27 | S2 | 2720h | 2720h |  | 23.976 | Nick Alfano, RIM | Rel-6 |  |  |  |  |  |  |
| 1041 | 18 | **Multimedia Messaging (MMS) enhancements** |  | 865d? | 2002-08-15 A | 2005-12-07 A | 100% | 2002-08-15 | 2005-12-07 | 865d? |  | T2 | 31936h | 31936h | MMS6 |  | Josef Laumen, Siemens | Rel-6 | TSG | Friedhelm |  | Josef.Laumen@SAL.SIEMENS.DE | Mes |  |
| 1042 | 18.1 | **Definition of service requirements** |  | 286d? | 2002-11-15 A | 2003-12-19 A | 100% | 2002-11-15 | 2003-12-19 | 286d? |  | S1 | 4576h | 4576h | MMS6-SR | 22.140 |  | Rel-6 |  |  |  |  |  |  |
| 1043 | 306.1.1 | Definition of service requirements charging |  | 286d? | 2002-11-15 A | 2003-12-19 A | 100% | 2002-11-15 | 2003-12-19 | 286d? | finish no earlier than 2003-12-20 | S1 | 2288h | 2288h |  | 22.140 | Josef Laumen, Siemens | Rel-6 |  |  |  | Josef.Laumen@SAL.SIEMENS.DE |  |  |
| 1044 | 18.2 | Technical realization |  | 591d | 2002-09-06 A | 2004-12-10 A | 100% | 2002-09-06 | 2004-12-10 | 591d | finish no earlier than 2004-12-10 | T2 | 4728h | 4728h |  | 23.140 | Josef Laumen, Siemens | Rel-6 | TSG | Friedhelm |  | Josef.Laumen@SAL.SIEMENS.DE |  |  |
| 1045 | 18.3 | OMA dependencies |  | 446d | 2003-08-15 A | 2005-04-29 A | 100% | 2003-08-15 | 2005-04-29 | 446d | finish no earlier than 2004-12-10 | OMA | 3568h | 3568h |  | OMA specs |  | Rel-6 | n/a | Friedhelm |  |  |  |  |
| 1046 | 18.4 | MMS formats and codecs |  | 865d | 2002-08-15 A | 2005-12-07 A | 100% | 2002-08-15 | 2005-12-07 | 865d | finish no earlier than 2005-12-07 | S4 | 6920h | 6920h | MMS6-Codec | 26.140, 26.936 | Roberto Castagno (Nokia) | Rel-6 |  | Paolo |  | roberto.castagno@nokia.com |  |  |
| 1047 | 306.5 | Handling of private addressing schemes in MMS |  | 263d | 2003-12-10 A | 2004-12-10 A | 100% | 2003-12-10 | 2004-12-10 | 263d | finish no earlier than 2004-12-10 | T2 | 2104h | 2104h |  | 23.140 | Steffen Habermann, T-Mobile | Rel-6 | TSG | Friedhelm |  | Steffen.Habermann@T-MOBILE.DE |  |  |
| 1048 | 306.6 | MMS charging |  | 390d? | 2003-03-21 A | 2004-09-16 A | 100% | 2003-03-21 | 2004-09-16 | 390d? | start no earlier than 2003-03-21 | S5 | 3120h | 3120h | MMS6-CH | 32.270 |  | Rel-6 | TSG |  |  |  |  |  |
| 1049 | 306.7 | Deleted - FS Multiple MMS Relay/Server Architecture | milestone | 0d | 2004-12-10 A | 2004-12-10 A | 100% | 2004-12-10 | 2004-12-10 | 0d | finish no earlier than 2004-12-10 | T2 |  |  |  | probably Annex to 23.140 | Juan Gorospe, Telefónica Móviles | Rel-6 | TSG | Friedhelm |  | gorospe_j@tsm.es |  |  |
| 1050 | 19 | **Rel-6 MExE enhancements** |  | 326d | 2002-03-08 A | 2003-06-06 A | 100% | 2002-03-08 | 2003-06-06 | 326d |  | T2 | 7328h | 7328h | MEXE6 |  |  | Rel-6 | TSG | Friedhelm |  |  | Ter |  |
| 1051 | 19.1 | MExE Rel-6 Improvements and Investigations |  | 264d | 2002-03-08 A | 2003-03-12 A | 100% | 2002-03-08 | 2003-03-12 | 264d | finish no earlier than 2003-03-12 | T2 | 2112h | 2112h | MEXE6-ENHANC | 22.057, 23.057 | Lars Brenk (TTPCom) | Rel-6 | TSG |  |  | lsb_ttpcom@HOTMAIL.COM | Ter |  |
| 1052 | 19.2 | MExE Run-Time Independent Framework Feasibility Study |  | 326d | 2002-03-08 A | 2003-06-06 A | 100% | 2002-03-08 | 2003-06-06 | 326d | finish no earlier than 2003-06-06 | T2 | 2608h | 2608h | MEXE6-RTIF | 22.857 | Aaron Cohen (Intel) | Rel-6 | TSG |  |  | Aaron.Cohen@intel.com | Ter |  |
| 1053 | 21 | Subscription Management |  | 650d | 2002-09-20 A | 2005-03-17 A | 100% | 2002-09-20 | 2005-03-17 | 650d | finish no earlier than 2005-03-17 | S5 | 5200h | 5200h | SuM | 32.140/1, 32.171/2/5, 32.803 | Istvan ABA (T-Mobile Austria) | Rel-6 | TSG | Adrian |  | istvan.aba@t-mobile.at |  |  |

Notes:
- 1030: Updated according to SP-040232
- 1031: Completed
- 1032: SA#28 06/2005 completed
- 1035: No contributions assumed that no more will be done in 3GPP hence work may need to be done in 3GPP2
- 1038: AS: Changed from FS to actual support of Push
- 1048: SA#25 09/2004 completed
- 1049: originally it was intended to create a FS TR but most likely the work will become an Annex of 23.140
- 1053: SA#27 03/2005 completed

| ID | WBS | Task | Duration | Start | Finish | Complete | Remaining | Baseline start | Baseline finish | Baseline duration | Total slack | Constraint | Resources | Work | Actual work | Text1 | Text4 | Text6 | Text7 | Text8 | Text9 | Text3 | Text5 |
| --- | --- | --- | --- | --- | --- | --- | --- | --- | --- | --- | --- | --- | --- | --- | --- | --- | --- | --- | --- | --- | --- | --- | --- |
| 1054 | 22 | **Presence Capability** | 1233d? | 2001-03-19 A | 2005-12-07 | 99% | 2.86d? | 2001-03-19 | 2005-12-07 | 1233d? | 1057d |  | S1 | 37112h | 35973.5h | PRESNC | Mark Cataldo, Motorola | Rel-6 | TSG | Michael | 11004 |  |  |
| 1055 | 22.1 | Stage 1 | 610d | 2001-03-19 A | 2003-07-18 A | 100% |  | 2001-03-19 | 2003-07-18 | 610d |  | finish no earlier than 2003-07-18 | S1 | 4880h | 4880h |  |  | Rel-6 |  |  | 11005 | 22.141 |  |
| 1056 | 22.2 | Stage 2 | 268d | 2001-09-12 A | 2002-09-20 A | 100% |  | 2001-09-12 | 2002-09-20 | 268d |  | finish no earlier than 2002-09-20 | S2 | 2144h | 2144h |  | Balazs BERTENYI, Nokia | Rel-6 | TSG |  |  |  | Balazs.Bertenyi@nokia.com |
| 1057 | 22.3 | Stage 3 | 703d | 2002-04-01 A | 2004-12-08 A | 100% |  | 2002-04-01 | 2004-12-08 | 703d |  | finish no earlier than 2004-12-08 | N1 | 5624h | 5624h |  | Keith Drage, Lucent | Rel-6 |  |  |  |  | drage@lucent.com |
| 1058 | 309.4 | Stage 3 (CN3 Part Pk interface) | 770d? | 2002-04-01 A | 2005-03-11 A | 100% |  | 2002-04-01 | 2005-03-11 | 770d? |  | finish no earlier than 2005-03-11 | N3 | 6160h | 6160h |  |  | Rel-6 |  |  |  |  |  |
| 1059 | 309.5 | Media Codecs and Formats for IMS Messaging and Presence | 650d? | 2003-06-12 A | 2005-12-07 A | 100% |  | 2003-06-12 | 2005-12-07 | 650d? |  | finish no earlier than 2005-12-07 | S4 | 5200h | 5200h | PRESNC-COFIMP | Harri Honko (Nokia) | Rel-6 | TSG | Paolo |  | TS 26.141, TR 26.936 | harri.honko@nokia.com |
| 1060 | 22.4 | Security issues | 79d | 2002-08-26 A | 2002-12-12 | 90% | 7.9d | 2002-08-26 | 2002-12-12 | 79d | 1836d | finish no earlier than 2002-12-12 | S3 | 632h | 568.8h |  |  | Rel-6 |  |  |  |  |  |
| 1061 | 309.7 | SIMPLE Presence | 326d? | 2004-01-01 A | 2005-03-31 A | 100% |  | 2004-01-01 | 2005-03-31 | 326d? |  | finish no earlier than 2004-12-30 | OMA | 2608h | 2608h |  |  | Rel-6 | n/a |  |  |  | OMA-LIAISON@mail.openmobilealliance.org |
| 1062 | 25 | **Enhanced A/Gb feasibility study** | 51d? | 2002-08-30 A | 2002-11-08 A | 100% |  | 2002-08-30 | 2002-11-08 | 51d? |  |  | GP | 3264h | 3264h | AGbEnFS | J-L Carrizo, Vodafone | Rel-6 | TSG | Paolo |  |  | jose-luis.carrizo@vodafone.co.uk |
| 1063 | 25.1 | **Feasibility study on A/Gb enhancements** | 51d? | 2002-08-30 A | 2002-11-08 A | 100% |  | 2002-08-30 | 2002-11-08 | 51d? |  |  | G2 | 2856h | 2856h | AGbEnFS-FS |  | Rel-6 | TSG |  |  |  |  |
| 1064 | 25.1.1 | Requirements for the support of conversational services | 51d | 2002-08-30 A | 2002-11-08 A | 100% |  | 2002-08-30 | 2002-11-08 | 51d |  | finish no earlier than 2002-11-08 | GP | 408h | 408h |  |  | Rel-6 |  |  |  |  |  |
| 1065 | 310.1.2 | Identification of the different building blocks for the provision of conversational services on the existing A/Gb protocol stack | 51d? | 2002-08-30 A | 2002-11-08 A | 100% |  | 2002-08-30 | 2002-11-08 | 51d? |  | finish no earlier than 2002-11-08 | GP | 408h | 408h |  |  | Rel-6 |  |  |  |  |  |
| 1066 | 310.1.3 | Outline of impact and feasibility of these building blocks and their different solutions | 51d? | 2002-08-30 A | 2002-11-08 A | 100% |  | 2002-08-30 | 2002-11-08 | 51d? |  | finish no earlier than 2002-11-08 | GP | 408h | 408h |  |  | Rel-6 |  |  |  |  |  |
| 1067 | 25.1.4 | Impact on 3GPP architecture and requirement to co-ordinatge with other TSGs (CN, SA) | 51d | 2002-08-30 A | 2002-11-08 A | 100% |  | 2002-08-30 | 2002-11-08 | 51d |  | finish no earlier than 2002-11-08 | GP | 408h | 408h |  |  | Rel-6 |  |  |  |  |  |
| 1068 | 25.1.5 | Standardisation effort | 51d | 2002-08-30 A | 2002-11-08 A | 100% |  | 2002-08-30 | 2002-11-08 | 51d |  | finish no earlier than 2002-11-08 | GP | 408h | 408h |  |  | Rel-6 |  |  |  |  |  |
| 1069 | 25.1.6 | Dependency to other features | 51d | 2002-08-30 A | 2002-11-08 A | 100% |  | 2002-08-30 | 2002-11-08 | 51d |  | finish no earlier than 2002-11-08 | GP | 408h | 408h |  |  | Rel-6 |  |  |  |  |  |
| 1070 | 26 | **Flexible Layer One for GERAN** | 1170d | 2000-01-03 A | 2004-06-25 A | 100% |  | 2000-01-03 | 2004-06-25 | 1170d |  |  | GP | 71535h | 71535h | FLOGER | Benoist Sébire | Rel-6 | TSG | Paolo |  |  | benoist.sebire@nokia.com |
| 1071 | 26.1 | **Realisation of a Flexible Layer One** | 1125d | 2000-01-03 A | 2004-04-23 A | 100% |  | 2000-01-03 | 2004-04-23 | 1125d |  |  | GP | 42808h | 42808h | FLOGER-Real | Benoist Sébire | Rel-6 |  |  |  |  | benoist.sebire@nokia.com |
| 1072 | 26.1.1 | Technical Report | 471d | 2002-04-19 A | 2004-02-06 A | 100% |  | 2002-04-19 | 2004-02-06 | 471d |  | finish no earlier than 2004-02-06 | GP | 3768h | 3768h |  |  | Rel-6 |  |  |  |  |  |
| 1073 | 26.1.2 | Architecture in 45.001 and 43.051 | 526d | 2002-04-19 A | 2004-04-23 A | 100% |  | 2002-04-19 | 2004-04-23 | 526d |  | finish no earlier than 2004-04-23 | G1 | 4208h | 4208h |  |  | Rel-6 |  |  |  |  |  |
| 1074 | 26.1.3 | Multiplexing in 45.002 | 526d | 2002-04-19 A | 2004-04-23 A | 100% |  | 2002-04-19 | 2004-04-23 | 526d |  | finish no earlier than 2004-04-23 | G1 | 4208h | 4208h |  |  | Rel-6 |  |  |  |  |  |
| 1075 | 26.1.4 | Channel Coding in 45.003 | 526d | 2002-04-19 A | 2004-04-23 A | 100% |  | 2002-04-19 | 2004-04-23 | 526d |  | finish no earlier than 2004-04-23 | G1 | 4208h | 4208h |  |  | Rel-6 |  |  |  |  |  |
| 1076 | 26.1.5 | Performance Requirements in 45.005 | 1125d | 2000-01-03 A | 2004-04-23 A | 100% |  | 2000-01-03 | 2004-04-23 | 1125d |  | finish no earlier than 2004-04-23 | G1 | 9000h | 9000h |  |  | Rel-6 |  |  |  |  |  |
| 1077 | 26.1.6 | Radio subsystem link control in 45.008 | 526d | 2002-04-19 A | 2004-04-23 A | 100% |  | 2002-04-19 | 2004-04-23 | 526d |  | finish no earlier than 2004-04-23 | G1 | 4208h | 4208h |  |  | Rel-6 |  |  |  |  |  |
| 1078 | 26.1.7 | Requirements in 44.004 | 526d | 2002-04-19 A | 2004-04-23 A | 100% |  | 2002-04-19 | 2004-04-23 | 526d |  | finish no earlier than 2004-04-23 | G2 | 4208h | 4208h |  |  | Rel-6 |  |  |  |  |  |

Notes:
- 1054: A Sultan merged "Presence Service Enhancements" (UID31028, PRES1) to this feature as no answer was provided on why Presence and Presence Encmts had same target completion date
- 1057: Dependency to 2 IETF drafts, no known work at the moment
- 1058: No Contributions so far - only requires a little work
- 1060: LSs handled in SA3. WID approved SA#17 Contribution at S3#25 & following e-mail discussion.
- 1061: Updated according to SP-040232
- 1062: Closed
- 1070: Nokia, Ericsson, Siemens, Telia
- 1071: Completed

| ID | WBS | Task | Type | Duration | Start | Finish | Complete | Baseline start | Baseline finish | Baseline duration | Constraint | Resources | Work | Actual work | Text1 | Text4 | Text5 | Text6 | Text3 | Text8 | Text7 | Text9 | Text12 |
| --- | --- | --- | --- | --- | --- | --- | --- | --- | --- | --- | --- | --- | --- | --- | --- | --- | --- | --- | --- | --- | --- | --- | --- |
| 1079 | 26.2 | **Signalling and protocol support for a Flexible Layer One** |  | 571d | 2002-04-19 A | 2004-06-25 A | 100% | 2002-04-19 | 2004-06-25 | 571d |  | G2 | 13704h | 13704h | FLOGER-SigPro | Benoist Sébire | benoist.sebire@nokia.com | Rel-6 |  |  |  |  |  |
| 1080 | 26.2.1 | Modifications to RLC/MAC in 44.060 and 44.160 |  | 571d | 2002-04-19 A | 2004-06-25 A | 100% | 2002-04-19 | 2004-06-25 | 571d | finish no earlier than 2004-06-25 | G2 | 4568h | 4568h |  |  |  | Rel-6 |  |  |  |  |  |
| 1081 | 26.2.2 | Modifications to RRC in 44.118 and 44.018 |  | 571d | 2002-04-19 A | 2004-06-25 A | 100% | 2002-04-19 | 2004-06-25 | 571d | finish no earlier than 2004-06-25 | G2 | 4568h | 4568h |  |  |  | Rel-6 |  |  |  |  |  |
| 1082 | 26.3 | **Security for a Flexible Layer One** |  | 356d | 2002-04-19 A | 2003-08-29 A | 100% | 2002-04-19 | 2003-08-29 | 356d |  | S3, G2 | 5663.03h | 5663.03h | FLOGER-SecFLO | Benoist Sébire | benoist.sebire@nokia.com | Rel-6 |  |  |  |  |  |
| 1083 | 26.3.1 | Ciphering in 44.160,44.118, 44.060 and 44.018 |  | 356d | 2002-04-19 A | 2003-08-29 A | 100% | 2002-04-19 | 2003-08-29 | 356d | finish no earlier than 2003-08-29 | S3, G2 | 2848h | 2848h |  |  |  | Rel-6 |  |  |  |  |  |
| 1084 | 26.4 | **Deleted at TSG#27 - GERAN MS Conformance test for the Flexible Layer One - DELETE** |  | 0d | 2004-02-06 A | 2004-02-06 A | 100% | 2004-02-06 | 2004-02-06 | 0d |  | G4; G5 |  |  | FLOGER-Msconf | Benoist Sébire | benoist.sebire@nokia.com | Rel-6 |  |  |  |  |  |
| 1085 | 26.4.1 | deleted at TSG #27 - MS Test in 51.010 | milestone | 0d | 2004-02-06 A | 2004-02-06 A | 100% | 2004-02-06 | 2004-02-06 | 0d | finish no earlier than 2004-02-06 | G4; G5 |  |  |  |  |  | Rel-6 |  |  |  |  |  |
| 1086 | 26.5 | **Deleted at TSG#27 - GERAN BTS Conformance test for the Flexible Layer One - DELETE** |  | 0d | 2004-02-06 A | 2004-02-06 A | 100% | 2004-02-06 | 2004-02-06 | 0d |  | G3 |  |  | FLOGER-BTSconf | Benoist Sébire | benoist.sebire@nokia.com | Rel-6 |  |  |  |  |  |
| 1087 | 26.5.1 | Deleted at TGS #27 - BTS Test in 51.021 - DELETE | milestone | 0d | 2004-02-06 A | 2004-02-06 A | 100% | 2004-02-06 | 2004-02-06 | 0d | finish no earlier than 2004-02-06 | G3 |  |  |  |  |  | Rel-6 |  |  |  |  |  |
| 1088 | 27 | Uplink TDOA feasibility study |  | 151d | 2001-11-30 A | 2002-06-28 A | 100% | 2001-11-30 | 2002-06-28 | 151d | finish no earlier than 2002-06-28 | GP | 1208h | 1208h | TDOAF | Bob Gross, TruePosition, Inc. | rlgross@trueposition.com | Rel-6 | 45.811 | Paolo |  |  |  |
| 1089 | 28 | **Multimedia Broadcast and Multicast Service** |  | 1781d? | 2001-05-11 A | 2008-03-07 A | 100% | 2001-05-11 | 2008-03-07 | 1781d? |  | S1 | 158281h | 158281h | MBMS |  |  | Rel-6 |  | Michael | TSG |  |  |
| 1090 | 28.1 | Stage 1 |  | 232d | 2001-05-11 A | 2002-04-01 A | 100% | 2001-05-11 | 2002-04-01 | 232d | finish no earlier than 2002-04-01 | S1 | 1856h | 1856h |  |  |  | Rel-6 | 22.146, 22.101 |  |  | 11003 |  |
| 1091 | 28.2 | **Stage 2** |  | 648d | 2001-09-24 A | 2004-03-17 A | 100% | 2001-09-24 | 2004-03-17 | 648d |  | S2 | 10408h | 10408h |  |  |  | Rel-6 |  |  | TSG |  |  |
| 1092 | 28.2.1 | TR on Architectural Study |  | 240d | 2001-09-24 A | 2002-08-23 A | 100% | 2001-09-24 | 2002-08-23 | 240d | finish no earlier than 2002-08-23 | S2 | 1920h | 1920h |  |  |  | Rel-6 | 23.846 |  |  |  |  |
| 1093 | 28.2.2 | Stage 2 Specification Work |  | 413d | 2002-08-19 A | 2004-03-17 A | 100% | 2002-08-19 | 2004-03-17 | 413d | finish no earlier than 2004-03-17 | S2 | 3304h | 3304h |  |  |  | Rel-6 | 23.246 |  |  |  |  |
| 1094 | 28.3 | **Introduction of MBMS in RAN** |  | 967d? | 2002-01-01 A | 2005-09-15 A | 100% | 2002-01-01 | 2005-09-15 | 967d? |  | R2 | 15992h | 15992h | MBMS-RAN | Juho Pirskanen , Nokia | juho.pirskanen@nokia.com | Rel-6 | TS 25.346, TS 25.304, 25.321, 25.322, 25.323, 25.331 | MCC_RAN | TSG | 2481 |  |
| 1095 | 313.3.1 | Introduction of MBMS in RAN (physical & upper layers, access network interfaces) |  | 771d? | 2002-01-01 A | 2004-12-14 A | 100% | 2002-01-01 | 2004-12-14 | 771d? | finish no earlier than 2004-12-14 | R2 | 6168h | 6168h | MBMS-RAN | Juho Pirskanen , Nokia | juho.pirskanen@nokia.com | Rel-6 | TS 25.346, TS 25.304, 25.321, 25.322, 25.323 | MCC_RAN | TSG |  |  |
| 1096 | 313.3.2 | UE Performance Requirements for MBMS |  | 261d? | 2004-09-15 A | 2005-09-15 A | 100% | 2004-09-15 | 2005-09-15 | 261d? | finish no earlier than 2005-09-15 | R4 | 2088h | 2088h | MBMS-RAN-RF | Torgny Palenius, Ericsson | Torgny.Palenius@ericsson.com | Rel-6 | TS25.101, TS25.133 | MCC_RAN | TSG |  |  |
| 1097 | 28.4 | Support of the MBMS in CN protocols |  | 647d | 2002-06-18 A | 2004-12-08 A | 100% | 2002-06-18 | 2004-12-08 | 647d | finish no earlier than 2004-12-08 | N1 | 5176h | 5176h |  |  |  | Rel-6 |  |  | TSG |  |  |
| 1098 | 313.5 | Gmb interface for MBMS (CN3 part) |  | 334d | 2003-08-29 A | 2004-12-08 A | 100% | 2003-08-29 | 2004-12-08 | 334d | finish no earlier than 2004-12-08 | N3 | 2672h | 2672h |  |  |  | Rel-6 | 29.061 |  |  |  |  |
| 1099 | 28.5 | Security Aspects of MBMS |  | 710d | 2002-07-01 A | 2005-03-18 A | 100% | 2002-07-01 | 2005-03-18 | 710d | finish no earlier than 2005-03-18 | S3 | 5680h | 5680h | MBMS | Escott, Adrian, 3 | adrian.escott@three.co.uk | Rel-6 |  |  | TSG |  |  |
| 1100 | 28.6 | **Support of MBMS in GERAN** |  | 892d? | 2001-08-30 A | 2005-01-28 A | 100% | 2001-08-30 | 2005-01-28 | 892d? |  | GP | 71040h | 71040h | MBMS-GERAN |  |  | Rel-6 |  |  | TSG |  |  |
| 1101 | 28.6.1 | Impact on the logical and physical channels |  | 631d | 2002-08-30 A | 2005-01-28 A | 100% | 2002-08-30 | 2005-01-28 | 631d | finish no earlier than 2005-01-28 | GP | 5048h | 5048h |  |  |  | Rel-6 |  |  |  |  |  |
| 1102 | 28.6.4 | Re-synchronisation at cell change |  | 631d | 2002-08-30 A | 2005-01-28 A | 100% | 2002-08-30 | 2005-01-28 | 631d | finish no earlier than 2005-01-28 | G2 | 5048h | 5048h |  |  |  | Rel-6 |  |  |  |  |  |
| 1103 | 313.7.3 | Simultaneous support of MBMS services |  | 631d? | 2002-08-30 A | 2005-01-28 A | 100% | 2002-08-30 | 2005-01-28 | 631d? | finish no earlier than 2005-01-28 | GP | 5048h | 5048h |  |  |  | Rel-6 |  |  |  |  |  |
| 1104 | 313.7.4 | Simultaneous support of MBMS and non-MBMS services |  | 892d? | 2001-08-30 A | 2005-01-28 A | 100% | 2001-08-30 | 2005-01-28 | 892d? | finish no earlier than 2005-01-28 | GP | 7136h | 7136h |  |  |  | Rel-6 |  |  |  |  |  |
| 1105 | 313.7.5 | Resynchronisation at cell change |  | 892d? | 2001-08-30 A | 2005-01-28 A | 100% | 2001-08-30 | 2005-01-28 | 892d? | finish no earlier than 2005-01-28 | GP | 7136h | 7136h |  |  |  | Rel-6 |  |  |  |  |  |
| 1106 | 28.6.5 | Decision making process between point-to-point or pont-to-multipoint configurations |  | 631d | 2002-08-30 A | 2005-01-28 A | 100% | 2002-08-30 | 2005-01-28 | 631d | finish no earlier than 2005-01-28 | GP | 5048h | 5048h |  |  |  | Rel-6 |  |  |  |  |  |
| 1107 | 28.6.6 | MBMS channel allocations procedures to multiple MSs |  | 631d | 2002-08-30 A | 2005-01-28 A | 100% | 2002-08-30 | 2005-01-28 | 631d | finish no earlier than 2005-01-28 | GP | 5048h | 5048h |  |  |  | Rel-6 |  |  |  |  |  |
| 1108 | 28.6.7 | Changes to the Gb interface |  | 631d | 2002-08-30 A | 2005-01-28 A | 100% | 2002-08-30 | 2005-01-28 | 631d | finish no earlier than 2005-01-28 | GP | 5048h | 5048h |  |  |  | Rel-6 |  |  |  |  |  |
| 1109 | 28.6.8 | GERAN specific changes to the Iu-ps interface |  | 631d | 2002-08-30 A | 2005-01-28 A | 100% | 2002-08-30 | 2005-01-28 | 631d | finish no earlier than 2005-01-28 | GP | 5048h | 5048h |  |  |  | Rel-6 |  |  |  |  |  |
| 1110 | 28.6.9 | Interaction between MBMS and Iu-flex |  | 631d | 2002-08-30 A | 2005-01-28 A | 100% | 2002-08-30 | 2005-01-28 | 631d | finish no earlier than 2005-01-28 | GP | 5048h | 5048h |  |  |  | Rel-6 |  |  |  |  |  |
| 1111 | 28.6.10 | Security aspects |  | 631d | 2002-08-30 A | 2005-01-28 A | 100% | 2002-08-30 | 2005-01-28 | 631d | finish no earlier than 2005-01-28 | GP | 5048h | 5048h |  |  |  | Rel-6 |  |  |  |  |  |
| 1112 | 313.7.12 | MS conformance tests- G3 |  | 786d? | 2002-01-25 A | 2005-01-28 A | 100% | 2002-01-25 | 2005-01-28 | 786d? | finish no earlier than 2005-01-28 | G3 | 6288h | 6288h |  |  |  | Rel-6 |  |  |  |  |  |
| 1113 | 313.7.13 | Deleted - MS conformance tests - G5 | milestone | 0d? | 2003-06-27 A | 2003-06-27 A | 100% | 2003-06-27 | 2003-06-27 | 0d? | start no earlier than 2003-06-27 | G5 |  |  |  |  |  | Rel-6 |  |  |  |  | GP-19 |

Notes:
- 1079: Completed
- 1082: Started
- 1084: DELETE
- 1085: DELETE
- 1086: DELETE
- 1087: DELETE
- 1089: Title renamed at SA#13
- 1090: This may or may not be a separate stage 1. In the meantime, CRs are proposed for 22.101
- 1095: Was "Introduction of MBMS in RAN" before RP#25. Created w/o WIDS after RAN approved the WT for RF aspects.Take WIDS from the parent BB
- 1096: Approved at RP#25 as RP-040370
- 1099: WID approved SA#17. 2004-12: Expected completion March 2005
- 1100: Completed
- 1112: Under evaluation

| ID | WBS | Task | Type | Duration | Start | Finish | Complete | Baseline start | Baseline finish | Baseline duration | Constraint | Deadline | Resources | Work | Actual work | Text6 | Text8 | Text9 | Text1 | Text4 | Text5 | Text7 | Text10 | Text12 |
| --- | --- | --- | --- | --- | --- | --- | --- | --- | --- | --- | --- | --- | --- | --- | --- | --- | --- | --- | --- | --- | --- | --- | --- | --- |
| 1114 | 28.1 | **MBMS User Services** |  | 743d? | 2003-05-13 A | 2006-03-16 A | 100% | 2003-05-13 | 2006-03-16 | 743d? |  |  | S1 | 13576h | 13576h | Rel-6 | Michael | 11003 |  |  |  |  |  |  |
| 1115 | 28.1 | MBMS User Services Stage 1 |  | 233d | 2003-05-13 A | 2004-04-01 A | 100% | 2003-05-13 | 2004-04-01 | 233d | start no earlier than 2003-05-13 |  | S1 | 1864h | 1864h | Rel-6 | Michael | 11003 |  |  |  |  |  |  |
| 1116 | 313.8.2 | Definition of MBMS user services, media codecs, formats and transport/application protocols using MBMS |  | 721d? | 2003-06-12 A | 2006-03-16 A | 100% | 2003-06-12 | 2006-03-16 | 721d? | finish no earlier than 2006-03-16 |  | S4 | 5768h | 5768h | Rel-6 | Paolo |  | MBMS-TSMBMS | Igor Curcio (Nokia) | igor.curcio@nokia.com | TSG |  |  |
| 1117 | 313.9 | MBMS charging |  | 108d? | 2005-01-11 A | 2005-06-09 A | 100% | 2005-01-11 | 2005-06-09 | 108d? | start no earlier than 2005-01-11 |  | S5 | 864h | 864h | Rel-6 |  |  | MBMS-CH |  |  | TSG |  |  |
| 1118 | 313.10 | **MBMS UE Conformance Testing** |  | 521d? | 2006-03-10 A | 2008-03-07 A | 100% | 2006-03-10 | 2008-03-07 | 521d? |  |  | R5 | 17047.2h | 17047.2h | Rel-6 | Stoyan Baev |  | MBMS-UEConTest | RAN5 |  |  |  |  |
| 1119 | 16.5.1 | RF/RRM Conformance Test Aspects – MBMS (FDD) |  | 461d | 2006-06-02 A | 2008-03-07 A | 100% | 2006-06-02 | 2008-03-07 | 461d | finish no earlier than 2008-03-07 | 2006-06-02 | R5 | 3688h | 3688h | Rel-6 | Stoyan Baev |  | MBMS-RAN-RF_Test | Leif Mattisson, Ericsson | leif.mattisson@ericsson.com |  | Fri 11/03/05 |  |
| 1120 | 313.10.2 | Conformance Test Aspects - MBMS for 3.84 Mcps and 7.68 Mcps TDD |  | 318d? | 2006-09-20 A | 2007-12-07 A | 100% | 2006-09-20 | 2007-12-07 | 318d? | finish no earlier than 2007-12-07 |  | R5 | 2544h | 2544h | Rel-6 | Stoyan Baev |  | MBMS-UEConTest_TDH | Timothy Speight, IPWireless | tspeight@ipwireless.com |  |  |  |
| 1121 | 313.10.3 | Signalling Conformance Test Aspects – MBMS for LCR TDD |  | 318d? | 2006-09-20 A | 2007-12-07 A | 100% | 2006-09-20 | 2007-12-07 | 318d? | finish no earlier than 2007-12-07 |  | R5 | 2544h | 2544h | Rel-6 | Stoyan Baev |  | MBMS-UEConTest_SIGTDL | Zhao Jian, DATANG MOBILE | zhaojian@datangmobile.cn |  |  |  |
| 1122 | 313.10.4 | Conformance Test Aspects – MBMS |  | 396d? | 2006-03-10 A | 2007-09-14 A | 100% | 2006-03-10 | 2007-09-14 | 396d? | finish no earlier than 2007-09-14 |  | R5 | 3168h | 3168h | Rel-6 | Stoyan Baev |  | MBMS_Test | Shubhang Vora, Qualcomm Europe S.A.R.L. | svora@qualcomm.com |  |  |  |
| 1123 | 16.5.1 | Conformance Test Aspects - 1.28Mcps TDD MBMS RF/RRM |  | 136d | 2007-06-01 A | 2007-12-07 A | 100% | 2007-06-01 | 2007-12-07 | 136d | finish no earlier than 2007-12-07 | 2006-06-02 | R5 | 1088h | 1088h | Rel-6 | Stoyan Baev |  | MBMS-UEConTest_RFTDL | Xiaozhong Chen, Datang Mobile | chenxiaozhong@datangmobile.cn |  | Fri 11/03/05 |  |
| 1124 | 29 | **Speech Recognition and Speech Enabled Services** |  | 1105d? | 2001-10-08 A | 2005-12-30 A | 100% | 2001-10-08 | 2005-12-30 | 1105d? |  |  | S1 | 20176h | 20176h | Rel-6 | Michael |  | SRSES |  |  | TSG |  |  |
| 1125 | 29.1 | Speech Enabled Services Based on Distributed Speech Recognition (DSR) |  | 115d | 2001-10-08 A | 2002-03-15 A | 100% | 2001-10-08 | 2002-03-15 | 115d | finish no earlier than 2002-03-15 |  | S1 | 920h | 920h | Rel-6 |  |  | DSR | D Williams, QUALCOMM, Inc. | Dwilliams@qualcomm.com | TSG |  |  |
| 1126 | 29.2 | TR on Architectural impacts |  | 212d | 2003-05-12 A | 2004-03-02 A | 100% | 2003-05-12 | 2004-03-02 | 212d | finish no earlier than 2004-03-02 |  | S2 | 1696h | 1696h | Rel-6 |  |  |  |  |  |  |  |  |
| 1127 | 314.3 | Codec Work to Support Speech Recognition Framework for Automated Voice Services |  | 568d? | 2002-10-15 A | 2004-12-16 A | 100% | 2002-10-15 | 2004-12-16 | 568d? | finish no earlier than 2004-12-16 |  | S4 | 4544h | 4544h | Rel-6 | Paolo |  | SRSES-Codec | David Pearce, Motorola | bdp003@motorola.com | WG |  |  |
| 1128 | 314.4 | Multimodal support |  | 522d? | 2004-01-01 A | 2005-12-30 A | 100% | 2004-01-01 | 2005-12-30 | 522d? | finish no earlier than 2005-06-30 |  | OMA | 4176h | 4176h | Rel-6 |  |  |  |  | OMA-LIAISON@mail.openmobilealliance.org |  | SP-24 |  |
| 1129 | 314.5 | Deleted - SES codec negotiation at SDP | milestone | 0d? | 2003-06-04 A | 2003-06-04 A | 100% | 2003-06-04 | 2003-06-04 | 0d? | start no earlier than 2003-06-04 |  | N1 |  |  | Rel-6 |  |  |  |  |  |  |  | NP-23 |
| 1130 | 30 | **Generic User Profile Rel-6** |  | 889d | 2001-10-08 A | 2005-03-03 A | 100% | 2001-10-08 | 2005-03-03 | 889d |  |  | S1 | 24295.8h | 24295.8h | Rel-6 | Michael |  | GUP |  |  | TSG |  |  |
| 1131 | 30.1 | Stage 1 - Requirements |  | 430d | 2001-10-08 A | 2003-05-30 A | 100% | 2001-10-08 | 2003-05-30 | 430d | finish no earlier than 2002-12-09 |  | S1 | 3440h | 3440h | Rel-6 |  |  |  | Kurt Bischinger (T-Mobile) | kurt.bischinger@t-mobile.at |  |  |  |
| 1132 | 30.3 | Stage 2 - Architecture |  | 355d | 2002-01-28 A | 2003-06-06 A | 100% | 2002-01-28 | 2003-06-06 | 355d | finish no earlier than 2003-06-06 |  | S2 | 2840h | 2840h | Rel-6 |  |  |  | Harri KOSKINEN, Nokia | harri.o.koskinen@nokia.com |  |  |  |
| 1133 | 30.2 | Stage 2 - Data Description Method |  | 586d | 2002-12-05 A | 2005-03-03 A | 100% | 2002-12-05 | 2005-03-03 | 586d | finish no earlier than 2005-03-03 |  | N4 | 4688h | 4688h | Rel-6 | Friedhelm |  |  | Kurt Bischinger (T-Mobile AUSTRIA) | kurt.bischinger@t-mobile.at | TSG |  |  |
| 1134 | 30.5 | Stage 3 - Network |  | 468.98d | 2003-05-19 A | 2005-03-03 A | 100% | 2003-05-19 | 2005-03-03 | 468.98d | finish no earlier than 2005-03-03 |  | N4 | 3751.83h | 3751.83h | Rel-6 |  |  |  |  |  |  |  |  |
| 1135 | 30.6 | Security Aspects |  | 308d | 2002-07-16 A | 2003-09-18 A | 100% | 2002-07-16 | 2003-09-18 | 308d | finish no earlier than 2003-09-18 |  | S3 | 2464h | 2464h | Rel-6 |  |  |  | Owen, Bradley | bvowen@lucent.com | WG |  |  |
| 1136 | 31 | **Digital Rights Management** |  | 690d? | 2001-10-08 A | 2004-05-28 A | 100% | 2001-10-08 | 2004-05-28 | 690d? |  |  | S1 | 10152h | 10152h | Rel-6 | Michael |  | DRM |  |  | TSG |  |  |
| 1137 | 31.1 | Requirements |  | 179d | 2001-10-08 A | 2002-06-13 A | 100% | 2001-10-08 | 2002-06-13 | 179d | finish no earlier than 2002-06-13 |  | S1 | 1432h | 1432h | Rel-6 |  |  |  | Nicholas Wood, Openwave Systems | nicholas.wood@openwave.com |  |  |  |
| 1138 | 316.2 | Stage 2 |  | 107d? | 2004-01-01 A | 2004-05-28 A | 100% | 2004-01-01 | 2004-05-28 | 107d? | finish no earlier than 2004-05-28 |  | OMA | 856h | 856h | Rel-6 |  |  |  |  | OMA-LIAISON@mail.openmobilealliance.org |  | SP-24 |  |
| 1139 | 316.3 | Stage 3 |  | 107d? | 2004-01-01 A | 2004-05-28 A | 100% | 2004-01-01 | 2004-05-28 | 107d? | finish no earlier than 2004-05-28 |  | OMA | 856h | 856h | Rel-6 |  |  |  |  | OMA-LIAISON@mail.openmobilealliance.org |  | SP-24 |  |
| 1140 | 31.3 | Security |  | 186d | 2002-06-17 A | 2003-03-03 A | 100% | 2002-06-17 | 2003-03-03 | 186d | finish no earlier than 2003-03-03 |  | OMA | 1488h | 1488h | Rel-6 |  |  |  |  |  |  |  |  |
| 1141 | 316.5 | Deleted - Monitoring of Stages 2 and 3 progress (actual work to be done by OMA) | milestone | 0d? | 2003-03-21 A | 2003-03-21 A | 100% | 2003-03-21 | 2003-03-21 | 0d? | start no earlier than 2002-08-19 |  | S1 |  |  | Rel-6 |  |  |  |  |  |  |  |  |

Notes:
- 1114: Text3: 22.246
- 1115: Text3: 22.246
- 1116: TR26.946 tbc by March 06 / Text3: 26.346, 26.936, 26.946
- 1117: SA#28 06/2005 completed / Text3: 32.273
- 1118: BB place holder for a number of RAN5 Tasks. Moved in from the Stoyan/Testing WP / Text3: TS 34.108, TS 34.109, TS 34.121-1, TS 34.121-2, TS 34.122, TS 34.123-1, TS 34.123-2, TS 34.123-3
- 1119: TS 34.109 is under RAN2; RAN5 need to identify possible new requirements on UE test loop functionality to enable testing / Text3: TS 34.108, TS 34.109, TS 34.121-1, TS 34.121-2
- 1120: Text3: TS 34.108, TS 34.122, TS 34.123-1, TS 34.123-2, TS 34.123-3
- 1121: Text3: TS 34.108, TS 34.123-1, TS 34.123-2, TS 34.123-3
- 1122: Text3: TS34.108, TS34.123-1, TS34.123-2, TS34.123-3
- 1123: Text3: TS 34.108, TS 34.109, TS 34.122
- 1125: Text3: 22.941, 23.207, 22.243
- 1126: Text3: 23.877
- 1127: Completed / Text3: 26.235, 26.236, 26.243, 26.177, 26.943
- 1129: Abandoned NP-23
- 1131: Text3: 22.240, 22.228
- 1132: Text3: 23.240
- 1133: TR approved in CN#26 / Text3: 23.241
- 1134: 17 May no activity in CN4............ / Text3: 29.240
- 1135: WID approved SA#17. SA WG3 progress slow, depends on progress in other groups. / Text3: 33.102, 33.203, 33.210
- 1136: Foreseen start and completion dates introduced by MCC (no indication at all on the WID)
- 1140: SA3 acknowledge role in WI at SA3#20. Active contribution S3#24, S3#25. S3 WID approved SA#17
- 1141: Replaced by UID 60005 and 60006

| ID | WBS | Task | Duration | Start | Finish | Complete | Baseline start | Baseline finish | Baseline duration | Constraint | Resources | Work | Actual work | Text1 | Text4 | Text5 | Text6 | Text7 | Text8 | Text3 | Text10 | Text9 | Text11 |
| --- | --- | --- | --- | --- | --- | --- | --- | --- | --- | --- | --- | --- | --- | --- | --- | --- | --- | --- | --- | --- | --- | --- | --- |
| 1142 | 32 | **WLAN-UMTS Interworking Rel-6** | 1494d? | 2000-01-03 A | 2005-09-22 A | 100% | 2000-01-03 | 2005-09-22 | 1494d? |  | S1 | 48464h | 48464h | WLAN | Telenor | frederic.paint@telenor.com | Rel-6 | TSG | Michael |  |  |  |  |
| 1143 | 32.1 | Technical Report | 900d? | 2000-01-03 A | 2003-06-13 A | 100% | 2000-01-03 | 2003-06-13 | 900d? | finish no earlier than 2003-06-13 | S1 | 7200h | 7200h | WLAN-TR | Telenor | frederic.paint@telenor.com | Rel-6 |  |  | 22.934, 22.101, 22.105 |  |  |  |
| 1144 | 317.2 | **Stage 1** | 375d? | 2003-01-06 A | 2004-06-11 A | 100% | 2003-01-06 | 2004-06-11 | 375d? |  | S1 | 3920h | 3920h | WLAN-TS | Telenor | frederic.paint@telenor.com | Rel-6 |  |  | 22.234 | SP-24 |  |  |
| 1145 | 317.2.1 | Global stage 1 | 375d? | 2003-01-06 A | 2004-06-11 A | 100% | 2003-01-06 | 2004-06-11 | 375d? | finish no earlier than 2004-06-11 | S1 | 3000h | 3000h | WLAN-TS | Fredric Paint, Telenor | frederic.paint@telenor.com | Rel-6 |  |  | 22.234 | SP-24 |  |  |
| 1146 | 32.2 | Architecture Definition for scenarii 2 and 3 | 571d | 2002-03-25 A | 2004-05-31 A | 100% | 2002-03-25 | 2004-05-31 | 571d | finish no earlier than 2004-05-31 | S2 | 4568h | 4568h |  |  |  | Rel-6 | TSG |  | 23.234 |  |  |  |
| 1147 | 32.3 | Security | 125d | 2002-09-30 A | 2003-03-21 A | 100% | 2002-09-30 | 2003-03-21 | 125d | finish no earlier than 2003-03-21 | S3 | 1000h | 1000h |  | Lopez-Soria, Luis, Ericsson | luis.lopez-soria@ece.ericsson.se | Rel-6 | TSG |  | 21.133, 33.106, 33.107, 33.108, 33.200, 33.203, 33.210 |  |  |  |
| 1148 | 317.5 | Stage 3 - CN4 aspects | 334d? | 2003-05-23 A | 2004-09-01 A | 100% | 2003-05-23 | 2004-09-01 | 334d? | finish no earlier than 2004-09-01 | N4 | 2672h | 2672h | WLAN-IW | Nokia | raquel.rodriguez@nokia.com | Rel-6 | TSG |  | 29.234, 29.061 |  |  |  |
| 1149 | 317.6 | Stage 3 - CN3 aspects (Wi Interface for Scenario 3) | 355d? | 2003-05-23 A | 2004-09-30 A | 100% | 2003-05-23 | 2004-09-30 | 355d? | start no earlier than 2003-05-23 | N3 | 2840h | 2840h | WLAN |  |  | Rel-6 | TSG |  | 29.161 | SP-24 |  |  |
| 1150 | 317.7 | Stage 3 for scenario 2 | 339d? | 2003-05-23 A | 2004-09-08 A | 100% | 2003-05-23 | 2004-09-08 | 339d? | finish no earlier than 2004-09-08 | N1 | 2712h | 2712h |  |  |  | Rel-6 | WG |  |  |  |  |  |
| 1151 | 317.8 | Stage 3 for scenario 3 | 404d? | 2003-05-23 A | 2004-12-08 A | 100% | 2003-05-23 | 2004-12-08 | 404d? | finish no earlier than 2004-12-08 | N1 | 3232h | 3232h |  |  |  | Rel-6 | WG |  |  | SP-24 |  |  |
| 1152 | 317.9 | WLAN charging | 655d? | 2003-03-21 A | 2005-09-22 A | 100% | 2003-03-21 | 2005-09-22 | 655d? | finish no earlier than 2005-09-22 | S5 | 5240h | 5240h | WLAN-CH | Nokia | benni.alexander@nokia.com | Rel-6 | TSG | Adrian | 32.252 |  |  |  |
| 1153 | 317.10 | USIM enhancements for WLAN Interworking | 391d? | 2003-09-05 A | 2005-03-04 A | 100% | 2003-09-05 | 2005-03-04 | 391d? | finish no earlier than 2005-03-04 | T3 | 3128h | 3128h |  | Jorge Abellan | Jabellan@axalto.com | Rel-6 | TSG |  |  |  |  |  |
| 1154 | 33 | **Priority Service** | 347d? | 2002-05-30 A | 2003-09-26 A | 100% | 2002-05-30 | 2003-09-26 | 347d? |  | S1 | 6464h | 6464h | NTShar |  |  | Rel-6 | TSG | Michael |  |  |  |  |
| 1155 | 33.1 | Feasibility Study | 1d | 2002-06-14 A | 2002-06-14 A | 100% | 2002-06-14 | 2002-06-14 | 1d | finish no earlier than 2002-06-14 | S1 | 8h | 8h | PRIOR-FS | Biplab K. Pramanik, Telcordia Technologies | bpramani@telcordia.com | Rel-6 |  | Michael | 22.950 |  |  |  |
| 1156 | 33.2 | Stage 1 - Requirements | 340d | 2002-05-30 A | 2003-09-17 A | 100% | 2002-05-30 | 2003-09-17 | 340d | finish no earlier than 2003-09-17 | S1 | 2720h | 2720h | PRIOR-SR | James J. Garrahan, Telcordia Technologies | bpramani@telcordia.com | Rel-6 |  | Michael |  |  |  |  |
| 1157 | 318.3 | Priority service implementation guide | 131d? | 2003-03-28 A | 2003-09-26 A | 100% | 2003-03-28 | 2003-09-26 | 131d? | finish no earlier than 2003-09-26 | S1 | 1048h | 1048h |  | Biplab K. Pramanik, Telcordia Technologies | bpramani@telcordia.com | Rel-6 |  |  | 22.952 |  |  |  |
| 1158 | 34 | **Network Sharing** | 498d? | 2003-01-20 A | 2004-12-15 A | 100% | 2003-01-20 | 2004-12-15 | 498d? |  | S1 | 16608h | 16608h | NTShar |  |  | Rel-6 | TSG | Michael |  |  |  |  |
| 1159 | 34.1 | Technical Report | 240d? | 2003-01-20 A | 2003-12-19 A | 100% | 2003-01-20 | 2003-12-19 | 240d? |  | S1 | 1920h | 1920h | NTShar-TR |  |  | Rel-6 |  | Michael | 22.951 |  |  |  |
| 1160 | 319.2 | Stage 1 - CRs to implement Network Sharing | 240d? | 2003-01-20 A | 2003-12-19 A | 100% | 2003-01-20 | 2003-12-19 | 240d? | finish no earlier than 2003-12-19 | S1 | 1920h | 1920h | NTShar-CR |  |  | Rel-6 |  |  | 22.011, 22.101, 22.115, 22.129 |  |  |  |
| 1161 | 319.3 | Stage 2 | 372d? | 2003-02-27 A | 2004-07-30 A | 100% | 2003-02-27 | 2004-07-30 | 372d? | finish no earlier than 2004-07-30 | S2 | 2976h | 2976h |  |  |  | Rel-6 |  |  | 23.251 |  |  |  |
| 1162 | 319.4 | Network sharing - stage 3 | 404d? | 2003-05-23 A | 2004-12-08 A | 100% | 2003-05-23 | 2004-12-08 | 404d? | finish no earlier than 2004-12-08 | N1 | 3232h | 3232h |  |  |  | Rel-6 | TSG |  |  |  |  |  |
| 1163 | 319.5 | Enhancement of the support of network sharing in the UTRAN | 324d | 2003-09-19 A | 2004-12-15 A | 100% | 2003-09-19 | 2004-12-15 | 324d | finish no earlier than 2004-12-15 | R2 | 2592h | 2592h | NTShar-UTRANEnh | Anders Dahlén, TeliaSonera | Anders.Dahlen@TeliaSonera.com | Rel-6 | TSG | MCC_RAN | TS25.401, TS25.413, TS25.331, TS25.304 |  | BB | Active |
| 1164 | 35 | **QoS Improvements** | 628d? | 2002-07-15 A | 2004-12-08 A | 100% | 2002-07-15 | 2004-12-08 | 628d? |  | S2 | 13128h | 13128h | QoS1 |  |  | Rel-6 | TSG | Sang-Ui |  |  |  |  |
| 1165 | 35.1 | FS on Dynamic Policy control enhancements for end-to-end QoS | 465d | 2002-07-15 A | 2004-04-23 A | 100% | 2002-07-15 | 2004-04-23 | 465d | finish no earlier than 2004-04-23 | S2 | 3720h | 3720h | QoS1 |  | Claire Mousset, Nortel | Rel-6 | TSG |  | 23.917 |  |  |  |
| 1166 | 320.2 | Definition of the Gq interface | 214d? | 2003-07-01 A | 2004-04-23 A | 100% | 2003-07-01 | 2004-04-23 | 214d? | finish no earlier than 2004-04-23 | S2 | 1712h | 1712h |  | Janne Rinne (Nokia) |  | Rel-6 |  |  | 23.221 |  |  |  |
| 1167 | 320.3 | Gq interface specification for Dynamic Policy control enhancements – Stage 3 | 334d | 2003-08-29 A | 2004-12-08 A | 100% | 2003-08-29 | 2004-12-08 | 334d | finish no earlier than 2004-12-08 | N3 | 2672h | 2672h |  | Anna Sillanpää, Nokia | Anna.Sillanpaai@nokia.com | Rel-6 | TSG |  | 24,228, 29.207, 29.208 |  |  |  |

Notes:
- 1147: Active contribution S3#24, S3#25. WID approved SA#17
- 1148: WID approved at CN#19...............
- 1152: SA#28: delayed 09/2005. WT also under SA5 BB 35017 Charging Management for Bearer level
- 1167: [DAB - 25.05.04] - Delayed to Sept - possibly Dec 2004

| ID | WBS | Task | Type | Duration | Start | Finish | Complete | Baseline start | Baseline finish | Baseline duration | Constraint | Resources | Work | Actual work | Text1 | Text4 | Text5 | Text6 | Text7 | Text8 | Text10 | Text12 |
| --- | --- | --- | --- | --- | --- | --- | --- | --- | --- | --- | --- | --- | --- | --- | --- | --- | --- | --- | --- | --- | --- | --- |
| 1168 | 36 | **Subscriber certificates** |  | 728d? | 2002-02-25 A | 2004-12-08 A | 100% | 2002-02-25 | 2004-12-08 | 728d? |  | S3 | 12888h | 12888h | SEC1-SC | Valtteri Niemi, Nokia | valtteri.niemi@nokia.com | Rel-6 | TSG | Maurice |  |  |
| 1169 | 36.1 | Stage 1 |  | 144d | 2002-02-25 A | 2002-09-12 A | 100% | 2002-02-25 | 2002-09-12 | 144d | finish no earlier than 2002-09-12 | S3 | 1152h | 1152h |  |  |  | Rel-6 |  |  |  |  |
| 1170 | 36.2 | Architecture review |  | 24d | 2002-10-14 A | 2002-11-14 A | 100% | 2002-10-14 | 2002-11-14 | 24d | finish no earlier than 2002-11-14 | S2 | 192h | 192h |  |  |  | Rel-6 |  |  |  |  |
| 1171 | 321.3 | Stage 3 |  | 313d? | 2003-09-19 A | 2004-11-30 A | 100% | 2003-09-19 | 2004-11-30 | 313d? | finish no earlier than 2004-11-30 | N4 | 2504h | 2504h | SEC1-SC | Lauri Laitinen, Nokia |  | Rel-6 |  | Kimmo |  |  |
| 1172 | 321.4 | Stage 3 Ua & Ub interfaces |  | 288d? | 2003-11-03 A | 2004-12-08 A | 100% | 2003-11-03 | 2004-12-08 | 288d? | finish no earlier than 2004-12-08 | N1 | 2304h | 2304h |  |  |  | Rel-6 |  |  |  |  |
| 1173 | 321.5 | OMA dependencies on Subscriber certificates |  | 114d? | 2004-01-01 A | 2004-06-08 A | 100% | 2004-01-01 | 2004-06-08 | 114d? | finish no earlier than 2004-06-08 | OMA | 912h | 912h |  |  | OMA-LIAISON@mail.openmobilealliance.org | Rel-6 | n/a |  | SP-24 |  |
| 1174 | 322 | **Rel-6 OSA enhancements** |  | 616d? | 2002-10-31 A | 2005-03-10 A | 100% | 2002-10-31 | 2005-03-10 | 616d? |  | N5 | 22576h | 22576h | OSA3 | Chelo ABARCA (Alcatel) | Chelo.Abarca@alcatel.fr | Rel-6 | TSG | Adrian |  |  |
| 1175 | 322.1 | Scope of the Open Service Access Release 6 |  | 66d? | 2003-03-28 A | 2003-06-27 A | 100% | 2003-03-28 | 2003-06-27 | 66d? | finish no earlier than 2003-06-27 | S1 | 528h | 528h |  |  |  | Rel-6 | TSG |  |  |  |
| 1176 | 322.2 | OSA Stage 2 |  | 150d? | 2004-08-13 A | 2005-03-10 A | 100% | 2004-08-13 | 2005-03-10 | 150d? | finish no earlier than 2005-03-10 | N5 | 1200h | 1200h |  |  |  | Rel-6 | TSG |  |  |  |
| 1177 | 322.3 | Multi Media Messaging function |  | 487d? | 2002-10-31 A | 2004-09-10 A | 100% | 2002-10-31 | 2004-09-10 | 487d? | finish no earlier than 2004-09-10 | N5 | 3896h | 3896h |  |  |  | Rel-6 | TSG |  |  |  |
| 1178 | 322.4 | Policy management extensions |  | 292d? | 2002-10-31 A | 2003-12-12 A | 100% | 2002-10-31 | 2003-12-12 | 292d? | finish no earlier than 2003-12-12 | N5 | 2336h | 2336h |  |  |  | Rel-6 | TSG |  |  |  |
| 1179 | 322.5 | TS on Presence and Availability Management (from the PRESNC WI) |  | 367d? | 2002-10-31 A | 2004-03-26 A | 100% | 2002-10-31 | 2004-03-26 | 367d? | finish no earlier than 2004-03-26 | N5 | 2936h | 2936h |  |  |  | Rel-6 | TSG |  |  |  |
| 1180 | 322.6 | OSA interfaces at different levels of abstractions (Parlay X, Web services) |  | 305d? | 2003-07-14 A | 2004-09-10 A | 100% | 2003-07-14 | 2004-09-10 | 305d? | finish no earlier than 2004-09-10 | N5 | 2440h | 2440h |  |  |  | Rel-6 | TSG |  |  |  |
| 1181 | 322.7 | Introduction of migration support mechanism |  | 290d? | 2002-10-31 A | 2003-12-10 A | 100% | 2002-10-31 | 2003-12-10 | 290d? | finish no earlier than 2003-12-12 | N5 | 2320h | 2320h |  |  |  | Rel-6 | TSG |  |  |  |
| 1182 | 322.8 | Framework Function for Federation |  | 225d? | 2003-02-03 A | 2003-12-12 A | 100% | 2003-02-03 | 2003-12-12 | 225d? | finish no earlier than 2003-12-12 | N5 | 1800h | 1800h |  |  |  | Rel-6 | TSG |  |  |  |
| 1183 | 322.9 | OMA potential overlaps with 3GPP OSA Stage 3 (Web services) |  | 196d? | 2003-12-18 A | 2004-09-16 A | 100% | 2003-12-18 | 2004-09-16 | 196d? | start no earlier than 2003-12-18 | OMA | 1568h | 1568h |  |  |  | Rel-6 | n/a |  | SP-24 |  |
| 1184 | 322.10 | Deleted - TR on Presence and Availability Management (from the PRESNC WI) | milestone | 0d? | 2004-09-17 A | 2004-09-17 A | 100% | 2004-09-17 | 2004-09-17 | 0d? | start no earlier than 2004-09-17 | N5 |  |  |  |  |  | Rel-6 |  |  |  | NP-24 |
| 1185 | 39 | **Addition of frequency bands to GSM (TAPS)** |  | 676d | 2002-06-28 A | 2005-01-28 A | 100% | 2002-06-28 | 2005-01-28 | 676d |  | GP | 16640h | 16640h | TAPS | Torben Themsen |  | Rel-6 | TSG | Paolo |  |  |
| 1186 | 39.1 | **Addition of frequency bands to GSM – Changes to core specs** |  | 26d | 2002-11-15 A | 2002-12-20 A | 100% | 2002-11-15 | 2002-12-20 | 26d |  | G1 | 416h | 416h | TAPS-Specs | Torben Themsen |  | Rel-6 | TSG |  |  |  |
| 1187 | 39.1.1 | Changes to core specs |  | 26d | 2002-11-15 A | 2002-12-20 A | 100% | 2002-11-15 | 2002-12-20 | 26d | finish no earlier than 2002-12-20 | G1 | 208h | 208h |  |  |  | Rel-6 |  |  |  |  |
| 1188 | 39.2 | **Deleted at TSG #27 - Addition of frequency bands to GSM – Changes for conformance tests** |  | 676d | 2002-06-28 A | 2005-01-28 A | 100% | 2002-06-28 | 2005-01-28 | 676d |  | G4 | 10816h | 10816h | TAPS-Conf | Torben Themsen |  | Rel-6 |  |  |  |  |
| 1189 | 39.2.1 | Deleted at TSG #27 - 51.010-1 Add testing |  | 676d | 2002-06-28 A | 2005-01-28 A | 100% | 2002-06-28 | 2005-01-28 | 676d | finish no earlier than 2005-01-28 | G4 | 5408h | 5408h |  |  |  | Rel-6 |  |  |  |  |
| 1190 | 40 | **Seamless support of streaming services in A/Gb mode** |  | 1425d? | 2000-01-03 A | 2005-06-17 A | 100% | 2000-01-03 | 2005-06-17 | 1425d? |  | GP | 53088h | 53088h | SSStrea | José Luis Carrizo Martínez, Vodafone |  | Rel-6 | TSG | Paolo |  |  |
| 1191 | 40.1 | **Identification of requirements for streaming** |  | 46d? | 2003-06-27 A | 2003-08-29 A | 100% | 2003-06-27 | 2003-08-29 | 46d? |  | G1 | 736h | 736h |  |  |  | Rel-6 |  |  |  |  |
| 1192 | 324.1.1 | Requirements |  | 46d? | 2003-06-27 A | 2003-08-29 A | 100% | 2003-06-27 | 2003-08-29 | 46d? | finish no earlier than 2003-08-29 | G1 | 368h | 368h |  |  |  | Rel-6 |  |  |  |  |

Notes:
- 1168: Approved at SA#14. This may require BBs from CN1, CN4, SA5 and T3 / Text3: 33.102
- 1169: Contribution received S3#24, S3#25
- 1171: Finished in CN4#26
- 1173: Updated according to SP-040420
- 1174: CN#25: Updated WID NP-040351 replaces NP-040144. / Text3: 22.127, 23.198, 29.198, 29.199, 29.998
- 1176: Inherited by CN5 from SA2 at TSG#25 Sep 2004. SA2's 23.127 (OSA/VHE Stage 2) replaced from Rel-6 onwards by a new CN5 TS 23.198 (Stage 2 OSA-only). / Text3: 23.198 OSA Stage 2-ONLY replaces 23.127 (OSA/VHE) from Rel-6 onwards
- 1177: Text3: 29.198-15
- 1178: Text3: 29.198, 29.998
- 1179: N5#26: Split WI into TS & TR. / Text3: 29.198-14
- 1180: Text3: 29.199
- 1181: Text3: 29.198, 29.998
- 1182: Text3: 29.198, 29.998
- 1183: TSG#25 Approved CN5 29.199 Parlay X Web services. Ongoing 3GPP/OMA co-ordination to avoid OMA producing conflicting/OVERLAPING specs (NP-040283/SP-040493).
- 1184: N5#26:TR Completion 09/04; consistent with CN1 delayed Rel-6 completion.
- 1186: Ready
- 1188: DELETE
- 1189: DELETE
- 1191: Started

| ID | WBS | Task | Duration | Start | Finish | Complete | Baseline start | Baseline finish | Baseline duration | Constraint | Resources | Work | Actual work | Text6 | Text3 | Text4 | Text5 | Text8 | Text1 | Text7 | Text2 |
| --- | --- | --- | --- | --- | --- | --- | --- | --- | --- | --- | --- | --- | --- | --- | --- | --- | --- | --- | --- | --- | --- |
| 1193 | 40.2 | **Performance study of cell change mechanisms** | 955d? | 2000-01-03 A | 2003-08-29 A | 100% | 2000-01-03 | 2003-08-29 | 955d? |  | G1 | 30560h | 30560h | Rel-6 |  |  |  |  |  |  |  |
| 1194 | 324.2.1 | Performance of NACC | 955d? | 2000-01-03 A | 2003-08-29 A | 100% | 2000-01-03 | 2003-08-29 | 955d? | finish no earlier than 2003-08-29 | G1 | 7640h | 7640h | Rel-6 |  |  |  |  |  |  |  |
| 1195 | 324.2.2 | Performance of cell change in DTM for the PS domain | 955d? | 2000-01-03 A | 2003-08-29 A | 100% | 2000-01-03 | 2003-08-29 | 955d? | finish no earlier than 2003-08-29 | G1 | 7640h | 7640h | Rel-6 |  |  |  |  |  |  |  |
| 1196 | 324.2.3 | Handover | 955d? | 2000-01-03 A | 2003-08-29 A | 100% | 2000-01-03 | 2003-08-29 | 955d? | finish no earlier than 2003-08-29 | G1 | 7640h | 7640h | Rel-6 |  |  |  |  |  |  |  |
| 1197 | 40.3 | **Reduction of service interruption times and packet loss during mobility procedures** | 516d? | 2003-06-27 A | 2005-06-17 A | 100% | 2003-06-27 | 2005-06-17 | 516d? |  | G2 | 10800h | 10800h | Rel-6 |  |  |  |  |  |  |  |
| 1198 | 324.3.1 | Optimisations of existing mechanisms/procedures | 106d? | 2003-06-27 A | 2003-11-21 A | 100% | 2003-06-27 | 2003-11-21 | 106d? | finish no earlier than 2003-11-21 | G2 | 848h | 848h | Rel-6 |  |  |  |  |  |  |  |
| 1199 | 324.3.2 | Inter-system NACC | 106d? | 2003-06-27 A | 2003-11-21 A | 100% | 2003-06-27 | 2003-11-21 | 106d? | finish no earlier than 2003-11-21 | G2 | 848h | 848h | Rel-6 |  |  |  |  |  |  |  |
| 1200 | 324.3.3 | PS Handover (within GERAN and between GERAN and UTRAN) | 516d? | 2003-06-27 A | 2005-06-17 A | 100% | 2003-06-27 | 2005-06-17 | 516d? | finish no earlier than 2003-11-21 | G2 | 4128h | 4128h | Rel-6 |  |  |  |  |  |  |  |
| 1201 | 324.3.4 | Dependency to other features | 106d? | 2003-06-27 A | 2003-11-21 A | 100% | 2003-06-27 | 2003-11-21 | 106d? | finish no earlier than 2003-11-21 | G2 | 848h | 848h | Rel-6 |  |  |  |  |  |  |  |
| 1202 | 40.5 | **MS conformance testing** | 31d? | 2003-12-19 A | 2004-01-30 A | 100% | 2003-12-19 | 2004-01-30 | 31d? |  | G3 | 248h | 248h | Rel-6 |  |  |  |  |  |  |  |
| 1203 | 324.4.1 | MS conformance tests | 31d? | 2003-12-19 A | 2004-01-30 A | 100% | 2003-12-19 | 2004-01-30 | 31d? | finish no earlier than 2004-01-30 | G4,G5 | 248h | 248h | Rel-6 |  |  |  |  |  |  |  |
| 1204 | 324.5 | GERAN A/Gb mode security enhancements | 612d? | 2002-09-26 A | 2005-01-28 A | 100% | 2002-09-26 | 2005-01-28 | 612d? | finish no earlier than 2005-01-28 | S3 | 4896h | 4896h | Rel-6 | 33.102 | Peter Howard, Vodafone | peter.howard@vodafone.com | Maurice |  |  |  |
| 1205 | 41 | Performance characterisation of default codecs for PS conversational multimedia application | 455d | 2002-09-13 A | 2004-06-10 A | 100% | 2002-09-13 | 2004-06-10 | 455d | finish no earlier than 2004-06-10 | S4 | 3640h | 3640h | Rel-6 | TR 26.935 | Pasi Ojala (Nokia) | pasi.s.ojala@nokia.com | Paolo | CODCAR | TSG |  |
| 1206 | 43 | Study on Privacy Capability | 83d | 2003-11-10 A | 2004-03-03 A | 100% | 2003-11-10 | 2004-03-03 | 83d | start no earlier than 2003-11-10 | S1 | 664h | 664h | Rel-6 | TR 21.949 | Liz Daniel, Lucent |  | Michael | PrivCap | TSG |  |
| 1207 | 44 | **OAM&P Rel-6** | 652d? | 2002-09-12 A | 2005-03-11 A | 100% | 2002-09-12 | 2005-03-11 | 652d? |  | S5 | 30819.5h | 30819.5h | Rel-6 | 32-series | Michael TRUSS (Motorola) | Michael.Truss@MOTOROLA.COM | Adrian | OAM | TSG |  |
| 1208 | 44.1 | Principles, high level Requirements and Architecture | 526d | 2002-09-12 A | 2004-09-16 A | 100% | 2002-09-12 | 2004-09-16 | 526d | finish no earlier than 2004-09-16 | S5 | 4208h | 4208h | Rel-6 | 32.101, 32.102 | Michael TRUSS (Motorola) | Michael.Truss@MOTOROLA.COM |  | OAM-AR | TSG | BCaM |
| 1209 | 44.2 | Performance Management | 591d | 2002-09-12 A | 2004-12-16 A | 100% | 2002-09-12 | 2004-12-16 | 591d | finish no earlier than 2004-12-16 | S5 | 4728h | 4728h | Rel-6 | 32.401/3, 52.402, 32.411/2/3, 32.432/5/6 | Christian TOCHE (Nortel Networks) | toche@NORTELNETWORKS.COM |  | OAM-PM | TSG | BCaM |
| 1210 | 44.4 | Network Infrastructure Management | 591d | 2002-09-12 A | 2004-12-16 A | 100% | 2002-09-12 | 2004-12-16 | 591d | finish no earlier than 2004-12-16 | S5 | 4728h | 4728h | Rel-6 | 32.15x, 32.3/6/7xy | Thomas TOVINGER (Ericsson) | Thomas.Tovinger@emw.ericsson.se |  | OAM-NIM | TSG |  |
| 1211 | 44.5 | **Trace Management Rel-6** | 646d? | 2002-09-20 A | 2005-03-11 A | 100% | 2002-09-20 | 2005-03-11 | 646d? |  | S5 | 12061.9h | 12061.9h | Rel-6 | 32.42x, 52.008 | Kari RÖNKÄ (Nokia) | kari.t.ronka@nokia.com |  | OAM-Trace | TSG |  |
| 1212 | 327.4.1 | Subscriber and UE trace management | 585d | 2002-09-20 A | 2004-12-16 A | 100% | 2002-09-20 | 2004-12-16 | 585d | finish no earlier than 2004-12-16 | S5 | 4680h | 4680h | Rel-6 | 32.421/2/3, 52.008 | Kari RÖNKÄ (Nokia) | kari.t.ronka@nokia.com |  | OAM-Trace | TSG |  |
| 1213 | 327.4.2 | Subscriber and equipment trace in UTRAN | 268d? | 2003-06-06 A | 2004-06-15 A | 100% | 2003-06-06 | 2004-06-15 | 268d? | finish no earlier than 2004-06-15 | R3 | 2144h | 2144h | Rel-6 | TS25.413, 25.420, 25.423 | Yann Sehedi, Nortel | sehedic@nortelnetworks.com | MCC_RAN | OAM-Trace-RAN | TSG |  |
| 1214 | 327.4.3 | Trace Management, Stage3 | 193.74d? | 2004-06-09 A | 2005-03-11 A | 100% | 2004-06-09 | 2005-03-11 | 193.74d? | finish no earlier than 2005-03-11 | N4 | 1549.92h | 1549.92h | Rel-6 | TS 23.205, 29.232, 29.060, 29.002, 29.228 | Seppo Kauntola ( Nokia Corporation) | seppo.kauntola@nokia.com |  | OAM-Trace | TSG |  |
| 1215 | 328 | **Charging Management** | 666d? | 2002-11-21 A | 2005-06-09 A | 100% | 2002-11-21 | 2005-06-09 | 666d? |  | S5 | 55320h | 55320h | Rel-6 | 32.2xy | Karl-Heinz NENNER (T-Mobile) | karl-heinz.nenner@t-mobile.de | Adrian | CH | TSG |  |
| 1216 | 328.1 | Charging architecture and principles | 390d? | 2003-03-21 A | 2004-09-16 A | 100% | 2003-03-21 | 2004-09-16 | 390d? | start no earlier than 2003-03-21 | S5 | 3120h | 3120h | Rel-6 | 32.240 |  |  |  | CH | TSG |  |
| 1217 | 328.2 | Charging Data Record (CDR) file format and transfer | 260d? | 2003-03-21 A | 2004-03-18 A | 100% | 2003-03-21 | 2004-03-18 | 260d? | start no earlier than 2003-03-21 | S5 | 2080h | 2080h | Rel-6 | 32.297 |  |  |  | CH | TSG |  |
| 1218 | 328.3 | CDR parameter description | 580d? | 2003-03-21 A | 2005-06-09 A | 100% | 2003-03-21 | 2005-06-09 | 580d? | finish no earlier than 2005-06-09 | S5 | 4640h | 4640h | Rel-6 | 32.298 |  |  |  | CH | TSG |  |
| 1219 | 328.4 | Diameter charging applications | 390d? | 2003-03-21 A | 2004-09-16 A | 100% | 2003-03-21 | 2004-09-16 | 390d? | start no earlier than 2003-03-21 | S5 | 3120h | 3120h | Rel-6 | 32.299 |  |  |  | CH | TSG |  |
| 1220 | 328.5 | Online Charging System (OCS) architecture study | 130d? | 2003-03-21 A | 2003-09-18 A | 100% | 2003-03-21 | 2003-09-18 | 130d? | start no earlier than 2003-03-21 | S5 | 1040h | 1040h | Rel-6 | 32.815 |  |  |  | CH | TSG |  |
| 1221 | 328.6 | OCS: Applications and interfaces | 455d? | 2003-03-21 A | 2004-12-16 A | 100% | 2003-03-21 | 2004-12-16 | 455d? | start no earlier than 2003-03-21 | S5 | 3640h | 3640h | Rel-6 | 32.296 |  |  |  | CH | TSG |  |

Notes:
- 1193: Started
- 1197: Completed at GERAN#17
- 1202: Closed, no work needed
- 1203: Closed, no work needed
- 1204: Possible changes to 33.102 or new specification needed.
- 1207: SA#26: Updated WID SP-040766 was SP-020445. Completion delayed 12/04->03/05 due to OAM-Trace in CN1/4.
- 1208: SA#25 09/2004 completed
- 1209: SA#26 12/2004 completed
- 1210: SA#26 12/2004 completed
- 1211: SA#26 12/2004 SA5 completed 12/04. Signalling Based Trace Activation for IMS (SIP) moved to Rel-7. Reason: CN1 cannot complete 24.229 trace without IETF dependency => estimate 05/2005.
- 1212: SA#26 12/2004 completed
- 1215: SA#28 Target 09/2005 for WLAN Charging 32.252
- 1216: SA#25 09/2004 completed
- 1217: SA#23 03/2004 completed
- 1218: SA#28 06/2005 completed
- 1219: SA#25 09/2004 completed
- 1220: SA#21 09/2003 completed
- 1221: SA#26 12/2004 completed

| ID | WBS | Task | Duration | Start | Finish | Complete | Baseline start | Baseline finish | Baseline duration | Constraint | Resources | Work | Actual work | Text1 | Text4 | Text6 | Text7 | Text10 | Text5 | Text2 | Text8 | Text9 |
| --- | --- | --- | --- | --- | --- | --- | --- | --- | --- | --- | --- | --- | --- | --- | --- | --- | --- | --- | --- | --- | --- | --- |
| 1222 | 328.7 | **Charging Management for Bearer level** | 390d? | 2003-03-21 A | 2004-09-16 A | 100% | 2003-03-21 | 2004-09-16 | 390d? |  | S5 | 11440h | 11440h | CH-BC | Benni ALEXANDER (Nokia) | Rel-6 | TSG |  |  |  |  |  |
| 1223 | 328.7.1 | CS domain charging | 260d? | 2003-03-21 A | 2004-03-18 A | 100% | 2003-03-21 | 2004-03-18 | 260d? | start no earlier than 2003-03-21 | S5 | 2080h | 2080h | CH |  | Rel-6 | TSG |  |  |  |  |  |
| 1224 | 328.7.2 | PS domain charging | 390d? | 2003-03-21 A | 2004-09-16 A | 100% | 2003-03-21 | 2004-09-16 | 390d? | start no earlier than 2003-03-21 | S5 | 3120h | 3120h | CH |  | Rel-6 | TSG |  |  |  |  |  |
| 1225 | 328.7.3 | CDR transfer | 390d? | 2003-03-21 A | 2004-09-16 A | 100% | 2003-03-21 | 2004-09-16 | 390d? | start no earlier than 2003-03-21 | S5 | 3120h | 3120h | CH |  | Rel-6 | TSG |  |  |  |  |  |
| 1226 | 328.8 | Charging Management for the IMS | 455d? | 2003-03-21 A | 2004-12-16 A | 100% | 2003-03-21 | 2004-12-16 | 455d? | finish no earlier than 2004-12-16 | S5 | 3640h | 3640h | IMS2-CH | Patrik TEPPO (Ericsson) | Rel-6 | TSG |  |  |  |  |  |
| 1227 | 328.9 | Charging Management for the Service domain | 580d? | 2003-03-21 A | 2005-06-09 A | 100% | 2003-03-21 | 2005-06-09 | 580d? | finish no earlier than 2005-06-09 | S5 | 4640h | 4640h | CH | Gerald GÖRMER (Siemens) | Rel-6 | TSG |  |  |  |  |  |
| 1228 | 328.10 | **Overall architectural aspects of IP flow based bearer level charging** | 602d? | 2002-11-21 A | 2005-03-11 A | 100% | 2002-11-21 | 2005-03-11 | 602d? |  | S2 | 12632h | 12632h | CH-FBC |  | Rel-6 |  |  |  |  |  |  |
| 1229 | 328.10.1 | Overall definition of FBC architecture | 334d? | 2002-11-21 A | 2004-03-02 A | 100% | 2002-11-21 | 2004-03-02 | 334d? | start no earlier than 2002-11-21 | S2 | 2672h | 2672h |  |  | Rel-6 |  | SP-24 |  |  |  |  |
| 1230 | 328.10.2 | Study on providing policy control with FBC | 130d? | 2004-02-02 A | 2004-07-30 A | 100% | 2004-02-02 | 2004-07-30 | 130d? | start no earlier than 2004-02-01 | S2 | 1040h | 1040h |  |  | Rel-6 |  | SP-24 |  |  |  |  |
| 1231 | 328.10.3 | Gx interface for flow based charging | 223d? | 2004-02-02 A | 2004-12-08 A | 100% | 2004-02-02 | 2004-12-08 | 223d? | start no earlier than 2004-02-01 | N3 | 1784h | 1784h | CH-FBC | Juha Räsänen (Nokia) | Rel-6 | TSG | SP-25 | juha.a.rasanen@nokia.com |  |  |  |
| 1232 | 328.10.4 | Rx interface for flow based charging | 290d? | 2004-02-02 A | 2005-03-11 A | 100% | 2004-02-02 | 2005-03-11 | 290d? | finish no earlier than 2005-03-11 | N3 | 2320h | 2320h | CH-FBC | Javier Gonzalez Gallego | Rel-6 | TSG | SP-25 | ggfj@nortelnetworks.com |  |  |  |
| 1233 | 13 | **Rel-6 UICC/USIM enhancements and interworking** | 1164d? | 2000-09-25 A | 2005-03-10 A | 100% | 2000-09-25 | 2005-03-10 | 1164d? |  | T3 | 43088h | 43088h | USAT1 |  | Rel-6 | TSG |  |  | Ter | Claus | 1800 |
| 1234 | 13.1 | **UICC API** | 777d | 2002-03-20 A | 2005-03-10 A | 100% | 2002-03-20 | 2005-03-10 | 777d |  | T3 | 15024h | 15024h | USAT1-API |  | Rel-6 |  |  |  | Ter |  | 1802 |
| 1235 | 13.1.1 | Java API Test specification | 59d | 2002-03-20 A | 2002-06-10 A | 100% | 2002-03-20 | 2002-06-10 | 59d | finish no earlier than 2002-09-20 | T3 | 472h | 472h |  | Mario Pérez (Microelectrónica Española) | Rel-6 |  |  |  |  |  |  |
| 1236 | 329.1.2 | 2G/3G Java Card™ API based applet interworking | 255d | 2003-03-17 A | 2004-03-05 A | 100% | 2003-03-17 | 2004-03-05 | 255d | finish no earlier than 2004-02-19 | T3 | 2040h | 2040h | USAT1-API | Stéphane Andrau-Oberthur Card Systems | Rel-6 | TSG |  |  |  |  |  |
| 1237 | 329.1.3 | (U)SIM API for Java Card Testing Work Item | 519d | 2003-03-17 A | 2005-03-10 A | 100% | 2003-03-17 | 2005-03-10 | 519d | finish no earlier than 2005-03-10 | T3 | 4152h | 4152h |  | Christophe Begassat (Axalto) | Rel-6 | TSG |  | 'cbegassat@axalto.com' |  | Friedhelm |  |
| 1238 | 13.1.2 | Deleted - Java API Test specification (TS 43.019 Rel-5) | 268d | 2002-05-30 A | 2003-06-09 A | 100% | 2002-05-30 | 2003-06-09 | 268d | finish no earlier than 2003-09-17 | T3 | 2144h | 2144h |  | Mario Pérez (Microelectrónica Española) | Rel-6 |  |  |  |  |  |  |
| 1239 | 329.2 | **Rel-6 USIM toolkit enhancements** | 1160d? | 2000-09-25 A | 2005-03-04 A | 100% | 2000-09-25 | 2005-03-04 | 1160d? |  | T3 | 21848h | 21848h |  |  | Rel-6 |  |  |  |  | Claus |  |
| 1240 | 329.2.1 | **C SIM API** | 525d | 2000-09-25 A | 2002-09-27 A | 100% | 2000-09-25 | 2002-09-27 | 525d |  | T3 | 9960h | 9960h | USAT1-API-MULTOS |  | Rel-6 | TSG |  |  | Ter |  | 2031 |
| 1241 | 329.2.1.1 | Specification | 525d | 2000-09-25 A | 2002-09-27 A | 100% | 2000-09-25 | 2002-09-27 | 525d | finish no earlier than 2002-09-27 | T3 | 4200h | 4200h |  | Neil Livingston – Aspects Software | Rel-6 | TSG |  |  | Ter |  | 2032 |
| 1242 | 329.2.1.2 | Test specification | 195d | 2001-01-01 A | 2001-09-28 A | 100% | 2001-01-01 | 2001-09-28 | 195d | finish no earlier than 2001-09-28 | T3 | 1560h | 1560h |  | Neil Livingston – Aspects Software | Rel-6 | TSG |  |  | Ter |  | 2033 |
| 1243 | 329.2.2 | USIM application toolkit Conformance Test Specification for Mobile Equipments | 326d? | 2003-12-05 A | 2005-03-04 A | 100% | 2003-12-05 | 2005-03-04 | 326d? | start no earlier than 2003-12-05 | T3 | 2608h | 2608h |  | Eric Laffont, Gemplus | Rel-6 | TSG |  | Eric.laffont@gemplus.com |  |  |  |
| 1244 | 330 | **Packet Switched Streaming Services Rel-6** | 798d? | 2002-11-18 A | 2005-12-07 A | 100% | 2002-11-18 | 2005-12-07 | 798d? |  | S4 | 11579.4h | 11579.4h | PSSrel6 | Olle Franceschi (Ericsson) | Rel-6 | TSG |  | olle.franceschi@ericsson.com |  | Paolo |  |
| 1245 | 330.1 | Stage 1 | 86d? | 2002-11-18 A | 2003-03-17 A | 100% | 2002-11-18 | 2003-03-17 | 86d? | finish no earlier than 2003-03-17 | S1 | 688h | 688h |  |  | Rel-6 | TSG |  |  |  |  |  |
| 1246 | 330.2 | Stage 3 | 779d? | 2002-12-13 A | 2005-12-07 A | 100% | 2002-12-13 | 2005-12-07 | 779d? | finish no earlier than 2005-12-07 | S4 | 6232h | 6232h | PSSrel6-Stage3 | Olle Franceschi (Ericsson) | Rel-6 | WG |  | olle.franceschi@ericsson.com |  | Paolo |  |
| 1247 | 331 | AMR-WB extension for high audio quality | 779d | 2002-12-13 A | 2005-12-07 A | 100% | 2002-12-13 | 2005-12-07 | 779d | finish no earlier than 2005-12-07 | S4 | 6232h | 6232h | AMRWB+ | Janne Vainio (Nokia) | Rel-6 | TSG |  | janne.m.vainio@nokia.com |  | Paolo |  |
| 1248 | 332 | Codec Enhancements for Packet Switched Conversational Multimedia Applications | 198d? | 2004-03-16 A | 2004-12-16 A | 100% | 2004-03-16 | 2004-12-16 | 198d? | finish no earlier than 2004-12-16 | S4 | 1584h | 1584h | CEPSCM | Miska Hannuksela (Nokia) | Rel-6 | WG |  | miska.hannuksela@nokia.com |  | Paolo |  |
| 1249 | 333 | 3G-324M Improvements | 198d? | 2004-03-16 A | 2004-12-16 A | 100% | 2004-03-16 | 2004-12-16 | 198d? | finish no earlier than 2004-12-16 | S4 | 1584h | 1584h | 3G-324MI | Bo Burman, Ericsson | Rel-6 | WG |  | bo.burman@ericsson.com |  | Paolo |  |
| 1250 | 334 | Single Antenna Receiver Interference Cancellation (SAIC) | 420.92d? | 2002-11-15 A | 2004-08-27 A | 100% | 2002-11-15 | 2004-08-27 | 420.92d? | finish no earlier than 2004-08-27 | GP; G1 | 6734.73h | 6734.73h | SAIC | Marc Grant, Cingular Wireless | Rel-6 | TSG |  |  |  | Paolo |  |

Notes:
- 1222: SA#28 Target 09/2005 for WLAN Charging 32.252
- 1223: SA#23 03/2004 completed / Text3: 32.250
- 1224: SA#25 09/2004 completed / Text3: 32.251
- 1225: SA#25 09/2004 completed / Text3: 32.295
- 1226: SA#26 12/2004 completed / Text3: 32.260
- 1227: SA#26: Updated WID SP-040778 was SP-030050. Target completion 06/2005. Consisting of MMS-CH, LCS-CH, WLAN-CH, POC-CH, MBMS-CH / Text3: 32.252, 32.270/1/2
- 1228: Text3: 23.125
- 1231: Text3: 29.210
- 1232: Text3: 29.209
- 1234: 8/3/2001: test spec is based on R99 core spec, so deleted from Workplan
- 1237: Text3: 31.213
- 1238: MOVED to Rel-5 WP
- 1243: Text3: 31.124
- 1245: 2nd resp SA4 / Text3: 22.233
- 1246: TR tbc by Sept. 05 / Text3: 26.233, 26.234, 26.244, 26.245, 26.246, 26.401, 26.402, 26.403, 26.404, 26.405, 26.406, 26.410, 26.411, 26.412, 26.273, 26.290, 26.304, 26.412, 26.274, 26.936
- 1247: TR tbc by Sept. 05 / Text3: 26.290, 26.304, 26.273, 26.274, 26.412, 26.936
- 1248: Completed / Text3: 26.235, 26.236
- 1249: Completed / Text3: 26.111, 26.911

| ID | WBS | Task | Type | Duration | Start | Finish | Complete | Baseline start | Baseline finish | Baseline duration | Constraint | Resources | Work | Actual work | Text1 | Text4 | Text6 | Text7 | Text8 | Text3 | Text5 |
| --- | --- | --- | --- | --- | --- | --- | --- | --- | --- | --- | --- | --- | --- | --- | --- | --- | --- | --- | --- | --- | --- |
| 1251 | 335 | **Enhancement of dialled service for CAMEL** |  | 199d | 2003-03-28 A | 2003-12-31 A | 100% | 2003-03-28 | 2003-12-31 | 199d |  | S1 | 3184h | 3184h | EDCAMEL | Craig Bishop, Samsung Electronics Research Institute | Rel-6 | TSG | Andrijana |  |  |
| 1252 | 335.1 | Stages 2 and 3 |  | 199d | 2003-03-28 A | 2003-12-31 A | 100% | 2003-03-28 | 2003-12-31 | 199d | finish no earlier than 2003-09-19 | N4 | 1592h | 1592h |  |  | Rel-6 |  |  |  |  |
| 1253 | 336 | Bandwidth and resource savings in CS networks |  | 273d? | 2003-06-01 A | 2004-06-16 A | 100% | 2003-06-01 | 2004-06-16 | 273d? | finish no earlier than 2004-06-16 | S2 | 2184h | 2184h | BARS |  | Rel-6 |  | Sang-Ui | 23.977 |  |
| 1254 | 337 | FS on (U)SIM Security Reuse by Peripheral Devices on Local Interfaces |  | 127d? | 2003-07-03 A | 2003-12-26 A | 100% | 2003-07-03 | 2003-12-26 | 127d? | finish no earlier than 2003-12-26 | S3 | 1016h | 1016h |  | Raziq Yaqub, Toshiba America Research Inc. | Rel-6 | TSG | Maurice |  | ryaqub@tari.toshiba.com |
| 1255 | 338 | **Multiple TBF in A/Gb mode** |  | 736d? | 2002-04-05 A | 2005-01-28 A | 100% | 2002-04-05 | 2005-01-28 | 736d? |  | GP; G2 | 35200h | 35200h | MULTBF | Gunnar Mildh, Ericsson | Rel-6 | TSG | Paolo |  |  |
| 1256 | 338.1 | **Multiple TBF in A/Gb mode** |  | 366d? | 2002-04-05 A | 2003-08-29 A | 100% | 2002-04-05 | 2003-08-29 | 366d? |  | GP; G2 | 23424h | 23424h | MULTBF-Agbmode | Gunnar Mildh, Ericsson | Rel-6 | TSG |  |  |  |
| 1257 | 338.1.1 | Multiple TBF Concept paper |  | 366d? | 2002-04-05 A | 2003-08-29 A | 100% | 2002-04-05 | 2003-08-29 | 366d? | finish no earlier than 2003-08-29 | GP; G2 | 5856h | 5856h |  |  | Rel-6 |  |  |  |  |
| 1258 | 338.1.2 | Multiple TBF Stage 2 (43.064) CRs |  | 366d? | 2002-04-05 A | 2003-08-29 A | 100% | 2002-04-05 | 2003-08-29 | 366d? | finish no earlier than 2003-08-29 | GP; G2 | 5856h | 5856h |  |  | Rel-6 |  |  |  |  |
| 1259 | 338.1.3 | Multiple TBF Stage 3 (44.060) CRs |  | 366d? | 2002-04-05 A | 2003-08-29 A | 100% | 2002-04-05 | 2003-08-29 | 366d? | finish no earlier than 2003-08-29 | GP; G2 | 5856h | 5856h |  |  | Rel-6 |  |  |  |  |
| 1260 | 338.2 | Deleted at TGS # 27 - Multiple TBF in A/Gb mode – MS testing | milestone | 0d? | 2005-01-28 A | 2005-01-28 A | 100% | 2005-01-28 | 2005-01-28 | 0d? | start no earlier than 2005-01-28 | G3 |  |  | MULTBF-Testing | Gunnar Mildh, Ericsson | Rel-6 | TSG | Paolo |  |  |
| 1261 | 339 | **Alignment between the test-regimes for GERAN capable MS** |  | 526d? | 2003-08-29 A | 2005-09-02 A | 100% | 2003-08-29 | 2005-09-02 | 526d? |  | G3 | 8416h | 8416h | ALTERE | Toubassi, Ericsson | Rel-6 | TSG | Stoyan |  |  |
| 1262 | 339.1 | Determine the controversial test cases in the different test regimes and align them with 3GPP GERAN test specifications. Such test cases to be added to TS 51.010. |  | 526d? | 2003-08-29 A | 2005-09-02 A | 100% | 2003-08-29 | 2005-09-02 | 526d? | finish no earlier than 2005-09-02 | G3 | 4208h | 4208h | ALTERE-TC |  | Rel-6 | TSG |  |  |  |
| 1263 | 340 | Addition of U-TDOA in the CS domain |  | 111d? | 2003-11-21 A | 2004-04-23 A | 100% | 2003-11-21 | 2004-04-23 | 111d? | finish no earlier than 2004-04-23 | GP | 888h | 888h | UTDOACS | Bob Gross, Rhys Robinson, TruePosition, Inc. | Rel-6 | TSG | Paolo |  | rlgross@trueposition.com |
| 1264 | 341 | Addition of U-TDOA in the PS domain |  | 361d? | 2003-06-27 A | 2004-11-12 A | 100% | 2003-06-27 | 2004-11-12 | 361d? | finish no earlier than 2004-11-12 | GP | 2888h | 2888h | UTDOAPS | Bob Gross, Rhys Robinson, TruePosition, Inc. | Rel-6 | TSG | Paolo |  | rlgross@trueposition.com |
| 1265 | 342 | **Downlink Advanced Receiver Performance** |  | 466d? | 2003-11-21 A | 2005-09-02 A | 100% | 2003-11-21 | 2005-09-02 | 466d? |  | GP | 19160h | 19160h | DARP | Tommy Bysted, Nokia | Rel-6 | TSG | Paolo |  | tommy.bysted@nokia.com |
| 1266 | 342.1 | DARP test scenarios |  | 201d? | 2003-11-21 A | 2004-08-27 A | 100% | 2003-11-21 | 2004-08-27 | 201d? | finish no earlier than 2004-08-27 | GP | 1608h | 1608h | DARP-TS | Tommy Bysted, Nokia | Rel-6 | TSG | Paolo |  | tommy.bysted@nokia.com |
| 1267 | 342.2 | **DARP for GMSK modulated voice services** |  | 201d? | 2004-02-06 A | 2004-11-12 A | 100% | 2004-02-06 | 2004-11-12 | 201d? |  | GP | 4824h | 4824h | DARP-GMSK | Tommy Bysted, Nokia | Rel-6 | TSG | Paolo |  | tommy.bysted@nokia.com |
| 1268 | 342.2.1 | Performance requirements in 45.005 |  | 201d? | 2004-02-06 A | 2004-11-12 A | 100% | 2004-02-06 | 2004-11-12 | 201d? | finish no earlier than 2004-11-12 | GP | 1608h | 1608h | DARP-GMSK-Perf |  | Rel-6 | TSG |  |  |  |
| 1269 | 342.2.2 | Radio subsystem link control in 45.008 |  | 201d? | 2004-02-06 A | 2004-11-12 A | 100% | 2004-02-06 | 2004-11-12 | 201d? | finish no earlier than 2004-11-12 | GP | 1608h | 1608h | DARP-GMSK-LC |  | Rel-6 | TSG |  |  |  |
| 1270 | 342.3 | **DARP for GPRS and EGPRS MCS1-MCS4** |  | 201d? | 2004-02-06 A | 2004-11-12 A | 100% | 2004-02-06 | 2004-11-12 | 201d? |  | GP | 4824h | 4824h | DARP-GPRSE | Tommy Bysted, Nokia | Rel-6 | TSG | Paolo |  | tommy.bysted@nokia.com |
| 1271 | 342.3.1 | Performance requirements in 45.005 |  | 201d? | 2004-02-06 A | 2004-11-12 A | 100% | 2004-02-06 | 2004-11-12 | 201d? | finish no earlier than 2004-11-12 | GP | 1608h | 1608h | DARP-GPRSE-Perf |  | Rel-6 | TSG |  |  |  |
| 1272 | 342.3.2 | Radio subsystem link control in 45.008 |  | 201d? | 2004-02-06 A | 2004-11-12 A | 100% | 2004-02-06 | 2004-11-12 | 201d? | finish no earlier than 2004-11-12 | GP | 1608h | 1608h | DARP-GPRSE-LC |  | Rel-6 | TSG |  |  |  |
| 1273 | 342.4 | DARP Capability signalling |  | 256d? | 2003-11-21 A | 2004-11-12 A | 100% | 2003-11-21 | 2004-11-12 | 256d? | finish no earlier than 2004-11-12 | GP | 2048h | 2048h | DARP-CAPSIG | Tommy Bysted, Nokia | Rel-6 | TSG | Paolo |  | tommy.bysted@nokia.com |
| 1274 | 342.5 | GERAN MS Conformance test for DARP |  | 266d? | 2004-08-27 A | 2005-09-02 A | 100% | 2004-08-27 | 2005-09-02 | 266d? | finish no earlier than 2005-06-24 | G3 | 2128h | 2128h | ARP-ConfTest | Tommy Bysted, Nokia | Rel-6 | TSG | Michael |  | tommy.bysted@nokia.com |

Notes:
- 1254: Approved TSG#20
- 1260: DELETE
- 1262: Completed
- 1263: Completed, except for potential LMU performance specs
- 1274: Started

| ID | WBS | Task | Type | Duration | Start | Finish | Complete | Remaining | Baseline start | Baseline finish | Baseline duration | Total slack | Constraint | Resources | Work | Actual work | Text1 | Text4 | Text5 | Text6 | Text7 | Text8 | Text3 | Text10 |
| --- | --- | --- | --- | --- | --- | --- | --- | --- | --- | --- | --- | --- | --- | --- | --- | --- | --- | --- | --- | --- | --- | --- | --- | --- |
| 1275 | 343 | **Reduction of PS service interruption in Dual Transfer Mode** |  | 416d? | 2003-11-21 A | 2005-06-24 | 59% | 172.62d? | 2003-11-21 | 2005-06-24 | 416d? | 1175d |  | G2 | 8360h | 2968.18h | PSintDTM | Toby Proctor, Siemens | toby.proctor@roke.co.uk | Rel-6 | TSG | Gert |  |  |
| 1276 | 343.1 | Use case and requirement definition |  | 111d? | 2003-11-21 A | 2004-04-23 A | 100% |  | 2003-11-21 | 2004-04-23 | 111d? |  | finish no earlier than 2004-04-23 | G2 | 888h | 888h | PSintDTM-Req | Toby Proctor, Siemens | toby.proctor@roke.co.uk | Rel-6 | TSG | Gert |  |  |
| 1277 | 343.2 | Performance Study of Current Procedures |  | 111d? | 2003-11-21 A | 2004-04-23 A | 100% |  | 2003-11-21 | 2004-04-23 | 111d? |  | start no earlier than 2003-11-21 | G2 | 888h | 888h | PSintDTM-Perf | Toby Proctor, Siemens | toby.proctor@roke.co.uk | Rel-6 | TSG | Gert |  |  |
| 1278 | 343.3 | Reduction of service interruption times and packet loss during Dual Transfer Mode and mobility procedures |  | 146d? | 2004-04-23 A | 2004-11-12 A | 100% |  | 2004-04-23 | 2004-11-12 | 146d? |  | finish no earlier than 2004-11-12 | G2 | 1168h | 1168h | PSintDTM-Reduct | Toby Proctor, Siemens | toby.proctor@roke.co.uk | Rel-6 | TSG | Gert |  |  |
| 1279 | 343.4 | MS Conformance testing |  | 261d? | 2004-06-25 | 2005-06-24 |  |  | 2004-06-25 | 2005-06-24 | 261d? | 1175d | finish no earlier than 2005-06-24 | G3 | 2088h |  | PSintDTM-ConfMS |  |  | Rel-6 | TSG | Stoyan |  |  |
| 1280 | 343.5 | Deleted - BTS Conformance testing | milestone | 0d? | 2005-06-24 A | 2005-06-24 A | 100% |  | 2005-06-24 | 2005-06-24 | 0d? |  | finish no earlier than 2005-06-24 | G3 |  |  | PSintDTM-ConfBTS |  |  | Rel-6 | TSG | Paolo |  |  |
| 1281 | 344 | CAMEL prepay interworking with SCUDIF |  | 206d | 2003-12-08 A | 2004-10-05 A | 100% |  | 2003-12-08 | 2004-10-05 | 206d |  |  | N4 | 1648h | 1648h | SCCAMEL |  |  | Rel-6 |  | Kimmo |  |  |
| 1282 | 345 | **Circuit Switched Video and Voice Service Improvements** |  | 430d? | 2004-01-12 A | 2005-09-02 A | 100% |  | 2004-01-12 | 2005-09-02 | 430d? |  |  | S1 | 6536h | 6536h | CS_VSS | John Watson, Vodafone Group |  | Rel-6 | TSG | Michael | 23.801 |  |
| 1283 | 345.1 | Stage 1 - Requirements |  | 199d | 2004-01-12 A | 2004-10-14 A | 100% |  | 2004-01-12 | 2004-10-14 | 199d |  | finish no earlier than 2004-10-14 | S1 | 1592h | 1592h | CS_VSS | John Watson, Vodafone Group |  | Rel-6 | TSG | Michael |  |  |
| 1284 | 345.2 | Stage 2 Study on architecture alternatives |  | 155d? | 2004-01-12 A | 2004-08-13 A | 100% |  | 2004-01-12 | 2004-08-13 | 155d? |  | finish no earlier than 2004-08-13 | S2 | 1240h | 1240h | CS_VSS |  |  | Rel-6 |  |  |  | SP-24 |
| 1285 | 345.3 | Stage 2 description on Redial |  | 164d? | 2004-05-03 A | 2004-12-16 A | 100% |  | 2004-05-03 | 2004-12-16 | 164d? |  | finish no earlier than 2004-12-16 | S2 | 1312h | 1312h | CS_VSS |  |  | Rel-6 |  |  | 23.903 | SP-24 |
| 1286 | 345.4 | Switching between voice and video call - Redial solution |  | 120d? | 2005-01-03 A | 2005-06-17 A | 100% |  | 2005-01-03 | 2005-06-17 | 120d? |  | start no earlier than 2005-01-03 | C1 | 960h | 960h | CS_VSS |  |  | Rel-6 |  |  |  |  |
| 1287 | 345.5 | Deleted - GERAN2 Part | milestone | 0d | 2005-09-02 A | 2005-09-02 A | 100% |  | 2005-09-02 | 2005-09-02 | 0d |  | start no earlier than 2005-09-02 | G2 |  |  | CS_VSS |  |  | Rel-6 | TSG | Gert |  |  |
| 1288 | 345.6 | Deleted - CN3 Part | milestone | 0d? | 2004-10-14 A | 2004-10-14 A | 100% |  | 2004-10-14 | 2004-10-14 | 0d? |  | start no earlier than 2004-10-14 | N3 |  |  | CS_VSS |  |  | Rel-6 |  |  |  |  |
| 1289 | 346 | Network Domain Security; MAP application layer security (NDS/MAPsec) |  | 127d? | 2004-07-06 A | 2004-12-29 | 20% | 101.6d? | 2004-07-06 | 2004-12-29 | 127d? | 1302d | finish no earlier than 2003-12-26 | S3 | 1016h | 203.2h | MAPSEC | Peter Howard, Vodafone | Peter.Howard@vodafone.com | Rel-6 | TSG | Maurice |  |  |
| 1290 | 347 | FS on Security for early IMS |  | 127d? | 2004-10-01 A | 2005-03-28 A | 100% |  | 2004-10-01 | 2005-03-28 | 127d? |  | finish no earlier than 2003-12-26 | S3 | 1016h | 1016h | SEC-IMS | Peter Howard, Vodafone | Peter.Howard@vodafone.com | Rel-6 | TSG | Maurice |  |  |
| 1291 | 348 | Reorganisation of CS Data Specifications |  | 14d? | 2004-11-19 A | 2004-12-08 A | 100% |  | 2004-11-19 | 2004-12-08 | 14d? |  | finish no earlier than 2004-12-24 | N3 | 112h | 112h | CS Data | Tomas Belling(Siemens) | thomas.belling@siemens.com | Rel-6 | TSG | Seung Don |  |  |
| 1292 | 349 | **Generic Access to A/Gb Interface (GAAI)** |  | 411d? | 2004-06-25 A | 2006-01-20 | 95% | 20.49d? | 2004-06-25 | 2006-01-20 | 411d? | 1025d |  | GP | 9160h | 8703.25h | GAAI | Motorola |  | Rel-6 | TSG | Paolo |  |  |
| 1293 | 349.1 | FS on GAAI |  | 46d? | 2004-06-25 A | 2004-08-27 A | 100% |  | 2004-06-25 | 2004-08-27 | 46d? |  | finish no earlier than 2004-08-27 | GP | 368h | 368h | GAAG | Motorola |  | Rel-6 | TSG | Paolo | TR 43.901 |  |
| 1294 | 349.2 | GAAI – Stage 2 |  | 161d? | 2004-08-27 A | 2005-04-08 A | 100% |  | 2004-08-27 | 2005-04-08 | 161d? |  | finish no earlier than 2005-04-08 | GP | 1288h | 1288h | GAAI-Stage2 | Jari Vikberg (KI/EAB) | jari.vikberg@ericsson.com | Rel-6 | TSG | Paolo | TS 43.318 |  |
| 1295 | 349.3 | GAAI – Stage 3 |  | 161d? | 2004-08-27 A | 2005-04-08 A | 100% |  | 2004-08-27 | 2005-04-08 | 161d? |  | finish no earlier than 2005-04-08 | GP | 1288h | 1288h | GAAI-Stage3 |  |  | Rel-6 | TSG | Gert | TS 44.318 |  |
| 1296 | 349.4 | MS Conformance Test for GAAI |  | 366d? | 2004-08-27 A | 2006-01-20 | 90% | 36.6d? | 2004-08-27 | 2006-01-20 | 366d? | 1025d | finish no earlier than 2006-01-20 | GP | 2928h | 2635.2h | GAAI-CT |  |  | Rel-6 | TSG | Stoyan |  |  |
| 1297 | 350 | **Support of PS Handover for GERAN A/Gb mode** |  | 473d? | 2003-11-03 A | 2005-08-24 A | 100% |  | 2003-11-03 | 2005-08-24 | 473d? |  |  | GP-G2 | 15136h | 15136h | SPSHAGB | Gunnar Hedby, Ericsson | gunnar.hedby@ericsson.com | Rel-6 |  | Paolo |  |  |
| 1298 | 350.1 | Stage 2 |  | 473d? | 2003-11-03 A | 2005-08-24 A | 100% |  | 2003-11-03 | 2005-08-24 | 473d? |  | finish no earlier than 2005-09-02 | GP-G2 | 3784h | 3784h | SPSHAGB-Stage2 | Gunnar Hedby, Ericsson | gunnar.hedby@ericsson.com | Rel-6 |  | Paolo | 43.129 |  |
| 1299 | 350.2 | PS handover |  | 473d? | 2003-11-03 A | 2005-08-24 A | 100% |  | 2003-11-03 | 2005-08-24 | 473d? |  | finish no earlier than 2005-09-02 | GP-G2 | 3784h | 3784h | SPSHAGB-PSHO | Gunnar Hedby, Ericsson | gunnar.hedby@ericsson.com | Rel-6 |  | Paolo |  |  |
| 1300 | 350.3 | Definition of radio resource management functionality |  | 473d? | 2003-11-03 A | 2005-08-24 A | 100% |  | 2003-11-03 | 2005-08-24 | 473d? |  | finish no earlier than 2005-09-02 | GP-G2 | 3784h | 3784h | SPSHAGB-RRM | Gunnar Hedby, Ericsson | gunnar.hedby@ericsson.com | Rel-6 |  | Paolo |  |  |

Notes:
- 1279: On-going
- 1289: Approved TSG#24
- 1290: Approved TSG#24. TR 33.978 Approved at TSG SA #27
- 1291: Created at TSG#27 as 100 % complete
- 1293: Feasibility Study
- 1294: Completed
- 1295: Completed
- 1296: Started
- 1297: Replaces SCSAGB- Originally Started Nov 2003 as GP-030443
- 1298: Replaces SCSAGB-Stage2
- 1299: Replaces SCSAGB-PSH
- 1300: Replaces SCSAGB-RRM

| ID | WBS | Task | Type | Duration | Start | Finish | Complete | Remaining | Baseline start | Baseline finish | Baseline duration | Total slack | Constraint | Resources | Work | Actual work | Text1 | Text6 | Text3 | Text8 | Text4 | Text5 | Text7 | Text12 | Text9 | Text11 | Text2 |
| --- | --- | --- | --- | --- | --- | --- | --- | --- | --- | --- | --- | --- | --- | --- | --- | --- | --- | --- | --- | --- | --- | --- | --- | --- | --- | --- | --- |
| 1301 | 351 | **Small Technical Enhancements and Improvements for Rel-6** |  | 503d? | 2006-06-02 A | 2008-05-06 A | 100% |  | 2006-06-02 | 2008-05-06 | 503d? |  |  | Generic | 8048h | 8048h | TEI6 | Rel-6 |  |  |  |  |  |  |  |  |  |
| 1302 | 351.1 | Small Technical Enhancements and Improvements for Rel-6 Conformance Testing |  | 503d? | 2006-06-02 A | 2008-05-06 A | 100% |  | 2006-06-02 | 2008-05-06 | 503d? |  | start no earlier than 2006-06-02 | R5 | 4024h | 4024h | TEI6_Test | Rel-6 | 34.108,34.121-1/2,34.122,34.123-1/2/3 | Stoyan Baev |  |  |  |  |  |  |  |
| 1303 | 352 | Deleted - Study of Feature Interactions Requirements | milestone | 0d? | 2004-10-01 A | 2004-10-01 A | 100% |  | 2004-10-01 | 2004-10-01 | 0d? |  | finish no earlier than 2004-10-01 | S1 |  |  | FINTER | Rel-6 |  |  |  |  |  |  |  |  |  |
| 1304 | 353 | Deleted (moved to Rel7) - Enhancements of VGCS in public networks for communication of public authority officials | milestone | 0d? | 2005-08-24 A | 2005-08-24 A | 100% |  | 2005-08-24 | 2005-08-24 | 0d? |  | start no earlier than 2005-08-24 | GP-G2 |  |  | EVGCS | Rel-6 | 44.018, 44.068, 48.008 | Gert | Ken Isaacs (Siemens) | kenneth.isaacs@roke.co.uk |  |  |  |  |  |
| 1305 | 354 | **Deleted - Support of Conversational Services in A/Gb mode via the PS domain** |  | 64d? | 2003-11-21 A | 2004-02-19 A | 100% |  | 2003-11-21 | 2004-02-19 | 64d? |  |  | GP |  |  | SCSAGB | Rel-6 |  | Paolo | David Bladsjö, Ericsson | david.bladsjo@ericsson.com | TSG |  |  |  |  |
| 1306 | 354.1 | Delete - Creation of a TR | milestone | 0d? | 2003-11-21 A | 2003-11-21 A | 100% |  | 2003-11-21 | 2003-11-21 | 0d? |  | start no earlier than 2003-11-21 | GP |  |  | SCSAGB-TR | Rel-6 |  |  | David Bladsjö, Ericsson |  | TSG |  |  |  |  |
| 1307 | 354.2 | Delete - Stage 2 | milestone | 0d? | 2003-11-21 A | 2003-11-21 A | 100% |  | 2003-11-21 | 2003-11-21 | 0d? |  | finish no earlier than 2003-11-21 | GP |  |  | SCSAGB-Stage2 | Rel-6 |  |  | David Bladsjö, Ericsson |  | TSG |  |  |  |  |
| 1308 | 354.3 | Delete - Radio Channel Support | milestone | 0d? | 2003-11-21 A | 2003-11-21 A | 100% |  | 2003-11-21 | 2003-11-21 | 0d? |  | finish no earlier than 2003-11-21 | GP |  |  | SCSAGB-RCS | Rel-6 |  |  | David Bladsjö, Ericsson |  | TSG |  |  |  |  |
| 1309 | 354.4 | Delete - Definition of radio resource management functionality | milestone | 0d? | 2003-11-21 A | 2003-11-21 A | 100% |  | 2003-11-21 | 2003-11-21 | 0d? |  | finish no earlier than 2003-11-21 | GP; G2 |  |  | SCSAGB-RRM | Rel-6 |  |  | David Bladsjö, Ericsson |  | TSG |  |  |  |  |
| 1310 | 354.5 | Delete, replaced by 50561 - PS Handover | milestone | 0d | 2003-11-21 A | 2004-02-19 A | 100% |  | 2003-11-21 | 2004-02-19 | 0d |  | start no earlier than 2003-11-21 | GP; GP, N1 |  |  | SCSAGB-PSH | Rel-6 |  |  | David Bladsjö, Ericsson |  | TSG |  |  |  |  |
| 1311 | 354.6 | Delete - Modifications to FLO | milestone | 0d? | 2003-11-21 A | 2003-11-21 A | 100% |  | 2003-11-21 | 2003-11-21 | 0d? |  | finish no earlier than 2003-11-21 | GP; G2 |  |  | SCSAGB-FLO | Rel-6 |  |  | David Bladsjö, Ericsson |  | TSG | RP-29 |  |  |  |
| 1312 | 355 | Deleted - Rel-6 Evolutions of the transport in the UTRAN | milestone | 0d | 2003-12-31 A | 2003-12-31 A | 100% |  | 2003-12-31 | 2003-12-31 | 0d |  | start no earlier than 2003-12-31 | RP |  |  | ETRAN | Rel-6 |  | Cesar | Francois Courau, Alcatel | francois.courau@alcatel.fr | TSG |  | Feat | Generic |  |
| 1313 | 356 | Release 5 Features |  | 1d? | 2000-01-03 | 2000-01-03 |  |  | 2000-01-03 | 2000-01-03 | 1d? | 2604d |  | CP,GP, RP,SP,TP | 8h |  |  | Rel-5 |  |  |  |  |  |  |  |  |  |
| 1314 | 75 | IP transport in the UTRAN |  | 445d | 2000-07-17 A | 2002-03-29 A | 100% |  | 2000-07-17 | 2002-03-29 | 445d |  | finish no earlier than 2002-03-29 | R3 | 3560h | 3560h | ETRAN-IPtrans | Rel-5 |  |  | Nicolas Drevon, Alcatel |  | TSG |  | 625 |  | BaAS |
| 1315 | 76 | FS on Usage of SUA |  | 205d | 2001-03-12 A | 2001-12-21 A | 100% |  | 2001-03-12 | 2001-12-21 | 205d |  | finish no earlier than 2001-12-21 | N4 | 1640h | 1640h | SS7IP | Rel-5 |  |  |  |  |  |  | 2455 |  |  |
| 1316 | 77 | **High Speed Downlink Packet Access** |  | 570d | 2001-04-02 A | 2003-06-06 | 96% | 24.05d | 2001-04-02 | 2003-06-06 | 570d | 1710d |  | R2 | 15272h | 14627.6h | HSDPA | Rel-5 |  | Cesar | Ravi Kuchibhotla, Motorola |  | TSG |  | 2476 |  |  |
| 1317 | 77.1 | Physical Layer |  | 257d | 2001-04-05 A | 2002-03-29 A | 100% |  | 2001-04-05 | 2002-03-29 | 257d |  | finish no earlier than 2002-03-29 | R1 | 2056h | 2056h | HSDPA-Phys |  |  |  | Amitava Ghosh, Motorola |  | TSG |  | 2477 |  |  |
| 1318 | 77.2 | Layer 2 and 3 aspects |  | 257d | 2001-04-05 A | 2002-03-29 A | 100% |  | 2001-04-05 | 2002-03-29 | 257d |  | finish no earlier than 2002-03-29 | R2 | 2056h | 2056h | HSDPA-L23 |  |  |  | Ravi Kuchibhotla, Motorola |  | TSG |  | 2478 |  |  |
| 1319 | 77.3 | Iub/Iur protocol aspects |  | 260d | 2001-04-02 A | 2002-03-29 A | 100% |  | 2001-04-02 | 2002-03-29 | 260d |  | finish no earlier than 2002-03-29 | R3 | 2080h | 2080h | HSDPA-IubIur |  |  |  | Mike Diesen, Motorola |  | TSG |  | 2479 |  |  |
| 1320 | 77.4 | RF Radio Transmission/ Reception, System Performance Requirements and Conformance Testing |  | 565d | 2001-04-09 A | 2003-06-06 | 90% | 56.5d | 2001-04-09 | 2003-06-06 | 565d | 1710d | finish no earlier than 2003-06-06 | R4 | 4520h | 4068h | HSDPA-RF |  |  |  | Howard Benn, Motorola |  | TSG |  | 2480 |  |  |
| 1321 | 78 | **Rel-5 Improvements of Radio Interface** |  | 535d | 2000-08-14 A | 2002-08-30 | 89% | 56.7d | 2000-08-14 | 2002-08-30 | 535d | 1910d |  | RP | 30376h | 27009h | RInImp | NA |  | Tsukasa |  |  | TSG |  |  |  |  |
| 1322 | 78.1 | **Base station classification** |  | 480d | 2000-08-14 A | 2002-06-14 A | 100% |  | 2000-08-14 | 2002-06-14 | 480d |  |  | R4 | 9208h | 9208h | RInImp-BSClass | Rel-5 |  |  | A. Toskala, Nokia |  | TSG |  | 1471 |  | BaAS |
| 1323 | 78.1.1 | TDD Base station classification |  | 410d | 2000-08-14 A | 2002-03-08 A | 100% |  | 2000-08-14 | 2002-03-08 | 410d |  | finish no earlier than 2002-03-08 | R4 | 3280h | 3280h | RInImp-BSClass-TDD |  |  |  | A. Toskala, Nokia |  | TSG |  | 1477 |  | BaAs |
| 1324 | 78.1.2 | Base Station Classification for 1.28 Mcps TDD option |  | 261d | 2001-06-15 A | 2002-06-14 A | 100% |  | 2001-06-15 | 2002-06-14 | 261d |  | finish no earlier than 2002-06-14 | R4 | 2088h | 2088h | RInImp-BSClass-LCRTDD |  |  |  | Meik Kottkamp, Siemens |  | TSG |  |  |  |  |
| 1325 | 78.2 | Enhancement on the DSCH hard split mode |  | 271d | 2001-03-16 A | 2002-03-29 A | 100% |  | 2001-03-16 | 2002-03-29 | 271d |  | finish no earlier than 2002-03-29 | R1 | 2168h | 2168h | RInImp-DSCHhsp | Rel-5 |  |  | Jaeyoel KIM, Samsung |  | TSG |  | 2469 |  |  |
| 1326 | 78.3 | Hybrid ARQ II/III |  | 355d | 2000-08-21 A | 2001-12-28 A | 100% |  | 2000-08-21 | 2001-12-28 | 355d |  | finish no earlier than 2001-12-28 | R2 | 2840h | 2840h | RInImp-HARQ | Rel-5 |  |  | A. Sitte, Siemens |  | TSG |  | 1217 |  |  |
| 1327 | 78.4 | FS on USTS |  | 355d | 2000-08-14 A | 2001-12-21 A | 100% |  | 2000-08-14 | 2001-12-21 | 355d |  | finish no earlier than 2001-12-21 | R1 | 2840h | 2840h | RInImp-USTS | Rel-5 |  |  | D. Kim, SK Telecom |  | TSG |  | 1221 |  | BaAS |
| 1328 | 78.5 | FS on UE antenna efficency test method performance requirements |  | 255d | 2000-09-25 A | 2001-09-14 A | 100% |  | 2000-09-25 | 2001-09-14 | 255d |  | finish no earlier than 2001-09-14 | R4 | 2040h | 2040h | RInImp-UEAnTM | Rel-5 |  |  | O. Edvardsson, Allgon |  | TSG |  | 1997 |  |  |
| 1329 | 78.6 | FS on the re-introduction of the downlink SIR measurement |  | 200d | 2001-03-12 A | 2001-12-14 A | 100% |  | 2001-03-12 | 2001-12-14 | 200d |  | finish no earlier than 2001-12-14 | R4 | 1600h | 1600h | RInImp-SIR | Rel-5 |  | Cesar | Torgny Palenius, Ericsson |  | TSG |  | 24002 |  |  |
| 1330 | 78.7 | FS on mitigating the effect of CPICH interference at the UE |  | 255d | 2001-03-19 A | 2002-03-08 A | 100% |  | 2001-03-19 | 2002-03-08 | 255d |  | finish no earlier than 2002-03-08 | R4 | 2040h | 2040h | RInImp-CPICH_Intf | Rel-5 |  | Cesar | Shimon Moshavi, Intel |  | TSG |  | 24001 |  |  |

Notes:
- 1301: "Joker" WI, to be used for a Rel 6 CR not related to any feature and with very limited impact on the system. Moved in from Stoyan/Testing WP
- 1302: "Joker" WI, to be used for small modifications applicable to Rel 4 conformance testing
- 1303: SP-23 - To be abandoned?
- 1304: Started
- 1307: Started
- 1308: Not started
- 1309: Not started
- 1310: Started
- 1311: Not started
- 1312: Generic feature
- 1315: update WID / 30.11.2001: To CN #14 for approval
- 1318: 30 November: Completion date shifted to March 2002
- 1326: Stopped at RAN#14; work on this task was performed as part of High Speed Downlink Packet Access feature

| ID | WBS | Task | Type | Duration | Start | Finish | Predecessors | Complete | Remaining | Baseline start | Baseline finish | Baseline duration | Total slack | Free slack | Constraint | Resources | Work | Actual work | Text6 | Text9 | Text1 | Text7 | Text8 | Text2 | Text4 | Text3 |
| --- | --- | --- | --- | --- | --- | --- | --- | --- | --- | --- | --- | --- | --- | --- | --- | --- | --- | --- | --- | --- | --- | --- | --- | --- | --- | --- |
| 1331 | 78.8 | **Conformance Test Spec. improvements in Radio Interface** |  | 140d | 2002-02-18 | 2002-08-30 |  |  |  | 2002-02-18 | 2002-08-30 | 140d | 1910d |  |  | T1 | 3360h |  |  |  |  |  |  |  |  |  |
| 1332 | 78.8.1 | Testing improvement of inter-frequency and inter-system measurement |  | 140d | 2002-02-18 | 2002-08-30 |  |  |  | 2002-02-18 | 2002-08-30 | 140d | 1910d |  | finish no earlier than 2002-08-30 | T1 | 1120h |  | Rel-5 | 2210 |  |  |  |  |  |  |
| 1333 | 78.8.2 | Testing Hybrid ARQ II/III |  | 140d | 2002-02-18 | 2002-08-30 |  |  |  | 2002-02-18 | 2002-08-30 | 140d | 1910d |  | finish no earlier than 2002-08-30 | T1 | 1120h |  | Rel-5 | 2211 |  |  |  |  |  |  |
| 1334 | 79 | **Rel-5 RAN improvements** |  | 772d? | 2001-03-16 A | 2004-03-01 |  | 87% | 100.69d? | 2001-03-16 | 2004-03-01 | 772d? | 1519d |  |  | RP | 39984h | 28864h | NA |  | RANimp | TSG | Cesar |  |  |  |
| 1335 | 79.1 | **RRM optimization for Iur and Iub** |  | 318d | 2001-03-16 A | 2002-06-04 A |  | 100% |  | 2001-03-16 | 2002-06-04 | 318d |  |  |  | R3 | 8904h | 8904h | Rel-5 | 656 | RANimp-RRMopt | TSG |  | BaAS | Gert-Jan van Lieshout, Ericsson |  |
| 1336 | 79.1.1 | Iur common transport channel efficiency optimisation |  | 271d | 2001-03-16 A | 2002-03-29 A |  | 100% |  | 2001-03-16 | 2002-03-29 | 271d |  |  | finish no earlier than 2002-03-29 | R3 | 2168h | 2168h |  |  | RANimp-RRMopt-ctc | TSG |  |  | Shahrokh Amirijoo, Ericsson |  |
| 1337 | 79.1.2 | Iur neighbouring cell reporting efficiency optimisation |  | 271d | 2001-03-16 A | 2002-03-29 A |  | 100% |  | 2001-03-16 | 2002-03-29 | 271d |  |  | finish no earlier than 2002-03-29 | R3 | 2168h | 2168h |  |  | RANimp-RRMopt-ncr | TSG |  |  | Shahrokh Amirijoo, Ericsson |  |
| 1338 | 79.1.3 | FS Introduction of direct transport bearers between SRNC and Node-B |  | 253d | 2001-06-15 A | 2002-06-04 A |  | 100% |  | 2001-06-15 | 2002-06-04 | 253d |  |  | finish no earlier than 2002-06-28 | R3 | 2024h | 2024h |  |  | RAN-imp-RRMopt-DTB | TSG |  |  | Risto Sepponen, Ericsson |  |
| 1339 | 79.2 | RL Timing Adjustment |  | 271d | 2001-03-16 A | 2002-03-29 A |  | 100% |  | 2001-03-16 | 2002-03-29 | 271d |  |  | finish no earlier than 2002-03-29 | R3 | 2168h | 2168h | Rel-5 | 22003 | RANimp-RLTA | TSG |  |  | Elena Voltolina, Ericsson |  |
| 1340 | 79.3 | Separation of resource reservation and radio link activation |  | 271d | 2001-03-16 A | 2002-03-29 A |  | 100% |  | 2001-03-16 | 2002-03-29 | 271d |  |  | finish no earlier than 2002-03-29 | R3 | 2168h | 2168h | Rel-5 | 22004 | RANimp-SepRR | TSG |  |  | Gert-Jan van Lieshout, Ericsson |  |
| 1341 | 79.4 | FS SRNS Relocation Procedure Enhancement |  | 318d | 2001-06-15 A | 2002-09-03 A |  | 100% |  | 2001-06-15 | 2002-09-03 | 318d |  |  | finish no earlier than 2002-09-06 | R3 | 2544h | 2544h | Rel-5 |  | RANimp-SRNS | TSG |  |  | Olivier Guyot, Nokia |  |
| 1342 | 79.5 | FS Improvement of Radio Resource Management across RNS and RNS/PSS |  | 201d | 2001-03-16 A | 2001-12-21 A |  | 100% |  | 2001-03-16 | 2001-12-21 | 201d |  |  | finish no earlier than 2001-12-21 | R3 | 1608h | 1608h | Rel-5 | 22001 | RANimp-ImpRRM | TSG |  |  | Antti Toskala, Nokia |  |
| 1343 | 79.6 | Re-arrangements of Iub transport bearers |  | 271d | 2001-03-16 A | 2002-03-29 A |  | 100% |  | 2001-03-16 | 2002-03-29 | 271d |  |  | finish no earlier than 2002-03-29 | R3 | 2168h | 2168h | Rel-5 | 22002 | RANimp-TTPS | TSG |  |  | Antti Toskala, Nokia |  |
| 1344 | 79.7 | RAB support enhancement for Rel-5 |  | 325d | 2001-04-02 A | 2002-06-28 A |  | 100% |  | 2001-04-02 | 2002-06-28 | 325d |  |  | finish no earlier than 2002-06-28 | R2 | 2600h | 2600h | Rel-5 |  | RANimp-RABSE5 | TSG |  |  | Juha Mikola, Nokia |  |
| 1345 | 79.8 | Beamforming requirements for UE |  | 61d | 2001-09-21 A | 2001-12-14 A |  | 100% |  | 2001-09-21 | 2001-12-14 | 61d |  |  | finish no earlier than 2001-12-14 | R1 | 488h | 488h | Rel-5 |  | RANimp-BFR-UE | TSG |  |  | Jussi Kähtävä, Nokia |  |
| 1346 | 79.9 | Support of Site Selection Diversity Transmission in UTRAN |  | 123d | 2001-12-14 A | 2002-06-04 A |  | 100% |  | 2001-12-14 | 2002-06-04 | 123d |  |  | finish no earlier than 2002-06-04 | R1 | 984h | 984h | Rel-5 |  | RANimp-SSDT | TSG |  |  | NEC |  |
| 1347 | 79.10 | Node B Synchronisation for 1.28 Mcps TDD |  | 271d | 2001-03-16 A | 2002-03-29 A |  | 100% |  | 2001-03-16 | 2002-03-29 | 271d |  |  | finish no earlier than 2002-03-29 | R1 | 2168h | 2168h | Rel-5 | 2472 | RANimp-NBSLCR | TSG |  |  | Jinling HU, CWTS/CATT |  |
| 1348 | 79.11 | Start Testing | milestone | 0d | 2001-12-03 | 2001-12-03 |  |  |  | 2001-12-03 | 2001-12-03 | 0d | 1844d | 21d | start no earlier than 2001-12-03 | MLST |  |  |  | 1912 |  |  |  |  |  |  |
| 1349 | 79.12 | **Conformance Test Aspects - RAN Improvements** |  | 565d? | 2002-01-01 | 2004-03-01 | 1348 |  |  | 2002-01-01 | 2004-03-01 | 565d? | 1519d |  |  | T1 | 8008h |  |  | 2102 |  |  |  |  |  | 0% |
| 1350 | 79.12.1 | Testing Radio access bearer support enhancments |  | 175d | 2002-01-01 | 2002-09-02 |  |  |  | 2002-01-01 | 2002-09-02 | 175d | 1909d |  | finish no earlier than 2002-09-02 | T1 | 1400h |  |  | 2222 |  |  |  |  |  |  |
| 1351 | 361.12.2 | General changes to TS34.121 and TS34.122 corresponding to release 5 |  | 261d? | 2003-03-03 | 2004-03-01 |  |  |  | 2003-03-03 | 2004-03-01 | 261d? | 1519d |  | finish no earlier than 2004-03-01 | T1 | 2088h |  | Rel-5 |  | RANimp-test | TSG |  |  |  | 34.108, 34.121, 34.122 |
| 1352 | 80 | UTRAN Sharing in Connected Mode |  | 197d | 2001-12-03 A | 2002-09-03 A |  | 100% |  | 2001-12-03 | 2002-09-03 | 197d |  |  | finish no earlier than 2002-09-06 | R3 | 1576h | 1576h | Rel-5 |  | NETSHARE |  |  |  | Martin Israelsson, Ericsson |  |
| 1353 | 81 | **Provisioning of IP-based multimedia services** |  | 1088d | 2000-01-03 A | 2004-03-03 |  | 92% | 90.44d | 2000-01-03 | 2004-03-03 | 1088d | 1517d |  |  | S1 | 184852h | 166937h | NA |  | IMS | TSG | MichaelC/Alain |  | Mark Cataldo, Openwave |  |
| 1354 | 81.1 | **Call control and roaming to support IMS in UMTS** |  | 640d | 2000-01-03 A | 2002-06-14 |  | 98% | 12.24d | 2000-01-03 | 2002-06-14 | 640d | 1965d |  |  | S2 | 82520h | 77103h | Rel-5 |  | IMS-CCR | TSG |  |  | Liz Daniel, Lucent |  |
| 1355 | 81.1.1 | Stage 1 |  | 215d | 2000-02-21 A | 2000-12-15 A |  | 100% |  | 2000-02-21 | 2000-12-15 | 215d |  |  | finish no earlier than 2000-09-21 | S1 | 1720h | 1720h |  | 1633 |  |  |  | CCaR | Mark Cataldo, Motorola | 22.228 |
| 1356 | 81.1.2 | Stage 2 (Architecture and Main flows) |  | 246d | 2000-04-14 A | 2001-03-23 A |  | 100% |  | 2000-04-14 | 2001-03-23 | 246d |  |  | finish no earlier than 2001-03-23 | S2 | 1968h | 1968h |  | 1514 |  | TSG |  | CCaR | Liz Daniel, Lucent | 23.228 |
| 1357 | 81.1.3 | Impact on MM/CC/SM |  | 400d | 2000-08-28 A | 2002-03-08 A |  | 100% |  | 2000-08-28 | 2002-03-08 | 400d |  |  | finish no earlier than 2002-03-08 | N1 | 3200h | 3200h |  | 1296 | IMS-CCR-IWMM |  |  | CCaR | Keith Drage, Lucent |  |

Notes:
- 1332: start/finish dates set / Not started due to lack of supporting companies
- 1333: start/finish dates set / Not started yet due to lack of supporting companies
- 1338: FS was closed and introduction of WI not agreed at RAN #16
- 1342: FS was closed and WI was introduced at RAN #14
- 1344: RFC 3095 context relocation
- 1346: RP-020356
- 1350: duration set to 6 months (was 0) / Task not started due to lack of supporting companies
- 1352: Formerly 'Shared Network support in connected mode', renamed at RAN #16.
- 1353: S1 WI proposed S1-000290 / TR22.976, WI Rapporteur, Mark Cataldo, Motorola
- 1355: Issues include e.g.: Roaming requirements, Requirements on supplementary services, Interworking requirements / Text5: 17.-21.7., S1#9, Completion of CR's against 22 series [dates taken from 22.976]
- 1356: Issues include e.g.: Mobile IP, RAB selection principles, Optimized VoIP bearer mechanisms, SIP multimedia protocol / Text5: R00 stage 2 at least 80 % complete in TSGS #8 21.-23.6.2000 [WI dates need revision. To be revised by TSG#8]
- 1357: Per 26/2-02: This is understood to be the PCO & TFT CRs which CN1 provides to TSGN #15 for approval. If this is correct understanding, then the task is 100 % complete. / Text5: drage@lucent.com

| ID | WBS | Task | Duration | Start | Finish | Complete | Remaining | Baseline start | Baseline finish | Baseline duration | Total slack | Constraint | Resources | Work | Actual work | Text3 | Text5 | Text7 | Text2 | Text9 | Text1 | Text6 |
| --- | --- | --- | --- | --- | --- | --- | --- | --- | --- | --- | --- | --- | --- | --- | --- | --- | --- | --- | --- | --- | --- | --- |
| 1358 | 81.1.4 | **SIP Call Control protocol for the IMS** | 640d | 2000-01-03 A | 2002-06-14 | 98% | 13.73d | 2000-01-03 | 2002-06-14 | 640d | 1965d |  | N1 | 70800h | 65682h | TS 24.228, TS 24.229, TS 23.218 | drage@lucent.com | TSG |  |  |  |  |
| 1359 | 81.1.4.1 | IMS signalling flows | 385d | 2000-10-02 A | 2002-03-22 A | 100% |  | 2000-10-02 | 2002-03-22 | 385d |  | finish no earlier than 2002-03-22 | N1 | 3080h | 3080h | TS 24.228 |  | TSG | CCaR | 1998 |  |  |
| 1360 | 81.1.4.2 | IMS stage 3 | 385d | 2000-10-02 A | 2002-03-22 A | 100% |  | 2000-10-02 | 2002-03-22 | 385d |  | finish no earlier than 2002-03-22 | N1 | 3080h | 3080h | TS 24.229 |  | TSG | CCaR | 1278 |  |  |
| 1361 | 81.1.4.3 | IMS Session Handling; stage 2 | 385d | 2000-10-02 A | 2002-03-22 A | 100% |  | 2000-10-02 | 2002-03-22 | 385d |  | finish no earlier than 2002-03-22 | N1 | 3080h | 3080h | TS 23.218 |  | TSG |  | 2255 |  |  |
| 1362 | 81.1.4.4 | **Main IETF dependencies** | 635d | 2000-01-03 A | 2002-06-07 | 99% | 0d | 2000-01-03 | 2002-06-07 | 635d | 0d |  | NP | 45392h | 43712h |  |  |  |  |  |  |  |
| 1363 | 81.1.4.4.1 | IETF: RFC 3261 (Session Initiation Protocol) | 346d | 2000-11-24 A | 2002-03-22 A | 100% |  | 2000-11-24 | 2002-03-22 | 346d |  | finish no earlier than 2002-03-22 | N1 | 2768h | 2768h |  |  |  |  |  |  |  |
| 1364 | 81.1.4.4.2 | IETF: RFC 3262 (Reliability of provisional responses) | 346d | 2000-11-24 A | 2002-03-22 A | 100% |  | 2000-11-24 | 2002-03-22 | 346d |  | finish no earlier than 2002-03-22 | N1 | 2768h | 2768h |  |  |  |  |  |  |  |
| 1365 | 81.1.4.4.3 | IETF: RFC 3312 (Without COMET)(Integration of resource management and SIP) | 382d | 2000-11-24 A | 2002-05-13 A | 100% |  | 2000-11-24 | 2002-05-13 | 382d |  | finish no earlier than 2002-05-13 | N1 | 3056h | 3056h |  |  |  |  |  |  |  |
| 1366 | 81.1.4.4.4 | IETF: RFC 3323 (SIP extensions for caller identity and privacy) | 382d | 2000-11-24 A | 2002-05-13 A | 100% |  | 2000-11-24 | 2002-05-13 | 382d |  | finish no earlier than 2002-05-13 | N1 | 3056h | 3056h |  |  |  |  |  |  |  |
| 1367 | 81.1.4.4.5 | IETF: RFC 3313 (SIP extensions for media authorization) | 382d | 2000-11-24 A | 2002-05-13 A | 100% |  | 2000-11-24 | 2002-05-13 | 382d |  | finish no earlier than 2002-05-13 | N1 | 3056h | 3056h |  |  |  |  |  |  |  |
| 1368 | 81.1.4.4.6 | IETF: RFC 3265 (specific event notification) | 346d | 2000-11-24 A | 2002-03-22 A | 100% |  | 2000-11-24 | 2002-03-22 | 346d |  | finish no earlier than 2002-03-22 | N1 | 2768h | 2768h |  |  |  |  |  |  |  |
| 1369 | 81.1.4.4.7 | IETF: RFC editor Queue (refer method) | 401d | 2000-11-24 A | 2002-06-07 A | 100% |  | 2000-11-24 | 2002-06-07 | 401d |  | finish no earlier than 2002-06-07 | N1 | 3208h | 3208h |  |  |  |  |  |  |  |
| 1370 | 81.1.4.4.8 | IETF: RFC editor Queue (DHCP options for SIP servers) | 382d | 2000-11-24 A | 2002-05-13 A | 100% |  | 2000-11-24 | 2002-05-13 | 382d |  | finish no earlier than 2002-05-13 | N1 | 3056h | 3056h |  |  |  |  |  |  |  |
| 1371 | 81.1.4.4.10 | IETF: RFC 3267 (AMR and AMR WB RTP and SDP) | 346d | 2000-11-24 A | 2002-03-22 A | 100% |  | 2000-11-24 | 2002-03-22 | 346d |  | finish no earlier than 2002-03-22 | N1 | 2768h | 2768h |  |  |  |  |  |  |  |
| 1372 | 81.1.4.4.11 | IETF: RFC 3266 (IPv6 support within SDP) | 580d | 2000-01-03 A | 2002-03-22 A | 100% |  | 2000-01-03 | 2002-03-22 | 580d |  | finish no earlier than 2002-03-22 | N1 | 4640h | 4640h |  |  |  |  |  |  |  |
| 1373 | 81.1.4.4.12 | IETF: RFC 3311 (The Update method) | 382d | 2000-11-24 A | 2002-05-13 A | 100% |  | 2000-11-24 | 2002-05-13 | 382d |  | finish no earlier than 2002-05-13 | N1 | 3056h | 3056h |  |  |  |  |  |  |  |
| 1374 | 81.1.4.4.13 | IETF: RFC 3324 (Network Asserted Identity) | 382d | 2000-11-24 A | 2002-05-13 A | 100% |  | 2000-11-24 | 2002-05-13 | 382d |  | finish no earlier than 2002-05-13 | N1 | 3056h | 3056h |  |  |  |  |  |  |  |
| 1375 | 81.1.4.4.14 | IETF: RFC editor Queue (Various 3GPP Private Extensions) | 382d | 2000-11-24 A | 2002-05-13 A | 100% |  | 2000-11-24 | 2002-05-13 | 382d |  | finish no earlier than 2002-05-13 | N1 | 3056h | 3056h |  |  |  |  |  |  |  |
| 1376 | 81.1.4.5 | **Addressing** | 380d | 2000-10-09 A | 2002-03-22 A | 100% |  | 2000-10-09 | 2002-03-22 | 380d |  |  | S2 | 7744h | 7744h |  |  |  | CCaR | 1290 |  |  |
| 1377 | 81.1.4.5.1 | Architectural issues | 235d | 2000-10-09 A | 2001-08-31 A | 100% |  | 2000-10-09 | 2001-08-31 | 235d |  | finish no earlier than 2001-03-16 | S2 | 1880h | 1880h |  |  |  | CCaR | 1291 |  |  |
| 1378 | 81.1.4.5.2 | Impact on HSS | 353d | 2000-11-15 A | 2002-03-22 A | 100% |  | 2000-11-15 | 2002-03-22 | 353d |  | finish no earlier than 2002-03-22 | N4 | 2824h | 2824h |  |  |  | CCaR | 1292 |  |  |
| 1379 | 81.1.4.6 | **Service Examples (Work stopped)** | 304d | 2001-04-17 A | 2002-06-14 | 50% | 152d | 2001-04-17 | 2002-06-14 | 304d | 1965d |  | S1 | 4864h | 1502.4h | 22.928 | mcatald1@email.mot.com | TSG |  |  | IMS-Sex |  |
| 1380 | 81.1.4.6.1 | IMS Framework Report (work stopped) | 304d | 2001-04-17 A | 2002-06-14 | 50% | 152d | 2001-04-17 | 2002-06-14 | 304d | 1965d | finish no earlier than 2002-06-14 | S1 | 2432h | 1216h | 22.941 | rwohlert@tri.sbc.com | TSG |  |  | IMS-FrWk |  |
| 1381 | 81.2 | **Access Security for IMS** | 190d | 2001-10-08 A | 2002-06-28 A | 100% |  | 2001-10-08 | 2002-06-28 | 190d |  |  | S3 | 4120h | 4120h |  | krister.boman@emw.ericsson.se | TSG |  | 1298 | IMS-ASEC | Rel-5 |
| 1382 | 81.2.2 | IMS impacts on UICC (ISIM application) | 185d | 2001-10-08 A | 2002-06-21 A | 100% |  | 2001-10-08 | 2002-06-21 | 185d |  | finish no earlier than 2002-06-21 | T3 | 1480h | 1480h |  |  |  |  |  |  |  |
| 1383 | 81.2.3 | SIP extensions for Integrity protection | 140d | 2001-12-17 A | 2002-06-28 A | 100% |  | 2001-12-17 | 2002-06-28 | 140d |  | finish no earlier than 2002-06-28 | N1 | 1120h | 1120h |  |  |  |  |  |  |  |
| 1384 | 81.3 | Security Aspects of Requirement for Network Configuration Independence | 130d | 2001-07-02 A | 2001-12-28 A | 100% |  | 2001-07-02 | 2001-12-28 | 130d |  | finish no earlier than 2001-12-28 | S3 | 1040h | 1040h |  | hugh.shieh@attws.com | TSG |  |  | SEC1-NCI | Rel-5 |
| 1385 | 81.4 | Lawful interception | 410d | 2000-09-04 A | 2002-03-29 A | 100% |  | 2000-09-04 | 2002-03-29 | 410d |  | finish no earlier than 2002-03-29 | S3 | 3280h | 3280h |  | berthold.wilhelm@regtp.de | TSG | CCaR | 1299 | IMS-LI | Rel-5 |
| 1386 | 81.5 | Charging and OAM&P for IMS | 383d | 2000-12-25 A | 2002-06-12 A | 100% |  | 2000-12-25 | 2002-06-12 | 383d |  | finish no earlier than 2002-06-12 | S5 | 3064h | 3064h | 32-series | Albert.Yuhan@voicestream.com; Michael.Truss@MOTOROLA.COM | TSG | CCaR | 1303 | IMS-OAM | Rel-5 |

Notes:
- 1358: TSGN_10 approved the change:CN1 - SA2 SIP joint meeting spotted one more place for improvement: work tasks with ID 1998 and 1278 are actually subtasks under of single CN1 WT. One WI has been approved for the CN1 WT with title "SIP Call Control protocol... / Text4: Keith Drage, Lucent
- 1359: TS 24.228...
- 1360: TS 24.229...
- 1361: TS 23.218...
- 1378: 17th May, KK: This is cover by 29.228 & 29228. Work complete.
- 1379: Text4: Mark Cataldo, Motorola
- 1380: Text4: Randolph Wohlert, SBC Technology Resources, Inc.
- 1381: TS33.203 will be presented for info at SA#14 and is scheduled for approval at SA#15. Dependencies on IETF exist. Approved SA#15 / Text4: Krister Boman, Ericsson
- 1382: Text4: Jeremy Norris (Vodafone)
- 1383: Per 26/2-02: CN1 is not aware of any requirements and is not doing anything on this task.
- 1384: Incorporated into IMS access security TS (33.203) which will be presented for info at SA#14 and is scheduled for approval at SA#15.Editors notes removed SA#16&17 / Text4: Hugh Shieh, AT&T Wireless Services
- 1385: Rel-5 33.106 and 33.107 approved at SA#12.Revised WID including new Rel-5 specification (33.108) scheduled for approval at SA#14. 33.108 approved SA#16. CR at SA#17 / Text4: Berthold Wilhelm, Reg TP
- 1386: Text4: Albert YUHAN (VoiceStream Wireless), Michael TRUSS (Motorola)

| ID | WBS | Task | Duration | Start | Finish | Complete | Remaining | Baseline start | Baseline finish | Baseline duration | Total slack | Constraint | Resources | Work | Actual work | Text1 | Text3 | Text4 | Text5 | Text6 | Text7 | Text9 | Text2 |
| --- | --- | --- | --- | --- | --- | --- | --- | --- | --- | --- | --- | --- | --- | --- | --- | --- | --- | --- | --- | --- | --- | --- | --- |
| 1387 | 81.6 | **Multimedia codecs and protocols for conversational PS services** | 568d | 2000-07-26 A | 2002-09-27 A | 100% |  | 2000-07-26 | 2002-09-27 | 568d |  |  | S4 | 15640h | 15640h | IMS-CODEC | 26.235, 26.236 | B. Aronson, Toshiba, and P. Ojala, Nokia | pasi.s.ojala@nokia.com | Rel-5 | TSG |  |  |
| 1388 | 81.6.1 | Codecs | 427d | 2000-07-26 A | 2002-03-14 A | 100% |  | 2000-07-26 | 2002-03-14 | 427d |  | finish no earlier than 2001-03-21 | S4 | 3416h | 3416h |  | 26.235, 26.236 |  |  |  | TSG | 2039 |  |
| 1389 | 81.6.2 | Transport protocols | 1d | 2002-03-12 A | 2002-03-12 A | 100% |  | 2002-03-12 | 2002-03-12 | 1d |  | finish no earlier than 2002-03-12 | S4 | 8h | 8h | IMS-CODEC | 26.236 | P. Ojala, Nokia |  | Rel-5 |  |  |  |
| 1390 | 81.6.4 | recommendation for QoS parameter values for various media types | 195d | 2001-12-31 A | 2002-09-27 A | 100% |  | 2001-12-31 | 2002-09-27 | 195d |  | finish no earlier than 2002-09-27 | S4 | 1560h | 1560h |  |  |  |  |  | TSG |  |  |
| 1391 | 81.6.5 | IETF: RFC 3310 (HTTP Digest Authentication using AKA) | 382d | 2000-11-24 A | 2002-05-13 A | 100% |  | 2000-11-24 | 2002-05-13 | 382d |  | finish no earlier than 2002-05-13 | N1 | 3056h | 3056h |  |  |  |  |  |  |  |  |
| 1392 | 81.6.6 | IETF: RFC 3329 (Security mechanism agreement for SIP connections) | 382d | 2000-11-24 A | 2002-05-13 A | 100% |  | 2000-11-24 | 2002-05-13 | 382d |  | finish no earlier than 2002-05-13 | N1 | 3056h | 3056h |  |  |  |  |  |  |  |  |
| 1393 | 81.7 | **SIP message compression** | 185d | 2001-09-24 A | 2002-06-07 A | 100% |  | 2001-09-24 | 2002-06-07 | 185d |  |  | S2 | 3128h | 3128h |  |  |  |  | Rel-5 |  |  |  |
| 1394 | 81.7.1 | Stage 2 | 25d | 2001-09-24 A | 2001-10-26 A | 100% |  | 2001-09-24 | 2001-10-26 | 25d |  | finish no earlier than 2001-10-26 | S2 | 200h | 200h |  |  |  |  |  |  |  |  |
| 1395 | 81.7.2 | Compression signalling | 181d | 2001-09-28 A | 2002-06-07 A | 100% |  | 2001-09-28 | 2002-06-07 | 181d |  | finish no earlier than 2002-06-07 | N1 | 1448h | 1448h |  |  |  |  |  |  |  |  |
| 1396 | 81.8 | **Stage 3 description of IMS interfaces** | 383d | 2001-03-14 A | 2002-08-30 | 99% | 4.93d | 2001-03-14 | 2002-08-30 | 383d | 1910d |  | NP | 29531.6h | 29151.4h |  |  |  |  | Rel-5 |  |  |  |
| 1397 | 81.8.1 | Cx interface (HSS to CSCF) | 135.95d | 2001-03-14 A | 2002-06-07 A | 100% |  | 2001-03-14 | 2002-06-07 | 135.95d |  | finish no earlier than 2002-06-07 | N4 | 1087.58h | 1087.58h |  |  |  |  |  | TSG |  |  |
| 1398 | 81.8.2 | Mp interface (MRFC - MRFP) enhancements | 258d | 2001-03-14 A | 2002-03-08 A | 100% |  | 2001-03-14 | 2002-03-08 | 258d |  | finish no earlier than 2002-06-07 | N4 | 2064h | 2064h |  |  |  |  |  |  |  |  |
| 1399 | 81.8.3 | Mw interface (CSCF to P-CSCF) | 323d | 2001-03-14 A | 2002-06-07 A | 100% |  | 2001-03-14 | 2002-06-07 | 323d |  | finish no earlier than 2002-06-07 | N1 | 2584h | 2584h |  |  |  |  |  |  |  |  |
| 1400 | 81.8.4 | Mr interface (CSCF to MRF) | 273d | 2001-03-14 A | 2002-03-29 A | 100% |  | 2001-03-14 | 2002-03-29 | 273d |  | finish no earlier than 2002-03-29 | N1 | 2184h | 2184h |  |  |  |  |  |  |  |  |
| 1401 | 81.8.5 | Dx interface (I-CSCF to SLF) | 323d | 2001-03-14 A | 2002-06-07 A | 100% |  | 2001-03-14 | 2002-06-07 | 323d |  | finish no earlier than 2002-06-07 | N4 | 2584h | 2584h |  |  |  |  |  |  |  |  |
| 1402 | 81.8.6 | Go interface (GGSN to PCF) | 323d | 2001-03-14 A | 2002-06-07 A | 100% |  | 2001-03-14 | 2002-06-07 | 323d |  | finish no earlier than 2002-06-07 | N3 | 2584h | 2584h |  |  |  |  |  |  |  |  |
| 1403 | 81.8.7 | ISC (IMS Service Control) Interface | 323d | 2001-03-14 A | 2002-06-07 A | 100% |  | 2001-03-14 | 2002-06-07 | 323d |  | finish no earlier than 2002-06-07 | N1 | 2584h | 2584h |  |  |  |  |  |  |  |  |
| 1404 | 81.8.8 | Sh interface (HSS to AS) | 82d | 2002-02-14 A | 2002-06-07 A | 100% |  | 2002-02-14 | 2002-06-07 | 82d |  | finish no earlier than 2002-06-07 | N4 | 656h | 656h |  |  |  |  |  |  |  |  |
| 1405 | 81.8.9 | Si interface (HSS to IM-SSF) | 162.5d | 2002-01-16 A | 2002-08-30 | 72% | 45d | 2002-01-16 | 2002-08-30 | 162.5d | 1910d | finish no earlier than 2002-06-07 | N4 | 1300h | 940h |  |  |  |  |  |  |  |  |
| 1406 | 81.8.10 | Gm interface (UE to CSCF) | 323d | 2001-03-14 A | 2002-06-07 A | 100% |  | 2001-03-14 | 2002-06-07 | 323d |  | finish no earlier than 2002-06-07 | N1 | 2584h | 2584h |  |  |  |  |  |  |  |  |
| 1407 | 81.8.11 | Mi interface (CSCF to BGCF) | 323d | 2001-03-14 A | 2002-06-07 A | 100% |  | 2001-03-14 | 2002-06-07 | 323d |  | finish no earlier than 2002-06-07 | N1 | 2584h | 2584h |  |  |  |  |  |  |  |  |
| 1408 | 81.8.12 | Mj interface (BGCF to MGCF) | 323d | 2001-03-14 A | 2002-06-07 A | 100% |  | 2001-03-14 | 2002-06-07 | 323d |  | finish no earlier than 2002-06-07 | N1 | 2584h | 2584h |  |  |  |  |  |  |  |  |
| 1409 | 81.8.13 | Mk interface (BGCF to BGCF) | 323d | 2001-03-14 A | 2002-06-07 A | 100% |  | 2001-03-14 | 2002-06-07 | 323d |  | finish no earlier than 2002-06-07 | N1 | 2584h | 2584h |  |  |  |  |  |  |  |  |
| 1410 | 81.9 | Support of VHE/OSA by entities and protocols of the IMS (e.g. CSCF) | 186d | 2001-09-21 A | 2002-06-07 A | 100% |  | 2001-09-21 | 2002-06-07 | 186d |  | finish no earlier than 2002-06-07 | N5 | 1488h | 1488h | IMS-ONOSA | 29.198, 29.998 | Ard-Jan MOERDIJK (Ericsson) | Ard.Jan.Moerdijk@eln.ericsson.se | Rel-5 | TSG | 1310 | CCaR |

Notes:
- 1397: DAB 12/12/01 to 75% / CN4 14/02/02 to 79% / 17th May work complete. 3GPP TSs 29.228 and 29.229 will be sent for proval in CN#16
- 1398: [DAB 08-03-02] - No work required in CN4
- 1401: CN4#11 30/11/01: No inputs received in CN4 / 14/02/02 Completed(introduced in 29.228)
- 1402: [DAB - 23/05/03] - 100 % complete
- 1404: CN4#11 30/11/01: No inputs received in CN4 / CN4#12bis 14/02/02: WID approved / 17th May 100% complete. 3GPP TS 29.329 will be sent for approval in CN#16
- 1405: SA16: Part of Rel5 only if completed in September 02

| ID | WBS | Task | Type | Duration | Start | Finish | Predecessors | Complete | Remaining | Baseline start | Baseline finish | Baseline duration | Total slack | Free slack | Constraint | Resources | Work | Actual work | Text1 | Text2 | Text4 | Text6 | Text9 | Text3 | Text5 | Text7 | Text8 |
| --- | --- | --- | --- | --- | --- | --- | --- | --- | --- | --- | --- | --- | --- | --- | --- | --- | --- | --- | --- | --- | --- | --- | --- | --- | --- | --- | --- |
| 1411 | 81.10 | **CAMEL control of IMS services** |  | 365d | 2001-04-16 A | 2002-09-06 |  | 91% | 34.05d | 2001-04-16 | 2002-09-06 | 365d | 1905d |  |  | N2 | 9952h | 9023.6h | IMS-CAMEL | CCaR | Angelica Remoquillo, Lucent | Rel-5 | 1310 |  |  |  |  |
| 1412 | 81.10.1 | Stage2 work 'general' |  | 365d | 2001-04-16 A | 2002-09-06 A |  | 100% |  | 2001-04-16 | 2002-09-06 | 365d |  |  | finish no earlier than 2002-09-06 | N2 | 2920h | 2920h |  |  |  |  |  |  |  |  |  |
| 1413 | 81.10.2 | Stage3 work 'CAP' |  | 175d | 2002-01-07 A | 2002-09-06 A |  | 100% |  | 2002-01-07 | 2002-09-06 | 175d |  |  | finish no earlier than 2002-09-06 | N2 | 1400h | 1400h |  |  |  |  |  |  |  |  |  |
| 1414 | 81.10.3 | Stage2 work 'Si interface' |  | 175d | 2002-01-07 A | 2002-09-06 A |  | 100% |  | 2002-01-07 | 2002-09-06 | 175d |  |  | finish no earlier than 2002-09-06 | N2 | 1400h | 1400h |  |  |  |  |  |  |  |  |  |
| 1415 | 81.10.4 | Stage3 work 'Si interface' |  | 82d | 2002-02-14 A | 2002-06-07 A |  | 100% |  | 2002-02-14 | 2002-06-07 | 82d |  |  | finish no earlier than 2002-06-07 | N4 | 656h | 656h |  |  |  |  |  |  |  |  |  |
| 1416 | 81.10.5 | SDM issues for CAMEL control of IMS |  | 82d | 2002-02-14 | 2002-06-07 |  |  |  | 2002-02-14 | 2002-06-07 | 82d | 1970d |  | finish no earlier than 2002-06-07 | N4 | 656h |  |  |  |  |  |  |  |  |  |  |
| 1417 | 81.11 | Pre-pay/real-time charging in IMS |  | 196d | 2001-06-15 A | 2002-03-15 |  | 60% | 78.4d | 2001-06-15 | 2002-03-15 | 196d | 2030d |  | finish no earlier than 2002-03-15 | S1 | 1568h | 940.8h |  |  |  | TBD |  |  |  |  |  |
| 1418 | 81.12 | **Charging** |  | 289d | 2001-08-06 A | 2002-09-12 A |  | 100% |  | 2001-08-06 | 2002-09-12 | 289d |  |  |  | S5 | 4624h | 4624h | OAM-CH |  | Karl-Heinz NENNER (T-Mobile) | Rel-5 |  | 32.2xy | karl-heinz.nenner@t-mobile.de | TSG |  |
| 1419 | 81.12.1 | Charging Implications of IMS architecture |  | 75d | 2001-08-06 A | 2001-11-16 A |  | 100% |  | 2001-08-06 | 2001-11-16 | 75d |  |  | finish no earlier than 2001-11-16 | S2 | 600h | 600h |  |  |  |  |  |  |  |  |  |
| 1420 | 81.12.2 | Charging management for IMS (off-line & on-line) |  | 214d | 2001-11-19 A | 2002-09-12 A | 1419 | 100% |  | 2001-11-19 | 2002-09-12 | 214d |  |  | finish no earlier than 2002-09-12 | S5 | 1712h | 1712h | OAM-CH |  |  | Rel-5 |  |  |  | TSG |  |
| 1421 | 81.13 | **Other IETF depencies** |  | 401d | 2000-11-24 A | 2002-06-07 |  | 70% | 120.3d | 2000-11-24 | 2002-06-07 | 401d | 1970d |  |  | NP | 9624h | 6736.8h |  |  |  | Rel-5 |  |  |  |  |  |
| 1422 | 81.13.1 | IETF: draft-ietf-aaa-diameter - should be CN4 |  | 401d | 2000-11-24 A | 2002-06-07 |  | 90% | 40.1d | 2000-11-24 | 2002-06-07 | 401d | 1970d |  | finish no earlier than 2002-06-07 | NP | 3208h | 2887.2h |  |  |  |  |  |  |  |  |  |
| 1423 | 81.13.2 | IETF: draft-johansson-aaa-diameter-mm-app - should be CN4 |  | 401d | 2000-11-24 A | 2002-06-07 |  | 50% | 200.5d | 2000-11-24 | 2002-06-07 | 401d | 1970d |  | finish no earlier than 2002-06-07 | NP | 3208h | 1604h |  |  |  |  |  |  |  |  |  |
| 1424 | 81.14 | Start Testing | milestone | 0d | 2002-03-18 | 2002-03-18 |  |  |  | 2002-03-18 | 2002-03-18 | 0d | 1825d | 0d | start no earlier than 2002-03-18 | MLST |  |  |  |  |  | Rel-5 | 1913 |  |  |  |  |
| 1425 | 81.15 | Conformance Test Aspects - Provisioning of IMS |  | 205d | 2002-03-18 | 2002-12-27 | 1424 |  |  | 2002-03-18 | 2002-12-27 | 205d | 1825d |  | finish no earlier than 2002-12-27 | T1 | 1640h |  | IMS-TEST |  |  |  | 1844 |  |  |  |  |
| 1426 | 81.16 | Testing of support for IMS - prose |  | 270d | 2002-09-18 | 2003-09-30 |  |  |  | 2002-09-18 | 2003-09-30 | 270d | 1628d |  | finish no earlier than 2003-09-30 | T1 | 2160h |  |  |  | Dan Fox, Anritsu | Rel-5 |  | 34.108, 34.123 | dan.fox@eu.anritsu.com | TSG |  |
| 1427 | 81.17 | Testing of support for IMS - TTCN |  | 381d | 2002-09-18 | 2004-03-03 |  |  |  | 2002-09-18 | 2004-03-03 | 381d | 1517d |  | finish no earlier than 2004-03-03 | T1 | 3048h |  |  |  | Dan Fox, Anritsu | Rel-5 |  | 34.108, 34.123 | dan.fox@eu.anritsu.com | TSG |  |
| 1428 | 82 | **Extended Transparent End-to-End PS Streaming Service** |  | 313d? | 2002-01-03 A | 2003-03-17 |  | 86% | 44.84d? | 2002-01-03 | 2003-03-17 | 313d? | 1769d |  |  | S4 | 6224h | 4687.32h | PSS-E |  | O. Franceschi, Ericsson | Rel-5 |  | 26.233, 26.234 | olle.franceschi@nrj.ericsson.se | TSG | Paolo |
| 1429 | 82.1 | **Stage 1** |  | 86d? | 2002-11-18 A | 2003-03-17 |  | 65% | 30.1d? | 2002-11-18 | 2003-03-17 | 86d? | 1769d |  |  | S1 | 1376h | 1015.2h |  |  | Stephen Wolak, VODAFONE Group Plc |  |  | 22.233 | stephen.wolak@vodafone.com | TSG |  |
| 1430 | 364.1.1 | Interaction with other services |  | 86d? | 2002-11-18 A | 2003-03-17 |  | 65% | 30.1d? | 2002-11-18 | 2003-03-17 | 86d? | 1769d |  | finish no earlier than 2003-03-17 | S1 | 688h | 447.2h |  |  | Stephen Wolak, VODAFONE Group Plc |  |  | 22.233 | stephen.wolak@vodafone.com | TSG |  |
| 1431 | 82.2 | Stage 2 (version Rel5 of TS 26.234) |  | 51d | 2002-01-03 A | 2002-03-14 A |  | 100% |  | 2002-01-03 | 2002-03-14 | 51d |  |  | finish no earlier than 2002-03-26 | S4 | 408h | 408h |  |  |  |  |  | 26.234 |  | TSG |  |
| 1432 | 82.3 | RTP usage model |  | 242d | 2002-01-03 A | 2002-12-06 |  | 90% | 24.2d | 2002-01-03 | 2002-12-06 | 242d | 1840d |  | finish no earlier than 2002-12-06 | S4 | 1936h | 1742.4h |  |  |  |  |  | 26.937 |  |  |  |
| 1433 | 83 | **Rel-5 OSA enhancements** |  | 639d | 2000-07-11 A | 2002-12-20 |  | 96% | 24.93d | 2000-07-11 | 2002-12-20 | 639d | 1830d |  |  | S1 | 62480h | 57172.1h | OSA1 |  | Jörg Swetina, SIEMENS AG | Rel-5 |  | 22.127, 23.127, 29.198-x, 29.998-x |  | TSG | Adrian |
| 1434 | 83.1 | General Stage 2 for Rel5 |  | 194d | 2001-09-11 A | 2002-06-07 |  | 47% | 103d | 2001-09-11 | 2002-06-07 | 194d | 1970d |  |  | S2 | 1232h | 408h |  |  |  | Rel-5 | 2116 |  |  |  |  |

Notes:
- 1411: SA16: Part of Rel5 only if Si completed in September 02
- 1412: DAB 12.12.01 split into cn4 and cn2 parts
- 1413: DAB 12.12.01 split into cn4 and cn2 parts
- 1414: DAB 12.12.01 split into cn4 and cn2 parts
- 1415: [DAB 08-03-02] - UID 12004 is MASTER of UID 14998 / 17 May need to be recearch possible impact on 23.008 & 23.016, changes to 29.002 are done.
- 1416: [DAB 08-03-02] - No activity on this in CN4
- 1418: Changed Rapp email
- 1421: Was introduced at SA#13 by Ileana Leuca (exact position in the WP and related WG have to be defined)
- 1425: The task is a building block, individual work items are being considered but are constrained by lack of supporting companies
- 1429: 2nd resp SA4
- 1430: 2nd resp SA4
- 1431: 2nd resp SA2

| ID | WBS | Task | Duration | Start | Finish | Predecessors | Complete | Remaining | Baseline start | Baseline finish | Baseline duration | Total slack | Constraint | Resources | Work | Actual work | Text1 | Text6 | Text7 | Text2 | Text3 | Text4 | Text5 | Text8 | Text9 |
| --- | --- | --- | --- | --- | --- | --- | --- | --- | --- | --- | --- | --- | --- | --- | --- | --- | --- | --- | --- | --- | --- | --- | --- | --- | --- |
| 1435 | 83.2 | **OSA APIs for Multimedia Call Control** | 499d | 2000-07-11 A | 2002-06-07 A |  | 100% |  | 2000-07-11 | 2002-06-07 | 499d |  |  | S2 | 5960h | 5960h | OSA1-CSCF | Rel-5 | TSG |  |  |  |  |  |  |
| 1436 | 83.2.1 | Stage 1 | 438d | 2000-07-11 A | 2002-03-14 A |  | 100% |  | 2000-07-11 | 2002-03-14 | 438d |  | finish no earlier than 2002-03-14 | S1 | 3504h | 3504h |  |  | TSG | Ser | 22.127 | Manfred Leitgeb, SIEMENS AG | Manfred.leitgeb@siemens.at | Michael | 1430 |
| 1437 | 83.2.2 | (Multimedia) Call Control - Stages 2 and 3 | 194d | 2001-09-11 A | 2002-06-07 A |  | 100% |  | 2001-09-11 | 2002-06-07 | 194d |  | finish no earlier than 2002-06-07 | N5 | 1552h | 1552h |  |  | TSG |  | 29.198-04 |  |  |  |  |
| 1438 | 83.3 | Generic user interaction - Stage 3 | 194d | 2001-09-11 A | 2002-06-07 A |  | 100% |  | 2001-09-11 | 2002-06-07 | 194d |  | finish no earlier than 2002-06-07 | N5 | 1552h | 1552h |  | Rel-5 | TSG |  | 29.198-05 |  |  |  |  |
| 1439 | 83.4 | Charging - Stage 3 | 194d | 2001-09-11 A | 2002-06-07 A |  | 100% |  | 2001-09-11 | 2002-06-07 | 194d |  | finish no earlier than 2002-06-07 | N5 | 1552h | 1552h |  | Rel-5 | TSG |  | 29.198-12 |  |  |  |  |
| 1440 | 83.5 | Call Control Service Mapping; Multiparty Call Control SIP - Stage 3 | 194d | 2001-09-11 A | 2002-06-07 A |  | 100% |  | 2001-09-11 | 2002-06-07 | 194d |  | finish no earlier than 2002-06-07 | N5 | 1552h | 1552h |  | Rel-5 | TSG |  | 29.998-04-4 |  |  |  |  |
| 1441 | 83.6 | WSDL APIs for SOAP/HTTP - Stage 3 | 455d | 2000-09-11 A | 2002-06-07 A |  | 100% |  | 2000-09-11 | 2002-06-07 | 455d |  | finish no earlier than 2002-06-07 | N5 | 3640h | 3640h |  | Rel-5 | TSG |  | 29.198, 29.998 |  |  |  |  |
| 1442 | 83.7 | **OSA security** | 639d | 2000-07-11 A | 2002-12-20 |  | 93% | 44.46d | 2000-07-11 | 2002-12-20 | 639d | 1830d |  | S3 | 15000h | 13956.3h | OSA1-SEC | Rel-5 | TSG | Ser |  | Colin Blanchard, BT | colin.blanchard@bt.com |  | 1419 |
| 1443 | 83.7.1 | Stage 1 | 349d | 2000-07-11 A | 2001-11-09 A |  | 100% |  | 2000-07-11 | 2001-11-09 | 349d |  | finish no earlier than 2001-11-09 | S1 | 2792h | 2792h |  |  | TSG |  | 22.127 | Manfred Leitgeb, SIEMENS AG | Manfred.leitgeb@siemens.at | Michael | 2121 |
| 1444 | 83.7.2 | Stage 3 | 430d | 2000-10-23 A | 2002-06-14 |  | 80% | 86d | 2000-10-23 | 2002-06-14 | 430d | 1965d | finish no earlier than 2002-06-14 | S3 | 3440h | 2752h |  |  | TSG | Ser | ??? |  |  |  | 1421 |
| 1445 | 83.7.3 | security related SCF(s) definition | 186d | 2001-09-21 A | 2002-06-07 A |  | 100% |  | 2001-09-21 | 2002-06-07 | 186d |  | finish no earlier than 2002-06-07 | N5 | 1488h | 1488h |  |  | TSG | Ser | 29.198, 29.998 | Ard-Jan MOERDIJK (Ericsson) | Ard.Jan.Moerdijk@eln.ericsson.se |  | 1422 |
| 1446 | 83.7.4 | (possibly) changes required from supporting platforms, e.g. gsmSCF, HLR | 69d | 2000-09-11 A | 2000-12-14 A |  | 100% |  | 2000-09-11 | 2000-12-14 | 69d |  | finish no earlier than 2000-12-14 | S3 | 552h | 552h |  |  | TSG | Ser | ??? |  |  |  | 1423 |
| 1447 | 365.7.5 | Security (moved from Rel-6) | 202d | 2002-03-14 A | 2002-12-20 A |  | 100% |  | 2002-03-14 | 2002-12-20 | 202d |  | finish no earlier than 2002-12-20 | S3 | 1616h | 1616h |  |  | TSG |  |  |  |  |  |  |
| 1448 | 83.8 | **Interactions OSA - e-commerce** | 499d | 2000-07-11 A | 2002-06-07 |  | 96% | 17.51d | 2000-07-11 | 2002-06-07 | 499d | 1970d |  | S2 | 6152h | 5976.8h | OSA1-ECOM | Rel-5 | TSG |  |  |  |  |  | 1424 |
| 1449 | 83.8.1 | Stage 1 | 438d | 2000-07-11 A | 2002-03-14 |  | 95% | 21.9d | 2000-07-11 | 2002-03-14 | 438d | 2031d | finish no earlier than 2000-12-28 | S1 | 3504h | 3328.8h |  |  | TSG |  | 22.127 | Jörg Swetina, SIEMENS AG |  |  | 1425 |
| 1450 | 83.8.2 | Stages 2 and 3 | 186d | 2001-09-21 A | 2002-06-07 A |  | 100% |  | 2001-09-21 | 2002-06-07 | 186d |  | finish no earlier than 2002-06-07 | N5 | 1488h | 1488h |  |  | TSG |  | 29.198, 29.998 | Ard-Jan MOERDIJK (Ericsson) | Ard.Jan.Moerdijk@eln.ericsson.se |  | 1529 |
| 1451 | 83.9 | Policy Management - Stage 3 | 194d | 2001-09-11 A | 2002-06-07 A |  | 100% |  | 2001-09-11 | 2002-06-07 | 194d |  | finish no earlier than 2002-06-07 | N5 | 1552h | 1552h |  | Rel-5 | TSG |  | 29.198-13 |  |  |  |  |
| 1452 | 83.10 | Presence and Availability Management (PAM) - Stage 3 | 194d | 2001-09-11 A | 2002-06-07 A |  | 100% |  | 2001-09-11 | 2002-06-07 | 194d |  | finish no earlier than 2002-06-07 | N5 | 1552h | 1552h |  | Rel-5 | TSG |  | 29.198-14 |  |  |  |  |
| 1453 | 83.11 | **CHECK STATUS - LCS - OSA interfaces** | 455d | 2000-09-11 A | 2002-06-07 |  | 99% | 0d | 2000-09-11 | 2002-06-07 | 455d | 0d |  | S1 | 5656h | 2590.4h | OSA1-LCSI | Rel-5 | TSG | Ser |  | Jörg Swetina, SIEMENS AG |  |  | 1786 |
| 1454 | 83.11.1 | Stage 1 | 65d | 2000-09-11 A | 2000-12-08 A |  | 100% |  | 2000-09-11 | 2000-12-08 | 65d |  | finish no earlier than 2000-12-08 | S1 | 520h | 520h |  |  | TSG | Ser | 22.127 | Jörg Swetina, SIEMENS AG |  |  | 1787 |
| 1455 | 83.11.2 | Stage 2 | 1d | 2000-12-11 A | 2000-12-11 A | 1454 | 100% |  | 2000-12-11 | 2000-12-11 | 1d |  | finish no earlier than 2000-12-11 | S2 | 8h | 8h |  |  | TSG |  | 23.127 | Christophe GOURRAUD, Ericsson Canada |  |  | 2124 |
| 1456 | 83.11.3 | Stage 3 | 186d | 2001-09-21 A | 2002-06-07 A | 1455 | 100% |  | 2001-09-21 | 2002-06-07 | 186d |  | finish no earlier than 2002-06-07 | N5 | 1488h | 1488h |  |  | TSG | Ser | 29.198, 29.998 | Ard-Jan MOERDIJK (Ericsson) | Ard.Jan.Moerdijk@eln.ericsson.se |  | 1788 |
| 1457 | 365.12 | Access to User Profile | 145d | 2001-06-01 A | 2001-12-20 A |  | 100% |  | 2001-06-01 | 2001-12-20 | 145d |  | finish no earlier than 2001-12-20 | S1 | 1160h | 1160h | OSA2-UP | Rel-5 | TSG |  |  |  |  |  |  |
| 1458 | 365.13 | **Retrieval of Terminal capabilities** | 634d | 2000-07-11 A | 2002-12-13 A |  | 100% |  | 2000-07-11 | 2002-12-13 | 634d |  |  | S2 | 10808h | 10808h | OSA2-TC | Rel-5 | TSG | Ser |  |  |  |  | 1433 |
| 1459 | 365.13.1 | Stage 1 | 132d | 2000-07-11 A | 2001-01-10 A |  | 100% |  | 2000-07-11 | 2001-01-10 | 132d |  | finish no earlier than 2001-01-10 | S1 | 1056h | 1056h |  | Rel-5 | TSG | Ser | 22.127 | Jörg Swetina, SIEMENS AG |  |  | 1434 |
| 1460 | 365.13.2 | Stages 2 and 3 | 321d | 2001-09-21 A | 2002-12-13 A | 1459 | 100% |  | 2001-09-21 | 2002-12-13 | 321d |  | finish no earlier than 2002-12-13 | N5 | 2568h | 2568h |  | Rel-5 | TSG | Ser | 29.198, 29.998 | Ard-Jan MOERDIJK (Ericsson) | Ard.Jan.Moerdijk@eln.ericsson.se |  | 1436 |
| 1461 | 365.13.3 | Provisionning of the terminal capabilities | 445d | 2001-04-02 A | 2002-12-13 A |  | 100% |  | 2001-04-02 | 2002-12-13 | 445d |  | finish no earlier than 2002-12-13 | T2 | 3560h | 3560h |  | Rel-5 | TSG |  | 23.057 |  |  |  | 2122 |

Notes:
- 1435: For Rel5 even if completed by March
- 1442: CR to correct security specifications in 29.198 scheduled for approval at CN#15
- 1444: ??
- 1447: Contribution at S3#25
- 1453: az: CN#13 - changed to Rel5
- 1455: az 24/05/01: Rel4 completion 90->100%.
- 1461: According to T2 SWG1 M. Cataldo this is automatically supported by the MExE support of UAProf therefore 100% complete

| ID | WBS | Task | Duration | Start | Finish | Predecessors | Complete | Remaining | Baseline start | Baseline finish | Baseline duration | Total slack | Constraint | Resources | Work | Actual work | Text1 | Text4 | Text5 | Text6 | Text7 | Text8 | Text9 | Text2 | Text3 |
| --- | --- | --- | --- | --- | --- | --- | --- | --- | --- | --- | --- | --- | --- | --- | --- | --- | --- | --- | --- | --- | --- | --- | --- | --- | --- |
| 1462 | 84 | **CAMEL phase 4** | 625d | 2000-04-17 A | 2002-09-06 |  | 99% | 0d | 2000-04-17 | 2002-09-06 | 625d | 0d |  | S1 | 41104h | 36244h | CAMEL4 | Keijo Palviainen, Nokia | keijo.palviainen@nokia.com | Rel-5 | WG | Andrijana | 1638 |  |  |
| 1463 | 84.1 | Service requirements | 565d | 2000-04-17 A | 2002-06-14 A |  | 100% |  | 2000-04-17 | 2002-06-14 | 565d |  | finish no earlier than 2002-06-14 | S1 | 4520h | 4520h |  |  |  |  | WG |  | 1461 | Ser |  |
| 1464 | 84.2 | Call Party Handling | 500d | 2000-07-10 A | 2002-06-07 A |  | 100% |  | 2000-07-10 | 2002-06-07 | 500d |  | finish no earlier than 2002-06-07 | N2 | 4000h | 4000h | CAMEL4-CPH |  |  |  | WG |  | 2012 | Ser |  |
| 1465 | 84.3 | Mid call procedure for MO and MT calls | 495d | 2000-07-17 A | 2002-06-07 A |  | 100% |  | 2000-07-17 | 2002-06-07 | 495d |  | finish no earlier than 2002-06-07 | N2 | 3960h | 3960h | CAMEL4-MCP |  |  |  | WG |  | 2013 | Ser |  |
| 1466 | 84.4 | Interactions with Optimal Routing | 430d | 2000-07-17 A | 2002-03-08 A |  | 100% |  | 2000-07-17 | 2002-03-08 | 430d |  | finish no earlier than 2002-03-08 | N2 | 3440h | 3440h | CAMEL4-IOR |  |  |  | WG |  | 2014 | Ser |  |
| 1467 | 84.5 | Inclusion of flexible tone injection | 430d | 2000-07-17 A | 2002-03-08 A |  | 100% |  | 2000-07-17 | 2002-03-08 | 430d |  | finish no earlier than 2002-03-08 | N2 | 3440h | 3440h | CAMEL4-IFTI |  |  |  | WG |  | 2015 | Ser |  |
| 1468 | 84.6 | CSE control over MT SMS | 430d | 2000-07-17 A | 2002-03-08 A |  | 100% |  | 2000-07-17 | 2002-03-08 | 430d |  | finish no earlier than 2002-03-08 | N2 | 3440h | 3440h | CAMEL4-CCSMS |  |  |  | WG |  | 2016 | Ser |  |
| 1469 | 84.7 | Notification of GPRS mobility management to CSE | 331d | 2001-03-02 A | 2002-06-07 A |  | 100% |  | 2001-03-02 | 2002-06-07 | 331d |  | finish no earlier than 2002-06-07 | N2 | 2648h | 2648h | CAMEL4-NMM |  |  |  | WG |  | 2460 |  |  |
| 1470 | 84.8 | Provision of location information of called subscriber | 266d | 2001-03-02 A | 2002-03-08 A |  | 100% |  | 2001-03-02 | 2002-03-08 | 266d |  | finish no earlier than 2002-03-08 | N2 | 2128h | 2128h | CAMEL4-LOCB |  |  |  | WG |  | 2458 |  |  |
| 1471 | 84.9 | Inclusion of ODB data in the CSE_HLR interface | 175d | 2001-07-09 A | 2002-03-08 A |  | 100% |  | 2001-07-09 | 2002-03-08 | 175d |  | finish no earlier than 2002-03-08 | N2 | 1400h | 1400h | CAMEL4-ODB |  |  |  | WG |  |  |  |  |
| 1472 | 84.10 | Location information during an ongoing call (Handover DP) | 280d | 2001-05-14 A | 2002-06-07 A |  | 100% |  | 2001-05-14 | 2002-06-07 | 280d |  | finish no earlier than 2002-06-07 | N2 | 2240h | 2240h | CAMEL4-HODP |  |  |  | WG |  |  |  |  |
| 1473 | 84.11 | GPRS Any Time Interrogation | 240d | 2001-07-09 A | 2002-06-07 A |  | 100% |  | 2001-07-09 | 2002-06-07 | 240d |  | finish no earlier than 2002-06-07 | N2 | 1920h | 1920h | CAMEL4-ATI |  |  |  | WG |  |  |  |  |
| 1474 | 84.12 | Transfer of IMEI (with SW version) to CSE | 240d | 2001-07-09 A | 2002-06-07 A |  | 100% |  | 2001-07-09 | 2002-06-07 | 240d |  | finish no earlier than 2002-06-07 | N2 | 1920h | 1920h | CAMEL4-ATI |  |  |  | WG |  |  |  |  |
| 1475 | 84.13 | Handling of partial implementations of CAMEL4 | 131d | 2002-03-08 A | 2002-09-06 A |  | 100% |  | 2002-03-08 | 2002-09-06 | 131d |  | finish no earlier than 2002-06-07 | N2 | 1048h | 1048h | CAMEL4-SUB |  |  |  | WG |  |  |  |  |
| 1476 | 85 | **Rel-5 MExE enhancements** | 250d | 2001-03-26 A | 2002-03-08 A |  | 100% |  | 2001-03-26 | 2002-03-08 | 250d |  |  | T2 | 2880h | 2880h | MEXE5 |  |  | Rel-5 | TSG | Friedhelm | 2464 | Ter |  |
| 1477 | 85.1 | MExE Rel-5 Improvements and Investigations | 110d | 2001-03-26 A | 2002-03-08 A |  | 100% |  | 2001-03-26 | 2002-03-08 | 110d |  | finish no earlier than 2001-12-17 | T2 | 880h | 880h | MEXE5-ENHANC | Mark CATALDO, Motorola | mcatald1@MOTOROLA.COM |  | TSG |  | 2466 | Ter | 22.057, 23.057 |
| 1478 | 86 | **Wideband Telephony Service - AMR** | 1035d | 2000-01-01 A | 2003-12-19 |  | 83% | 179.73d | 2000-01-01 | 2003-12-19 | 1035d | 1570d |  | S4 | 83992h | 65964.1h | AMRWB | Imre Varga, Siemens AG | Imre.Varga@mch.siemens.de | Rel-5 | TSG | Paolo |  |  |  |
| 1479 | 86.1 | **Specification** | 704d | 2000-01-01 A | 2002-09-12 |  | 99% | 0.4d | 2000-01-01 | 2002-09-12 | 704d | 1901d |  | S4 | 22512h | 22482h |  |  |  | Rel-5 |  |  |  |  |  |
| 1480 | 86.1.1 | Stage 1 | 125d | 2001-10-01 A | 2002-03-22 A |  | 100% |  | 2001-10-01 | 2002-03-22 | 125d |  | finish no earlier than 2002-03-22 | S1 | 1000h | 1000h |  |  |  | Rel-5 |  |  |  |  |  |
| 1481 | 86.1.2 | **Stage 2** | 76d | 2000-01-03 A | 2000-04-17 A |  | 100% |  | 2000-01-03 | 2000-04-17 | 76d |  |  | S4 | 1224h | 1224h |  |  |  | Rel-5 |  |  |  |  |  |
| 1482 | 86.1.2.1 | Design Constraints | 26d | 2000-01-03 A | 2000-02-07 A |  | 100% |  | 2000-01-03 | 2000-02-07 | 26d |  |  | S4 | 208h | 208h |  |  |  | Rel-5 |  |  | 1459 | Cod |  |
| 1483 | 86.1.2.2 | General Description | 51d | 2000-02-07 A | 2000-04-17 A | 1482 | 100% |  | 2000-02-07 | 2000-04-17 | 51d |  | start no earlier than 2000-09-25 | S4 | 408h | 408h |  |  |  | Rel-5 |  |  | 1460 | Cod |  |
| 1484 | 86.1.3 | Feasibility Study | 26d | 2000-04-28 A | 2000-06-02 A | 1483 | 100% |  | 2000-04-28 | 2000-06-02 | 26d |  | finish no earlier than 2000-06-02 | S4 | 208h | 208h |  |  |  | Rel-5 | TSG |  | 1626 | Cod | TR 26.901 |
| 1485 | 86.1.4 | N1 Aspects | 66d | 2001-09-21 A | 2001-12-21 A |  | 100% |  | 2001-09-21 | 2001-12-21 | 66d |  | finish no earlier than 2001-12-21 | N1 | 528h | 528h |  |  |  | Rel-5 | TSG |  | 1656 |  |  |
| 1486 | 86.1.5 | N4 work | 83d | 2002-02-13 A | 2002-06-07 A |  | 100% |  | 2002-02-13 | 2002-06-07 | 83d |  | finish no earlier than 2002-06-07 | N4 | 664h | 664h |  |  |  | Rel-5 | TSG |  | 1656 |  |  |

Notes:
- 1471: Added on May 29, 2001
- 1475: stage2 and stage3 CRs for approval at CN#17
- 1484: S4,TD SP-000024: TR 26.901 v.4.0.0
- 1485: Some of N1 tasks: Indication of supported codecs by the MS, Bearer cap negociation, codec indication to MS... / One common set of codec negotiation procedures will be specified as in ID1657.
- 1486: CN4#11 30/11/01: No inputs to CN4 at this meeting / 14/02/02 work started 50% reached / 17 May work is done 100%

| ID | WBS | Task | Type | Duration | Start | Finish | Predecessors | Complete | Remaining | Baseline start | Baseline finish | Baseline duration | Total slack | Constraint | Resources | Work | Actual work | Text6 | Text2 | Text7 | Text9 | Text1 | Text3 | Text4 | Text5 | Text8 |
| --- | --- | --- | --- | --- | --- | --- | --- | --- | --- | --- | --- | --- | --- | --- | --- | --- | --- | --- | --- | --- | --- | --- | --- | --- | --- | --- |
| 1487 | 86.1.6 | **Codec issues** |  | 704d | 2000-01-03 A | 2002-09-12 |  | 99% | 0.54d | 2000-01-03 | 2002-09-12 | 704d | 1901d |  | S4 | 11504h | 11496h | Rel-5 |  |  |  |  |  |  |  |  |
| 1488 | 86.1.6.1 | Codec qualification |  | 86d | 2000-02-01 A | 2000-05-30 A |  | 100% |  | 2000-02-01 | 2000-05-30 | 86d |  | finish no earlier than 2000-05-31 | S4 | 688h | 688h | Rel-5 | Cod | TSG | 1627 |  |  |  |  |  |
| 1489 | 86.1.6.2 | Codec selection tests |  | 102d | 2000-06-01 A | 2000-10-20 A | 1488 | 100% |  | 2000-06-01 | 2000-10-20 | 102d |  | finish no earlier than 2000-10-20 | S4 | 816h | 816h | Rel-5 | Cod |  | 74 |  |  |  |  |  |
| 1490 | 86.1.6.3 | Codec selection |  | 5d | 2000-10-23 A | 2000-10-27 A | 1489 | 100% |  | 2000-10-23 | 2000-10-27 | 5d |  | finish no earlier than 2000-10-27 | S4 | 40h | 40h | Rel-5 | Cod |  | 891 |  |  |  |  |  |
| 1491 | 86.1.6.4 | TFO AMR-WB |  | 63d | 2001-12-18 A | 2002-03-14 A |  | 100% |  | 2001-12-18 | 2002-03-14 | 63d |  | finish no earlier than 2002-03-14 | S4 | 504h | 504h | Rel-5 |  |  |  | AMRWB-TFO |  |  |  |  |
| 1492 | 86.1.6.5 | Other codec issues (verif., caracterisation) |  | 441d | 2000-09-29 A | 2002-06-07 A |  | 100% |  | 2000-09-29 | 2002-06-07 | 441d |  | finish no earlier than 2002-06-07 | S4 | 3528h | 3528h | Rel-5 | Cod |  | 890 |  | TR 26.976 |  |  |  |
| 1493 | 86.1.6.6 | AMR-WB and narrrowband interworking |  | 121d | 2001-09-27 A | 2002-03-14 A |  | 100% |  | 2001-09-27 | 2002-03-14 | 121d |  | finish no earlier than 2002-03-14 | S4 | 968h | 968h | Rel-5 |  |  |  | AMRWB-IWG |  |  |  |  |
| 1494 | 86.1.6.7 | Interworking with fixed broadband networks |  | 121d | 2001-09-27 A | 2002-03-14 A |  | 100% |  | 2001-09-27 | 2002-03-14 | 121d |  | finish no earlier than 2002-03-14 | S4 | 968h | 968h | Rel-5 |  |  |  |  |  |  |  |  |
| 1495 | 86.1.6.8 | Tones and announcements |  | 121d | 2001-09-27 A | 2002-03-14 A |  | 100% |  | 2001-09-27 | 2002-03-14 | 121d |  | finish no earlier than 2002-03-14 | S4 | 968h | 968h | Rel-5 |  |  |  |  |  |  |  |  |
| 1496 | 86.1.6.9 | WB Conferencing and WB Voice Group calls (deleted) |  | 1d | 2000-01-03 | 2000-01-03 |  |  |  | 2000-01-03 | 2000-01-03 | 1d | 2604d | finish no earlier than 2000-01-03 | S1 | 8h |  | Rel-5 |  |  |  |  |  |  |  |  |
| 1497 | 86.1.6.10 | Billing, accounting and call detail record aspects |  | 251d | 2001-09-27 A | 2002-09-12 A |  | 100% |  | 2001-09-27 | 2002-09-12 | 251d |  | finish no earlier than 2002-09-12 | S5 | 2008h | 2008h | Rel-5 |  |  |  |  | 32.2xy | Karl-Heinz NENNER (T-Mobile) | Karl-Heinz.Nenner@T-MOBILE.DE |  |
| 1498 | 86.1.7 | Start Testing | milestone | 0d | 2002-02-25 | 2002-02-25 |  |  |  | 2002-02-25 | 2002-02-25 | 0d | 2045d | start no earlier than 2002-02-25 | MLST |  |  | Rel-5 |  |  | 1989 |  |  |  |  |  |
| 1499 | 86.1.8 | **Conformance tests (CRs to 34 series)** |  | 73d | 2000-01-01 A | 2000-04-12 A | 1498 | 100% |  | 2000-01-01 | 2000-04-12 | 73d |  |  | T1 | 1752h | 1752h | Rel-5 | Cod |  | 1855 |  |  |  |  |  |
| 1500 | 86.1.8.1 | **Terminal Acoustic Characteristics** |  | 73d | 2000-01-01 A | 2000-04-12 A |  | 100% |  | 2000-01-01 | 2000-04-12 | 73d |  |  | S4 | 1168h | 1168h | Rel-5 | Cod |  | 76 |  |  |  |  |  |
| 1501 | 86.1.8.1.1 | Definition |  | 21d | 2000-01-01 A | 2000-01-31 A |  | 100% |  | 2000-01-01 | 2000-01-31 | 21d |  | finish no earlier than 2000-01-28 | S4 | 168h | 168h | Rel-5 | Cod | TSG | 1628 |  | 26.131 |  |  |  |
| 1502 | 86.1.8.1.2 | Test specification |  | 52d | 2000-02-01 A | 2000-04-12 A | 1501 | 100% |  | 2000-02-01 | 2000-04-12 | 52d |  | finish no earlier than 2000-03-13 | S4 | 416h | 416h | Rel-5 | Cod | TSG | 1629 |  | 26.132 |  |  |  |
| 1503 | 86.2 | Floating-point ANSI-C code for the AMR-WB speech codec |  | 123d | 2001-09-25 A | 2002-03-14 A |  | 100% |  | 2001-09-25 | 2002-03-14 | 123d |  | finish no earlier than 2002-03-14 | S4 | 984h | 984h | Rel-5 |  | TSG |  | AMRWB-FP | TS 26.204 | J. Vainio (Nokia) | janne.m.vainio@nokia.com |  |
| 1504 | 86.3 | **Support of AMR-WB in GERAN: GMSK and 8PSK WB FR / HR** |  | 650d | 2000-01-03 A | 2002-06-28 A |  | 100% |  | 2000-01-03 | 2002-06-28 | 650d |  |  | GP | 23480h | 23480h | Rel-5 | Cod | TSG | 80 | GAMRWB |  |  |  | Paolo |
| 1505 | 86.3.1 | Channel coding in 45.003 |  | 590d | 2000-01-03 A | 2002-04-05 A |  | 100% |  | 2000-01-03 | 2002-04-05 | 590d |  |  | GP | 4720h | 4720h | Rel-5 |  | TSG | 2265 |  |  |  |  |  |
| 1506 | 86.3.2 | Signalling for the A interface |  | 390d | 2000-01-03 A | 2001-06-29 A |  | 100% |  | 2000-01-03 | 2001-06-29 | 390d |  | finish no earlier than 2001-06-29 | GP | 3120h | 3120h | Rel-5 |  | TSG | 2266 |  |  |  |  |  |
| 1507 | 86.3.3 | Signalling for Iu |  | 650d | 2000-01-03 A | 2002-06-28 A |  | 100% |  | 2000-01-03 | 2002-06-28 | 650d |  | finish no earlier than 2002-06-28 | GP | 5200h | 5200h | Rel-5 |  | TSG | 2267 |  |  |  |  |  |
| 1508 | 86.3.4 | Receiver performance in TS 45.005 |  | 325d | 2001-04-02 A | 2002-06-28 A |  | 100% |  | 2001-04-02 | 2002-06-28 | 325d |  | finish no earlier than 2002-06-28 | GP | 2600h | 2600h | Rel-5 |  | TSG | 2268 |  |  |  |  |  |
| 1509 | 86.3.5 | Link Adaptation in 45.009 |  | 330d | 2001-03-26 A | 2002-06-28 A |  | 100% |  | 2001-03-26 | 2002-06-28 | 330d |  | finish no earlier than 2002-06-28 | GP | 2640h | 2640h | Rel-5 |  |  |  |  |  |  |  |  |
| 1510 | 86.4 | **GERAN MS conformance test for AMR-WB** |  | 1035d | 2000-01-03 | 2003-12-19 |  |  |  | 2000-01-03 | 2003-12-19 | 1035d | 1570d |  | GP | 16560h |  | Rel-5 |  | TSG | 2269 |  |  |  |  | Paolo |
| 1511 | 86.4.1 | MS test |  | 1035d | 2000-01-03 | 2003-12-19 |  |  |  | 2000-01-03 | 2003-12-19 | 1035d | 1570d | finish no earlier than 2003-12-19 | GP | 8280h |  | Rel-5 |  | TSG | 2270 |  |  |  |  |  |

Notes:
- 1492: ANSI C-Code , Test Sequences, Speech Transcoding Functions, Error Concealment of lost frames, Source Controlled Bit-Rate Operation, Voice Activity Detector, Frame Structure
- 1505: 50098 -> 50298
- 1510: Not started

| ID | WBS | Task | Duration | Start | Finish | Complete | Remaining | Baseline start | Baseline finish | Baseline duration | Total slack | Constraint | Resources | Work | Actual work | Text6 | Text7 | Text8 | Text9 | Text1 | Text2 | Text3 | Text4 | Text5 |
| --- | --- | --- | --- | --- | --- | --- | --- | --- | --- | --- | --- | --- | --- | --- | --- | --- | --- | --- | --- | --- | --- | --- | --- | --- |
| 1512 | 86.5 | **GERAN BTS conformance test for AMR-WB** | 761d | 2000-01-03 A | 2002-12-02 A | 100% |  | 2000-01-03 | 2002-12-02 | 761d |  |  | GP | 12176h | 12176h | Rel-5 | TSG | Paolo | 2271 |  |  |  |  |  |
| 1513 | 86.5.1 | BTS test | 761d | 2000-01-03 A | 2002-12-02 A | 100% |  | 2000-01-03 | 2002-12-02 | 761d |  | finish no earlier than 2002-12-02 | GP | 6088h | 6088h | Rel-5 | TSG |  | 2272 |  |  |  |  |  |
| 1514 | 11 | **Terminal interfaces** | 223d | 2001-05-14 A | 2002-03-20 A | 100% |  | 2001-05-14 | 2002-03-20 | 223d |  |  | T2 | 3568h | 3568h | Rel-5 |  | Friedhelm | 1826 | TI | Ter |  |  |  |
| 1515 | 87 | Terminal local model enhancements | 223d | 2001-05-14 A | 2002-03-20 A | 100% |  | 2001-05-14 | 2002-03-20 | 223d |  | finish no earlier than 2002-03-20 | T2 | 1784h | 1784h | Rel-5 | TSG |  | 1832 | TLM5 | Ter | 23.227 |  |  |
| 1516 | 88 | **Rel-5 Location Services enhancements** | 845d | 2000-04-03 A | 2003-06-27 | 81% | 162.63d | 2000-04-03 | 2003-06-27 | 845d | 1695d |  | S2 | 174419h | 151076h | Rel-5 | TSG | Alain |  | LCS1 |  |  | Jan Kall, Nokia |  |
| 1517 | 88.1 | **UE positioning** | 315d | 2001-01-15 A | 2002-03-29 | 99% | 0d | 2001-01-15 | 2002-03-29 | 315d | 0d |  | RP | 5560h | 5368.13h | NA | TSG |  | 1600 | LCS1-UEpos |  |  |  |  |
| 1518 | 88.1.1 | UE positioning enhancements for 1.28 Mcps TDD | 255d | 2001-04-09 A | 2002-03-29 A | 100% |  | 2001-04-09 | 2002-03-29 | 255d |  | finish no earlier than 2002-03-29 | R2 | 2040h | 2040h | Rel-5 | TSG |  | 2474 | LCS-128Pos |  |  | Xiaohua Mei, CATT |  |
| 1519 | 88.1.2 | Open SMLC-SRNC Interface within the UTRAN to support A-GPS Positioning | 195d | 2001-01-15 A | 2001-10-12 A | 100% |  | 2001-01-15 | 2001-10-12 | 195d |  |  | R2 | 1560h | 1560h | Rel-5 | TSG |  | 2125 | LCS-INTF |  |  | Kirk Burroughs, Qualcomm |  |
| 1520 | 88.2 | **Event based and Periodic LCS** | 535d | 2000-05-22 A | 2002-06-07 | 88% | 62.67d | 2000-05-22 | 2002-06-07 | 535d | 1970d |  | S1 | 6288h | 5551.48h | Rel-5 |  |  | 1171 | LCS1-EBP | Loc |  |  |  |
| 1521 | 88.2.1 | Stage 1 | 130d | 2000-05-22 A | 2000-11-17 A | 100% |  | 2000-05-22 | 2000-11-17 | 130d |  | finish no earlier than 2000-07-21 | S1 | 1040h | 1040h |  |  |  | 1641 |  | Loc | 22.071 | Randolph Wohlert, Pacific Bell Wireless | rwohlert@tri.sbc.com |
| 1522 | 88.2.2 | Stage 2 specification | 60d | 2000-11-06 A | 2001-01-26 | 51% | 29.4d | 2000-11-06 | 2001-01-26 | 60d | 2325d | finish no earlier than 2001-01-26 | S2 | 480h | 244.8h |  |  |  | 1538 |  | Loc |  |  |  |
| 1523 | 88.2.3 | Impact on MAP | 61d | 2002-03-15 A | 2002-06-07 A | 100% |  | 2002-03-15 | 2002-06-07 | 61d |  | finish no earlier than 2002-06-07 | N4 | 488h | 488h |  |  |  | 1179 |  | Loc |  |  |  |
| 1524 | 88.3 | **Location Services for GERAN in A/Gb Mode** | 485d | 2000-04-03 A | 2002-02-08 A | 100% |  | 2000-04-03 | 2002-02-08 | 485d |  |  | GP | 24032h | 24032h | Rel-5 | TSG | Paolo | 2436 | LCS-GERAN |  |  |  |  |
| 1525 | 88.3.1 | GERAN LCS Stage 2 (first release) | 485d | 2000-04-03 A | 2002-02-08 A | 100% |  | 2000-04-03 | 2002-02-08 | 485d |  | finish no earlier than 2002-02-08 | GP; S2; G1; G2 | 13152h | 13152h |  | TSG |  | 2437 |  |  |  |  |  |
| 1526 | 88.3.2 | Gb interface support for LCS | 370d | 2000-04-03 A | 2001-08-31 A | 100% |  | 2000-04-03 | 2001-08-31 | 370d |  | finish no earlier than 2001-08-31 | GP | 2960h | 2960h |  | TSG |  | 2438 |  |  |  |  |  |
| 1527 | 88.3.3 | L3 protocol support for LCS | 305d | 2000-04-03 A | 2001-06-01 A | 100% |  | 2000-04-03 | 2001-06-01 | 305d |  | finish no earlier than 2001-06-01 | GP | 2440h | 2440h |  | TSG |  | 2440 |  |  |  |  |  |
| 1528 | 88.3.4 | Stage 3 specifications | 305d | 2000-04-03 A | 2001-06-01 A | 100% |  | 2000-04-03 | 2001-06-01 | 305d |  | finish no earlier than 2001-06-01 | GP | 2440h | 2440h |  | TSG |  | 2441 |  |  |  |  |  |
| 1529 | 88.4 | **Location Services for GERAN in Iu Mode** | 585d | 2000-04-03 A | 2002-06-28 A | 100% |  | 2000-04-03 | 2002-06-28 | 585d |  |  | GP | 78498.7h | 78498.7h | Rel-5 | TSG | Paolo |  |  |  |  |  |  |
| 1530 | 88.4.1 | GERAN LCS Stage 2 | 585d | 2000-04-03 A | 2002-06-28 A | 100% |  | 2000-04-03 | 2002-06-28 | 585d |  | finish no earlier than 2002-06-28 | GP; R2; R3; S2; G1; G2 | 22880.9h | 22880.9h |  | TSG |  | 2443 |  |  |  |  |  |
| 1531 | 88.4.2 | Iu-ps interface support for LCS | 585d | 2000-04-03 A | 2002-06-28 A | 100% |  | 2000-04-03 | 2002-06-28 | 585d |  | finish no earlier than 2002-06-28 | GP; R2; R3; S2; G1; G2 | 19000.9h | 19000.9h |  | TSG |  |  |  |  |  |  |  |
| 1532 | 88.4.3 | Iu-cs interface support for LCS | 585d | 2000-04-03 A | 2002-06-28 A | 100% |  | 2000-04-03 | 2002-06-28 | 585d |  | finish no earlier than 2002-06-28 | GP; R2; R3; S2; G1; G2 | 19000.9h | 19000.9h |  | TSG |  | 2445 |  |  |  |  |  |
| 1533 | 88.4.4 | Iur-g interface support for LCS | 62.5d | 2002-01-23 A | 2002-04-19 A | 100% |  | 2002-01-23 | 2002-04-19 | 62.5d |  | finish no earlier than 2002-04-19 | GP; R2; R3; S2; G1; G2 | 3000h | 3000h |  | TSG |  | 2446 |  |  |  |  |  |
| 1534 | 88.4.5 | RRC protocol support for LCS | 75d | 2001-08-20 A | 2001-11-30 A | 100% |  | 2001-08-20 | 2001-11-30 | 75d |  | finish no earlier than 2001-11-30 | GP; R2; R3; S2; G1; G2 | 3600h | 3600h |  | TSG |  | 2447 |  |  |  |  |  |
| 1535 | 88.4.6 | Additional impacts on Broadcast of LCS data on packet channels | 77.5d | 2001-08-20 A | 2001-12-05 A | 100% |  | 2001-08-20 | 2001-12-05 | 77.5d |  | finish no earlier than 2001-12-05 | GP; R2; R3; S2; G1; G2 | 3000h | 3000h |  | TSG |  | 2448 |  |  |  |  |  |
| 1536 | 88.4.7 | Stage 3 specifications | 69.5d | 2002-03-25 A | 2002-06-28 A | 100% |  | 2002-03-25 | 2002-06-28 | 69.5d |  | finish no earlier than 2002-06-28 | GP; R2; R3; S2; G1; G2 | 3336h | 3336h |  | TSG |  | 2449 |  |  |  |  |  |

Notes:
- 1519: Finished at RAN#13
- 1521: Evaluate Event based and Periodic LCS to be included in R00, corresponding Stage 1 description
- 1523: Possible impact on UTRAN of LCS quality level request / 17 May No stage 2 for event-based & periodic LCS. Work 100% completefor current stage 2
- 1533: FFS

| ID | WBS | Task | Duration | Start | Finish | Predecessors | Complete | Remaining | Baseline start | Baseline finish | Baseline duration | Total slack | Constraint | Resources | Work | Actual work | Text1 | Text2 | Text9 | Text6 | Text7 | Text8 | Text3 | Text5 |
| --- | --- | --- | --- | --- | --- | --- | --- | --- | --- | --- | --- | --- | --- | --- | --- | --- | --- | --- | --- | --- | --- | --- | --- | --- |
| 1537 | 88.5 | **GERAN MS Conformance test for LCS** | 280d | 2002-06-03 A | 2003-06-27 |  | 60% | 112d | 2002-06-03 | 2003-06-27 | 280d | 1695d |  | GP | 11200h | 6720h | LCS-GERAN-MSconf |  |  |  |  |  |  |  |
| 1538 | 88.5.1 | Develop LCS MS test case work plan (Release 98/99/4) | 280d | 2002-06-03 A | 2003-06-27 |  | 60% | 112d | 2002-06-03 | 2003-06-27 | 280d | 1695d | finish no earlier than 2003-06-27 | G4; G5 | 4480h | 2688h |  |  |  |  |  |  |  |  |
| 1539 | 88.5.2 | Develop LCS MS test cases | 280d | 2002-06-03 A | 2003-06-27 |  | 60% | 112d | 2002-06-03 | 2003-06-27 | 280d | 1695d | finish no earlier than 2003-06-27 | G4; G5 | 4480h | 2688h |  |  |  |  |  |  |  |  |
| 1540 | 88.6 | **GERAN BTS Conformance test for LCS** | 280d | 2002-06-03 | 2003-06-27 |  |  |  | 2002-06-03 | 2003-06-27 | 280d | 1695d |  | GP | 11200h |  | LCS-GERAN-BTSconf |  |  |  |  |  |  |  |
| 1541 | 88.6.1 | Develop LCS BTS test case work plan (Release 98/99/4) | 280d | 2002-06-03 | 2003-06-27 |  |  |  | 2002-06-03 | 2003-06-27 | 280d | 1695d | finish no earlier than 2003-06-27 | G4; G5 | 4480h |  |  |  |  |  |  |  |  |  |
| 1542 | 88.6.2 | Develop LCS BTS test cases | 280d | 2002-06-03 | 2003-06-27 |  |  |  | 2002-06-03 | 2003-06-27 | 280d | 1695d | finish no earlier than 2003-06-27 | G4; G5 | 4480h |  |  |  |  |  |  |  |  |  |
| 1543 | 88.7 | LCS interoperation stage 2 aspects | 480d | 2000-08-28 A | 2002-06-28 |  | 17% | 400.8d | 2000-08-28 | 2002-06-28 | 480d | 1955d |  | S2 | 3840h | 633.6h |  | Loc | 544 |  |  |  |  |  |
| 1544 | 88.8 | **LCS interoperability aspects to GERAN** | 480d | 2000-08-28 A | 2002-06-28 A |  | 100% |  | 2000-08-28 | 2002-06-28 | 480d |  |  | GP | 19632h | 19632h | LCS-GERAN |  | 2434 | Rel-5 | TSG | Paolo |  |  |
| 1545 | 88.8.1 | Co-ordinated development of GSM LCS Phase 2 and UMTS LCS, S2 and GERAN | 480d | 2000-08-28 A | 2002-06-28 A |  | 100% |  | 2000-08-28 | 2002-06-28 | 480d |  | finish no earlier than 2002-06-28 | GP; S2; S5; R2; R3; G2; G1 | 15792h | 15792h | LCS-GERAN |  | 2435 |  | TSG |  |  |  |
| 1546 | 88.9 | FS on LCS support in the IMS | 90d | 2001-02-12 A | 2002-01-18 |  | 75% | 22.5d | 2001-02-12 | 2002-01-18 | 90d | 2070d | start no earlier than 2001-02-12 | S1 | 720h | 540h |  | Loc | 1183 |  |  |  |  |  |
| 1547 | 88.10 | Charging and OAM&P for LCS enhancements | 201d | 2001-09-21 A | 2002-06-28 A |  | 100% |  | 2001-09-21 | 2002-06-28 | 201d |  | finish no earlier than 2002-06-28 | S5 | 1608h | 1608h | LCS1-OAM |  | 519 | Rel-5 | TSG |  | 32-series | Albert.Yuhan@voicestream.com; Michael.Truss@MOTOROLA.COM |
| 1548 | 88.11 | New security aspects of LCS (not identified) | 446d | 2000-04-14 A | 2001-12-28 A |  | 100% |  | 2000-04-14 | 2001-12-28 | 446d |  | finish no earlier than 2001-12-28 | S3 | 3568h | 3568h | LCS1-SEC | Loc | 521 | Rel-5 |  |  |  | valtteri.niemi@nokia.com |
| 1549 | 88.12 | Specification for the Le Interface | 45d | 2002-01-14 A | 2002-03-15 A |  | 100% |  | 2002-01-14 | 2002-03-15 | 45d |  | start no earlier than 2002-01-14 | S2 | 360h | 360h | LCS1-Le |  |  | Rel-5 | TSG |  |  |  |
| 1550 | 88.13 | CHECK STATUS - Inter-GMLC interface | 153d | 2002-05-30 | 2002-12-30 |  |  |  | 2002-05-30 | 2002-12-30 | 153d | 1824d | finish no earlier than 2002-12-30 | S2 | 1224h |  |  |  |  |  |  |  |  |  |
| 1551 | 89 | **Rel-5 Security enhancements** | 615d | 2000-02-21 A | 2002-06-28 |  | 99% | 4.24d | 2000-02-21 | 2002-06-28 | 615d | 1955d |  | S3 | 29974.9h | 28371.3h | SEC1 |  |  | Rel-5 | TSG | Maurice |  | Peter.Howard@vodafone.com |
| 1552 | 89.1 | **Network domain security** | 615d | 2000-02-21 A | 2002-06-28 |  | 99% | 4.24d | 2000-02-21 | 2002-06-28 | 615d | 1955d |  | S3 | 25054.9h | 23451.3h | SEC1-NDS | Sec | 1576 | Rel-5 | TSG |  |  | Geir-myrdahl.koien@telenor.com |
| 1553 | 89.1.1 | **Control plane protection in core network (e.g., GTP, CAP, MAP/IP, provided by IPsec)** | 541d | 2000-05-12 A | 2002-06-07 |  | 99% | 0d | 2000-05-12 | 2002-06-07 | 541d | 0d |  | S3 | 7118.9h | 5722.98h |  | Sec | 1577 |  |  |  |  |  |
| 1554 | 89.1.1.1 | Main aspects | 290d | 2000-05-12 A | 2001-06-21 A |  | 100% |  | 2000-05-12 | 2001-06-21 | 290d |  | finish no earlier than 2001-06-21 | S3 | 2320h | 2320h |  | Sec | 1578 |  |  |  |  |  |
| 1555 | 89.1.1.2 | Integration of GTP signalling security architecture | 191d | 2001-09-14 A | 2002-06-07 A |  | 100% |  | 2001-09-14 | 2002-06-07 | 191d |  | finish no earlier than 2002-06-07 | N4 | 1528h | 1528h |  | Sec | 1579 |  |  |  |  |  |
| 1556 | 89.1.2 | **User plane protection in core network (e.g., provided by IPsec)** | 615d | 2000-02-21 A | 2002-06-28 |  | 98% | 11.41d | 2000-02-21 | 2002-06-28 | 615d | 1955d |  | S3 | 9360.02h | 9186.3h |  | Sec | 1580 |  |  |  |  |  |
| 1557 | 89.1.2.1 | Main aspects | 349d | 2000-02-21 A | 2001-06-21 A |  | 100% |  | 2000-02-21 | 2001-06-21 | 349d |  | finish no earlier than 2001-06-21 | S3 | 2792h | 2792h |  | Sec | 1581 |  |  |  |  |  |
| 1558 | 89.1.2.2 | Integration of GTP signalling security architecture | 206d | 2001-09-14 A | 2002-06-28 |  | 95% | 10.3d | 2001-09-14 | 2002-06-28 | 206d | 1955d | finish no earlier than 2002-06-28 | N4 | 1648h | 1565.6h |  | Sec | 1582 |  |  |  |  |  |
| 1559 | 89.1.3 | IP network layer security (NDS/IP) | 457d | 2000-06-15 A | 2002-03-15 A |  | 100% |  | 2000-06-15 | 2002-03-15 | 457d |  | finish no earlier than 2002-03-15 | S3 | 3656h | 3656h | SEC1-NDS-IP |  |  |  | WG |  | TS 33.210 | Geir-myrdahl.koien@telenor.com |
| 1560 | 90 | **Intra Domain Connection of RAN Nodes to Multiple CN Nodes** | 455d | 2000-10-02 A | 2002-06-28 A |  | 100% |  | 2000-10-02 | 2002-06-28 | 455d |  |  | S2 | 15136h | 15136h | IUFLEX |  |  | Rel-5 | TSG | Alain | 23.236 |  |
| 1561 | 90.1 | Overall System Architecture | 188d | 2001-01-03 A | 2001-09-21 A |  | 100% |  | 2001-01-03 | 2001-09-21 | 188d |  | finish no earlier than 2001-06-01 | S2 | 1504h | 1504h |  |  | 2244 |  | TSG |  |  |  |
| 1562 | 90.2 | Stage 3: RAN node selecting CN node | 130d | 2001-09-24 A | 2002-03-22 A | 1561 | 100% |  | 2001-09-24 | 2002-03-22 | 130d |  | finish no earlier than 2002-03-22 | R3 | 1040h | 1040h |  |  |  |  | TSG |  |  |  |
| 1563 | 90.3 | N1 work | 205d | 2001-09-17 A | 2002-06-28 A |  | 100% |  | 2001-09-17 | 2002-06-28 | 205d |  | start no earlier than 2001-09-17 | N1 | 1640h | 1640h |  |  |  |  | TSG |  | 24.008 and check 29.018 |  |
| 1564 | 90.4 | N4 work | 375d | 2000-10-02 A | 2002-03-08 A |  | 100% |  | 2000-10-02 | 2002-03-08 | 375d |  | finish no earlier than 2002-03-15 | N4 | 3000h | 3000h |  |  | 2249 |  | TSG |  |  |  |

Notes:
- 1537: On-going
- 1540: Not started
- 1547: Text4: Albert YUHAN (VoiceStream Wireless), Michael TRUSS (Motorola)
- 1548: 14/09/00: End date 28/12/01 WI may need to be split to improve on this date. S3#17 15% complete. No progress since S3#17 / Text4: Valtteri Niemi, Nokia
- 1551: Added BB UE authentication and rapporteur added. TO BE DELETED / Text4: Peter Howard, Vodafone
- 1552: S3#17: All due in Rel5. (WI Update at S3#18). Replaced by NDS-IP and NDS-MAP. TO BE DELETED OR MOVED TO HISTORY FILE / Text4: Geir M. Køien, Telenor
- 1554: TO BE DELETED
- 1555: Waiting for input from SA3! / 14/02/2002 requirements are not clear/not received / 17 May 100% complete
- 1556: TO BE DELETED
- 1557: ??
- 1558: 14/02/2002 requirements are not clear/not received
- 1559: TS 33.210 will be presented for info at SA#14 and is scheduled for approval at SA#15. 2002/12: All IPsec RFCs are stable STD Track RFCs. WID updated SA#17 / Text4: Geir M. Køien, Telenor
- 1560: No clear indication on the end date. Put to Rel5 by AS. / Text4: Stephen Terrill, Ericsson
- 1562: Not identified / Text4: Brendan McWilliams, Vodafone
- 1564: DAB 12.12.01 - % complete to 66% / 14/02/02 Work completed

| ID | WBS | Task | Duration | Start | Finish | Complete | Baseline start | Baseline finish | Baseline duration | Total slack | Constraint | Resources | Work | Actual work | Text1 | Text5 | Text6 | Text7 | Text8 | Text9 | Text3 | Text2 |
| --- | --- | --- | --- | --- | --- | --- | --- | --- | --- | --- | --- | --- | --- | --- | --- | --- | --- | --- | --- | --- | --- | --- |
| 1565 | 90.5 | **GERAN work for Intra Domain Connection of RAN Nodes to Multiple CN Nodes** | 101d | 2002-02-08 A | 2002-06-28 A | 100% | 2002-02-08 | 2002-06-28 | 101d |  |  | GP | 4848h | 4848h | IDCRAN-GERAN | ingemar.backlund@era.ericsson.se | Rel-5 |  |  |  |  |  |
| 1566 | 90.5.1 | Stage 2 (changes to ) | 101d | 2002-02-08 A | 2002-06-28 A | 100% | 2002-02-08 | 2002-06-28 | 101d |  | finish no earlier than 2002-06-28 | G1 | 808h | 808h |  |  |  |  |  |  |  |  |
| 1567 | 90.5.2 | 43.051 Introduction of support for IDNNS in GERAN Iu mode | 101d | 2002-02-08 A | 2002-06-28 A | 100% | 2002-02-08 | 2002-06-28 | 101d |  | finish no earlier than 2002-06-28 | G1 | 808h | 808h |  |  |  |  |  |  |  |  |
| 1568 | 90.5.3 | Stage 3 (changes to ) | 101d | 2002-02-08 A | 2002-06-28 A | 100% | 2002-02-08 | 2002-06-28 | 101d |  | finish no earlier than 2002-06-28 | G2 | 808h | 808h |  |  |  |  |  |  |  |  |
| 1569 | 90.5.4 | 48.016 Use of Gb interface concepts when a network applies IDNNS | 101d | 2002-02-08 A | 2002-06-28 A | 100% | 2002-02-08 | 2002-06-28 | 101d |  | finish no earlier than 2002-06-28 | G2 | 808h | 808h |  |  |  |  |  |  |  |  |
| 1570 | 90.5.5 | 48.018 Include MSC/VLR identity in CS IMSI paging | 101d | 2002-02-08 A | 2002-06-28 A | 100% | 2002-02-08 | 2002-06-28 | 101d |  | finish no earlier than 2002-06-28 | G2 | 808h | 808h |  |  |  |  |  |  |  |  |
| 1571 | 91 | **GERAN improvements 3 (new transport layer on interface A)** | 446d | 2001-04-06 | 2002-12-20 |  | 2001-04-06 | 2002-12-20 | 446d | 1830d |  | GP | 14272h |  | GEIMP3 |  | Rel-5 | TSG | Paolo | 2320 |  |  |
| 1572 | 91.1 | **Evolution of the transport for A** | 446d | 2001-04-06 | 2002-12-20 |  | 2001-04-06 | 2002-12-20 | 446d | 1830d |  | GP | 10704h |  | GEIMP3-EtA |  |  | TSG | Paolo | 2321 |  |  |
| 1573 | 91.1.1 | Definition of a new A/Ater interface Transport Layer option based on the Iu Interface Transport Layer | 446d | 2001-04-06 | 2002-12-20 |  | 2001-04-06 | 2002-12-20 | 446d | 1830d | finish no earlier than 2002-12-20 | GP | 3568h |  |  |  |  | TSG |  | 2322 |  |  |
| 1574 | 91.1.2 | Adaptation of the Layer 3 BSSMAP procedures as required | 446d | 2001-04-06 | 2002-12-20 |  | 2001-04-06 | 2002-12-20 | 446d | 1830d | finish no earlier than 2002-12-20 | GP | 3568h |  |  |  |  | TSG |  | 2323 |  |  |
| 1575 | 92 | **Rel-5 Charging and OAM&P** | 264d | 2001-09-10 A | 2002-09-12 A | 100% | 2001-09-10 | 2002-09-12 | 264d |  |  | S5 | 9976h | 9976h | OAM | Albert.Yuhan@voicestream.com; Michael.Truss@MOTOROLA.COM | Rel-5 | TSG | Adrian |  | 32-series |  |
| 1576 | 92.1 | Rel5 Principles, high level Requirements and Architecture | 205d | 2001-09-17 A | 2002-06-28 A | 100% | 2001-09-17 | 2002-06-28 | 205d |  | finish no earlier than 2002-06-28 | S5 | 1640h | 1640h | OAM-AR/PR | Michael.Truss@MOTOROLA.COM | Rel-5 | TSG |  | 2089 | 32.101, 32.102 | BCaM |
| 1577 | 92.2 | Rel5 Performance Management | 259d | 2001-09-17 A | 2002-09-12 A | 100% | 2001-09-17 | 2002-09-12 | 259d |  | finish no earlier than 2002-09-12 | S5 | 2072h | 2072h | OAM-PM | toche@NORTELNETWORKS.COM | Rel-5 | TSG |  | 2088 | 32.4xy, 52.402 | BCaM |
| 1578 | 92.3 | Rel5 Charging Management | 264d | 2001-09-10 A | 2002-09-12 A | 100% | 2001-09-10 | 2002-09-12 | 264d |  | finish no earlier than 2002-09-12 | S5 | 2112h | 2112h | OAM-CH | Karl-Heinz.Nenner@T-MOBILE.DE | Rel-5 | TSG |  | 2083 | 32.2xy |  |
| 1579 | 92.4 | Rel5 Network Infrastructure Management | 255d | 2001-09-21 A | 2002-09-12 A | 100% | 2001-09-21 | 2002-09-12 | 255d |  | finish no earlier than 2002-09-12 | S5 | 2040h | 2040h | OAM-NIM | Thomas.Tovinger@emw.ericsson.se | Rel-5 | TSG |  |  | 32.6xy, 32.3xy |  |
| 1580 | 93 | **GERAN enhancements for streaming services 1 (RLC enhancements)** | 430d | 2000-11-06 A | 2002-06-28 A | 100% | 2000-11-06 | 2002-06-28 | 430d |  |  | GP | 8944h | 8944h |  |  | Rel-5 |  | Paolo | 2392 |  |  |
| 1581 | 93.1 | Concept | 258d | 2000-11-06 A | 2001-10-31 A | 100% | 2000-11-06 | 2001-10-31 | 258d |  | finish no earlier than 2001-10-31 | GP | 2064h | 2064h |  |  |  |  |  | 2394 |  |  |
| 1582 | 93.2 | RLC protocol enhancement (SDU Discard) | 430d | 2000-11-06 A | 2002-06-28 A | 100% | 2000-11-06 | 2002-06-28 | 430d |  | finish no earlier than 2002-06-28 | GP | 3440h | 3440h |  |  |  |  |  | 2395 |  |  |
| 1583 | 94 | **GERAN enhancements for streaming services 2 (usage of ECSD)** | 430d | 2000-11-06 A | 2002-06-28 A | 100% | 2000-11-06 | 2002-06-28 | 430d |  |  | GP | 19840h | 19840h |  |  | Rel-5 |  | Paolo | 2396 |  |  |
| 1584 | 94.1 | Usage of ECSD Concept | 380d | 2000-11-06 A | 2002-04-19 A | 100% | 2000-11-06 | 2002-04-19 | 380d |  | finish no earlier than 2002-04-19 | GP | 3040h | 3040h |  |  |  |  |  | 2398 |  |  |
| 1585 | 94.2 | Stage 2 | 380d | 2000-11-06 A | 2002-04-19 A | 100% | 2000-11-06 | 2002-04-19 | 380d |  | finish no earlier than 2002-04-19 | GP | 3040h | 3040h |  |  |  |  |  | 2399 |  |  |
| 1586 | 94.3 | Stage 3 | 430d | 2000-11-06 A | 2002-06-28 A | 100% | 2000-11-06 | 2002-06-28 | 430d |  | finish no earlier than 2002-06-28 | GP | 3440h | 3440h |  |  |  |  |  | 2400 |  |  |
| 1587 | 94.4 | RLC PDU formats | 430d | 2000-11-06 A | 2002-06-28 A | 100% | 2000-11-06 | 2002-06-28 | 430d |  | finish no earlier than 2002-06-28 | GP | 3440h | 3440h |  |  |  |  |  | 2401 |  |  |
| 1588 | 94.5 | MAC header | 430d | 2000-11-06 A | 2002-06-28 A | 100% | 2000-11-06 | 2002-06-28 | 430d |  | finish no earlier than 2002-06-28 | GP | 3440h | 3440h |  |  |  |  |  | 2402 |  |  |

Notes:
- 1565: Accept changes Gb over IP / Text4: Ingemar Backlund, Ericsson
- 1569: Closed, accept changes for Gb over IP
- 1571: TERMINATED - NOT STANDARDIZED
- 1572: TERMINATED - NOT STANDARDIZED
- 1573: TERMINATED - NOT STANDARDIZED
- 1574: TERMINATED - NOT STANDARDIZED
- 1575: Text4: Albert YUHAN (VoiceStream Wireless), Michael TRUSS (Motorola)
- 1576: Text4: Michael TRUSS (Motorola)
- 1577: Text4: Christian TOCHE (Nortel Networks)
- 1578: Text4: Karl-Heinz NENNER (T-Mobile)
- 1579: Text4: Thomas TOVINGER (Ericsson)
- 1583: AWS, Nokia, Ericsson, Nortel, Siemens, Motorola, Vodafone / Text4: Frank Muller, Ericsson

| ID | WBS | Task | Duration | Start | Finish | Predecessors | Complete | Remaining | Baseline start | Baseline finish | Baseline duration | Total slack | Constraint | Resources | Work | Actual work | Text1 | Text6 | Text8 | Text9 | Text5 | Text7 | Text2 |
| --- | --- | --- | --- | --- | --- | --- | --- | --- | --- | --- | --- | --- | --- | --- | --- | --- | --- | --- | --- | --- | --- | --- | --- |
| 1589 | 95 | **GERAN/UTRAN interface evolution 1 (evolution of Iu PS)** | 476d | 2000-09-01 A | 2002-06-28 A |  | 100% |  | 2000-09-01 | 2002-06-28 | 476d |  |  | GP; R3 | 17825.6h | 17825.6h | GERUEV1 | Rel-5 | Paolo | 2412 |  |  |  |
| 1590 | 95.1 | **Evolution of Iu ps** | 476d | 2000-09-01 A | 2002-06-28 A |  | 100% |  | 2000-09-01 | 2002-06-28 | 476d |  |  | GP; R3 | 12205.6h | 12205.6h | GERUEV1-IuPS |  |  | 2413 |  |  |  |
| 1591 | 95.1.1 | Identification of GERAN requirements on Iu ps | 326d | 2000-09-01 A | 2001-11-30 A |  | 100% |  | 2000-09-01 | 2001-11-30 | 326d |  | finish no earlier than 2001-11-30 | GP; R3 | 4185.6h | 4185.6h |  |  |  | 2414 |  |  |  |
| 1592 | 95.1.2 | Update of specifications | 150d | 2001-12-03 A | 2002-06-28 A | 1591 | 100% |  | 2001-12-03 | 2002-06-28 | 150d |  | finish no earlier than 2002-06-28 | GP; R3 | 2400h | 2400h |  |  |  | 2415 |  |  |  |
| 1593 | 96 | **GERAN/UTRAN interface evolution 2 (evolution of Iu CS)** | 476d | 2000-09-01 A | 2002-06-28 A |  | 100% |  | 2000-09-01 | 2002-06-28 | 476d |  |  | GP; R3 | 23025.6h | 23025.6h | GERUEV2 | Rel-5 | Paolo | 2416 |  |  |  |
| 1594 | 96.1 | **Evolution of Iu cs** | 476d | 2000-09-01 A | 2002-06-28 A |  | 100% |  | 2000-09-01 | 2002-06-28 | 476d |  |  | GP; R3 | 17845.6h | 17845.6h | GERUEV2-IuCS |  | Paolo | 2417 |  |  |  |
| 1595 | 96.1.1 | Identification of GERAN requirements on Iu cs | 426d | 2000-09-01 A | 2002-04-19 A |  | 100% |  | 2000-09-01 | 2002-04-19 | 426d |  | finish no earlier than 2002-04-19 | GP; R3 | 5049.6h | 5049.6h |  |  |  | 2418 |  |  |  |
| 1596 | 96.1.2 | Update of specifications | 476d | 2000-09-01 A | 2002-06-28 A |  | 100% |  | 2000-09-01 | 2002-06-28 | 476d |  | finish no earlier than 2002-06-28 | GP; R3 | 7616h | 7616h |  |  |  | 2419 |  |  |  |
| 1597 | 97 | **End to End QoS for PS Domain including IMS** | 480d | 2000-08-28 A | 2002-06-28 |  | 97% | 13.22d | 2000-08-28 | 2002-06-28 | 480d | 1955d |  | S2 | 9856.02h | 9584.5h | E2EQoS | Rel-5 | Alain |  | Johnson.oyama@era.ericcson.se | TSG |  |
| 1598 | 97.1 | E2E QoSConcept and Architecture | 178d | 2001-01-03 A | 2001-09-07 A |  | 100% |  | 2001-01-03 | 2001-09-07 | 178d |  | finish no earlier than 2001-09-07 | S2 | 1424h | 1424h |  |  |  |  |  | TSG |  |
| 1599 | 97.2 | E2E QoS interworking | 465d | 2000-08-28 A | 2002-06-07 |  | 95% | 23.25d | 2000-08-28 | 2002-06-07 | 465d | 1970d | finish no earlier than 2002-06-07 | N3 | 3720h | 3534h | E2EQoS-IW |  |  |  | yokota@lucent.com | WG |  |
| 1600 | 97.3 | QoS Management (Provisioning and Monitoring) | 201d | 2001-09-21 A | 2002-06-28 A |  | 100% |  | 2001-09-21 | 2002-06-28 | 201d |  | finish no earlier than 2002-06-28 | S5 | 1608h | 1608h | E2EQoS-OAM | Rel-5 |  |  | Albert.Yuhan@voicestream.com; Michael.Truss@MOTOROLA.COM | TSG |  |
| 1601 | 98 | **Messaging enhancements Rel-5** | 467d | 2001-06-15 A | 2003-03-31 |  | 93% | 34.87d | 2001-06-15 | 2003-03-31 | 467d | 1759d |  | T2 | 19000h | 16103.4h | MESS5 | Rel-5 | Friedhelm | 1818 |  | TSG | Mes |
| 1602 | 98.1 | **Multimedia Messaging (MMS) enhancements** | 467d | 2001-06-15 A | 2003-03-31 |  | 91% | 43.88d | 2001-06-15 | 2003-03-31 | 467d | 1759d |  | T2 | 11688h | 10589.8h | MESS5-MMS |  |  | 1819 | Josef.Laumen@SAL.SIEMENS.DE | TSG | Mes |
| 1603 | 98.1.1 | Definition of service requirements | 196d | 2001-06-15 A | 2002-03-15 A |  | 100% |  | 2001-06-15 | 2002-03-15 | 196d |  | finish no earlier than 2002-03-15 | S1 | 1568h | 1568h | MESS5-SR | Rel-5 |  |  | Josef.Laumen@SAL.SIEMENS.DE |  |  |
| 1604 | 98.1.2 | Technical realization | 256d | 2001-06-15 A | 2002-06-07 A |  | 100% |  | 2001-06-15 | 2002-06-07 | 256d |  | finish no earlier than 2002-06-07 | T2 | 2048h | 2048h |  |  |  |  | Josef.Laumen@SAL.SIEMENS.DE |  |  |
| 1605 | 98.1.3 | WAP Forum dependency: MM1 stage 3 | 467d | 2001-06-15 A | 2003-03-31 |  | 80% | 93.4d | 2001-06-15 | 2003-03-31 | 467d | 1759d | finish no earlier than 2003-03-31 | T2 | 3736h | 2988.8h |  |  |  |  |  |  |  |
| 1606 | 98.1.4 | MMS formats and codecs | 75d | 2001-12-03 A | 2002-03-15 A |  | 100% |  | 2001-12-03 | 2002-03-15 | 75d |  | finish no earlier than 2002-03-15 | S4 | 600h | 600h |  |  |  |  |  |  |  |
| 1607 | 98.2 | **Enhanced Messaging Service (EMS) enhancements** | 191d | 2001-06-15 A | 2002-03-08 |  | 99% | 0d | 2001-06-15 | 2002-03-08 | 191d | 0d |  | T2 | 3584h | 2064h | MESS5-EMS |  |  | 1820 | Alan.Baldwin@EML.ERICSSON.SE | TSG | Mes |
| 1608 | 98.2.1 | Definition of service requirements | 66d | 2001-06-15 A | 2001-09-14 A |  | 100% |  | 2001-06-15 | 2001-09-14 | 66d |  | finish no earlier than 2001-09-14 | S1 | 528h | 528h |  |  |  |  | Alan.Baldwin@EML.ERICSSON.SE |  |  |
| 1609 | 98.2.2 | Technical realization | 191d | 2001-06-15 A | 2002-03-08 A |  | 100% |  | 2001-06-15 | 2002-03-08 | 191d |  | finish no earlier than 2002-03-08 | T2 | 1528h | 1528h |  |  |  |  | Alan.Baldwin@EML.ERICSSON.SE |  |  |
| 1610 | 99 | **GERAN Inter BSC NACC improvements over the Gb Interface** | 215d | 2001-09-03 A | 2002-06-28 A |  | 100% |  | 2001-09-03 | 2002-06-28 | 215d |  |  | GP | 11184h | 11184h | GERNACC | Rel-5 | Paolo |  |  |  |  |
| 1611 | 99.1 | **Modification of core network protocols for GERAN Inter BSC NACC over Gb Interface** | 165d | 2001-09-03 A | 2002-04-19 A |  | 100% |  | 2001-09-03 | 2002-04-19 | 165d |  |  | N4; S2 | 7048h | 7048h | GERNACC-Cnmod |  |  |  |  |  |  |
| 1612 | 99.1.1 | Stage 2 - Concept | 43d | 2001-09-03 A | 2001-10-31 A |  | 100% |  | 2001-09-03 | 2001-10-31 | 43d |  | finish no earlier than 2001-10-31 | N4; S2 | 688h | 688h |  |  |  |  |  |  |  |
| 1613 | 99.1.2 | Stage 2 - 23.060 change - Definition of Inter BSC NACC | 165d | 2001-09-03 A | 2002-04-19 A |  | 100% |  | 2001-09-03 | 2002-04-19 | 165d |  | finish no earlier than 2002-04-19 | N4; S2 | 2640h | 2640h |  |  |  |  |  |  |  |
| 1614 | 99.1.3 | Stage 3 (changes to TS 29.060) | 135d | 2001-09-03 A | 2002-03-08 A |  | 100% |  | 2001-09-03 | 2002-03-08 | 135d |  | finish no earlier than 2002-03-08 | N4 | 1080h | 1080h |  |  |  |  |  |  |  |

Notes:
- 1589: SBC, Motorola, Nokia, Ericsson, Nortel / Text4: Marc Grant , SBC
- 1594: Lucent, Ericsson, AWS, Nortel / Text4: Krishna Balachandran, Lucent
- 1597: Text4: Johnson Oyama, Ericsson
- 1598: Text3: 23.207
- 1599: [DAB - 30/07/02] - % complete to 95% (if we exclude Diffserv) / Text3: 29.208, 29.207, 27.060, 29.061, 24.008, 24.228, , 24.229, 29.060, 29.163 / Text4: Daisuke Yokota, Lucent
- 1600: Text3: 32-series / Text4: Albert YUHAN (VoiceStream Wireless), Michael TRUSS (Motorola)
- 1601: support of UAProf, so this in my opinion is 100% complete
- 1602: Text4: Josef Laumen, Siemens
- 1603: Text3: 22.140 / Text4: Josef Laumen, Siemens
- 1604: stage 3 MM7 is missing / Text3: 23.140 / Text4: Josef Laumen, Siemens
- 1606: Text3: 26.140
- 1607: Text3: 23.040 / Text4: Alan Baldwin, Ericsson
- 1608: Text4: Alan Baldwin, Ericsson
- 1609: Text3: 23.040 / Text4: Alan Baldwin, Ericsson
- 1614: IP 30/11/01: Input awaited from GERAN2 to CN4 / 17 May Work complete 100%

| ID | WBS | Task | Duration | Start | Finish | Complete | Remaining | Baseline start | Baseline finish | Baseline duration | Total slack | Constraint | Resources | Work | Actual work | Text1 | Text6 | Text8 | Text3 | Text4 | Text5 | Text7 | Text2 | Text9 |
| --- | --- | --- | --- | --- | --- | --- | --- | --- | --- | --- | --- | --- | --- | --- | --- | --- | --- | --- | --- | --- | --- | --- | --- | --- |
| 1615 | 99.2 | **Modification of Gb protocols for GERAN Inter BSC NACC over Gb Interface** | 151d | 2001-11-30 A | 2002-06-28 A | 100% |  | 2001-11-30 | 2002-06-28 | 151d |  |  | GP | 2416h | 2416h | GERNACC-Gbmod |  |  |  |  |  |  |  |  |
| 1616 | 99.2.1 | Stage 3 (changes to TS 48.018) | 151d | 2001-11-30 A | 2002-06-28 A | 100% |  | 2001-11-30 | 2002-06-28 | 151d |  | finish no earlier than 2002-06-28 | GP | 1208h | 1208h |  |  |  |  |  |  |  |  |  |
| 1617 | 100 | **Enhanced Power Control** | 540d | 2001-11-26 A | 2003-12-19 |  | 537.46d | 2001-11-26 | 2003-12-19 | 540d | 1570d |  | GP | 12840h | 60.28h | EPC | Rel-5 |  |  |  |  |  |  |  |
| 1618 | 100.1 | Realization of Enhanced power control and signaling support | 5d | 2001-11-26 A | 2001-11-30 A | 100% |  | 2001-11-26 | 2001-11-30 | 5d |  | finish no earlier than 2001-11-30 | GP | 40h | 40h |  |  |  |  |  |  |  |  |  |
| 1619 | 100.2 | GERAN MS Conformance test for Enhanced Power Control | 530d | 2001-12-10 | 2003-12-19 |  |  | 2001-12-10 | 2003-12-19 | 530d | 1570d | finish no earlier than 2003-12-19 | GP | 4240h |  |  |  |  |  |  |  |  |  |  |
| 1620 | 100.3 | GERAN BTS Conformance test for Enhanced Power Control | 530d | 2001-12-10 | 2003-12-19 |  |  | 2001-12-10 | 2003-12-19 | 530d | 1570d | finish no earlier than 2003-12-19 | GP | 4240h |  |  |  |  |  |  |  |  |  |  |
| 1621 | 101 | **8PSK AMR HR** | 530d | 2001-12-10 A | 2003-12-19 | 73% | 143.32d | 2001-12-10 | 2003-12-19 | 530d | 1570d |  | GP | 21080h | 15693.5h | 8PSK-AH | Rel-5 | Paolo |  |  |  |  |  |  |
| 1622 | 101.1 | **Definition of channel coding, performance requirements and signaling support** | 145d | 2001-12-10 A | 2002-06-28 A | 100% |  | 2001-12-10 | 2002-06-28 | 145d |  |  | GP | 10440h | 10440h |  |  |  |  |  |  |  |  |  |
| 1623 | 101.1.1 | Concept | 145d | 2001-12-10 A | 2002-06-28 A | 100% |  | 2001-12-10 | 2002-06-28 | 145d |  | finish no earlier than 2002-06-28 | GP | 1160h | 1160h |  |  |  |  |  |  |  |  |  |
| 1624 | 101.1.2 | Changes to 44.018 | 145d | 2001-12-10 A | 2002-06-28 A | 100% |  | 2001-12-10 | 2002-06-28 | 145d |  | finish no earlier than 2002-06-28 | G2 | 1160h | 1160h |  |  |  |  |  |  |  |  |  |
| 1625 | 101.1.3 | Changes to 45.001 | 145d | 2001-12-10 A | 2002-06-28 A | 100% |  | 2001-12-10 | 2002-06-28 | 145d |  | finish no earlier than 2002-06-28 | G1 | 1160h | 1160h |  |  |  |  |  |  |  |  |  |
| 1626 | 101.1.4 | Changes to 45.002 | 145d | 2001-12-10 A | 2002-06-28 A | 100% |  | 2001-12-10 | 2002-06-28 | 145d |  | finish no earlier than 2002-06-28 | G1 | 1160h | 1160h |  |  |  |  |  |  |  |  |  |
| 1627 | 101.1.5 | Changes to 45.003 | 145d | 2001-12-10 A | 2002-06-28 A | 100% |  | 2001-12-10 | 2002-06-28 | 145d |  | finish no earlier than 2002-06-28 | G1 | 1160h | 1160h |  |  |  |  |  |  |  |  |  |
| 1628 | 101.1.6 | Changes to 45.005 | 145d | 2001-12-10 A | 2002-06-28 A | 100% |  | 2001-12-10 | 2002-06-28 | 145d |  | finish no earlier than 2002-06-28 | G1 | 1160h | 1160h |  |  |  |  |  |  |  |  |  |
| 1629 | 101.1.7 | Changes to 24.008 | 145d | 2001-12-10 A | 2002-06-28 A | 100% |  | 2001-12-10 | 2002-06-28 | 145d |  | finish no earlier than 2002-06-28 | G2 | 1160h | 1160h |  |  |  |  |  |  |  |  |  |
| 1630 | 101.1.8 | Changes to 48.058 | 145d | 2001-12-10 A | 2002-06-28 A | 100% |  | 2001-12-10 | 2002-06-28 | 145d |  | finish no earlier than 2002-06-28 | G2 | 1160h | 1160h |  |  |  |  |  |  |  |  |  |
| 1631 | 101.2 | GERAN MS Conformance test for 8PSK HR | 530d | 2001-12-10 | 2003-12-19 |  |  | 2001-12-10 | 2003-12-19 | 530d | 1570d | finish no earlier than 2003-12-19 | GP | 4240h |  |  |  |  |  |  |  |  |  |  |
| 1632 | 101.3 | GERAN BTS Conformance test for 8PSK HR | 270d | 2001-12-10 A | 2002-12-20 A | 100% |  | 2001-12-10 | 2002-12-20 | 270d |  | finish no earlier than 2002-12-20 | GP | 2160h | 2160h |  |  |  |  |  |  |  |  |  |
| 1633 | 102 | Service Change and UDI Fallback | 175d | 2001-10-08 A | 2002-06-07 A | 100% |  | 2001-10-08 | 2002-06-07 | 175d |  | finish no earlier than 2002-06-07 | N3 | 1400h | 1400h | SCUDIF | Rel-5 | David | 29.007, 27.001, 24.008 | Rune Werner Wiik, Ericsson AS | Rune.Werner.Wiik@ericsson.no | WG |  |  |
| 1634 | 103 | **Rel-5 USIM toolkit enhancements** | 865d | 2000-06-05 A | 2003-09-26 | 51% | 425.77d | 2000-06-05 | 2003-09-26 | 865d | 1630d |  | T3 | 24352h | 13591.2h | USAT1 | Rel-5 | Claus |  |  |  |  | Ter | 1800 |
| 1635 | 103.1 | Test specification for USIM toolkit security mechanims | 349d | 2002-05-28 | 2003-09-26 |  |  | 2002-05-28 | 2003-09-26 | 349d | 1630d | finish no earlier than 2003-09-26 | T3 | 2792h |  |  | Rel-5 |  |  | Sophie Viallet (Gemplus) |  |  |  |  |
| 1636 | 103.2 | **Protocol Standardisation of a SIM Toolkit Interpreter** | 688d | 2000-06-05 A | 2003-01-22 | 64% | 250.88d | 2000-06-05 | 2003-01-22 | 688d | 1807d |  | T3 | 12512h | 7949.4h | USAT1-Interpr | Rel-5 |  | 27.103 | Michael Meyer, G & D |  | TSG | Ter | 1801 |
| 1637 | 103.2.1 | Stage 1 | 205d | 2000-06-05 A | 2001-03-16 A | 100% |  | 2000-06-05 | 2001-03-16 | 205d |  | finish no earlier than 2001-03-16 | T3 | 1640h | 1640h |  |  |  |  |  |  | TSG |  |  |
| 1638 | 103.2.2 | Stage 2 and 3 | 308d | 2001-01-03 A | 2002-03-08 A | 100% |  | 2001-01-03 | 2002-03-08 | 308d |  | finish no earlier than 2002-03-08 | T3 | 2464h | 2464h |  |  |  |  |  |  | TSG |  |  |
| 1639 | 103.2.3 | Test specification | 363d | 2001-09-03 A | 2003-01-22 | 12% | 319.44d | 2001-09-03 | 2003-01-22 | 363d | 1807d | finish no earlier than 2003-01-22 | T3 | 2904h | 348.48h |  |  |  |  | Gérald MAUNIER (Gemplus) |  | TSG |  |  |

Notes:
- 1618: Ready
- 1619: Not started
- 1620: Not started
- 1621: Completed for Rel-5
- 1633: [DAB - 23/05/03] - 100 % complete some issues with CAMEL
- 1636: 28/5/2001: T3-19 proposed that since the stage 2 and 3 will not be presented to TP-12 for approval as expected, the WI will be moved to rel-5, with completion expected at TP-13.
- 1637: 5/10/2001: Stage one comepeted at TP-12.
- 1638: 5/10/2001: TS 31.112 and 31.113 approved at TP-13. TS 31.114 to be presented to TP-14.
- 1639: 5/10/2001: Work started on test specification

| ID | WBS | Task | Duration | Start | Finish | Complete | Remaining | Baseline start | Baseline finish | Baseline duration | Total slack | Constraint | Resources | Work | Actual work | Text1 | Text6 | Text4 | Text7 | Text9 | Text8 | Text5 |
| --- | --- | --- | --- | --- | --- | --- | --- | --- | --- | --- | --- | --- | --- | --- | --- | --- | --- | --- | --- | --- | --- | --- |
| 1640 | 103.4 | **(U)SIM API** | 133d | 2002-03-20 A | 2002-09-20 A | 100% |  | 2002-03-20 | 2002-09-20 | 133d |  |  | T3 | 2128h | 2128h | USAT1-API | NA |  |  |  |  |  |
| 1641 | 103.4.1 | Java API Test specification | 133d | 2002-03-20 A | 2002-09-20 A | 100% |  | 2002-03-20 | 2002-09-20 | 133d |  | finish no earlier than 2002-09-20 | T3 | 1064h | 1064h |  |  | Mario Pérez (Microelectrónica Española) |  |  |  |  |
| 1642 | 104 | **small Technical Enhancements and Improvements for Rel5** | 2348d? | 2000-01-03 A | 2008-12-31 A | 100% |  | 2000-01-03 | 2008-12-31 | 2348d? |  |  | All | 18784h | 18784h | TEI5 | Rel-5 |  | TSG | 1993 |  |  |
| 1643 | 386.1 | Small Technical Enhancements and Improvements for Rel-5 Conformance Testing | 2348d? | 2000-01-03 A | 2008-12-31 A | 100% |  | 2000-01-03 | 2008-12-31 | 2348d? |  | finish no earlier than 2008-12-31 | R5 | 18784h | 18784h | TEI5_Test | Rel-5 |  |  |  | Stoyan Baev |  |
| 1644 | 105 | Technical Report on UE Functionality Split (Work stopped) | 86d | 2000-01-03 | 2000-05-01 |  |  | 2000-01-03 | 2000-05-01 | 86d | 2519d |  | S1 | 688h |  | UESPLIT | Rel-5 | Sanjay Gupta, Motorola | TSG |  | Michael | sanjay.gupta@motorola.com |
| 1645 | 106 | **User Equipment Management** | 267d | 2001-06-21 A | 2002-06-28 | 99% | 0d | 2001-06-21 | 2002-06-28 | 267d | 0d |  | S5 | 3752h | 3752h | UEM | Rel-5 | John Mudge (Vodafone) | TSG |  | Adrian | john.mudge@vf.vodafone.co.uk |
| 1646 | 106.1 | FS on User Equipment (UE) Management | 267d | 2001-06-21 A | 2002-06-28 A | 100% |  | 2001-06-21 | 2002-06-28 | 267d |  | finish no earlier than 2002-06-28 | S5 | 2136h | 2136h | OAM-UEM | Rel-5 | John Mudge (Vodafone) | TSG |  | Adrian | john.mudge@VF.VODAFONE.CO.UK |
| 1647 | 107 | **Flow control supporting an MS with multiple data flows with different QoS over the Gb interface** | 50d | 2002-06-24 A | 2002-08-30 A | 100% |  | 2002-06-24 | 2002-08-30 | 50d |  |  | GP | 1288h | 1288h | FlowCon | Rel-5 | Ingemar Backlund, Ericsson | TSG |  |  |  |
| 1648 | 107.1 | **Update of stage 2 specifications** | 50d | 2002-06-24 A | 2002-08-30 A | 100% |  | 2002-06-24 | 2002-08-30 | 50d |  |  | GP | 808h | 808h |  |  |  | TSG |  |  |  |
| 1649 | 107.1.1 | Concept document 23.060 (changes to) | 46d | 2002-06-28 A | 2002-08-30 A | 100% |  | 2002-06-28 | 2002-08-30 | 46d |  | finish no earlier than 2002-08-30 | S2 | 368h | 368h |  |  |  |  |  |  |  |
| 1650 | 107.1.2 | Flow Control | 5d | 2002-06-24 A | 2002-06-28 A | 100% |  | 2002-06-24 | 2002-06-28 | 5d |  | finish no earlier than 2002-06-28 | GP | 40h | 40h |  |  |  |  |  |  |  |
| 1651 | 107.2 | **Modification of BSSGP protocol** | 5d | 2002-06-24 A | 2002-06-28 A | 100% |  | 2002-06-24 | 2002-06-28 | 5d |  |  | GP | 80h | 80h |  |  | Ingemar Backlund, Ericsson | TSG |  |  |  |
| 1652 | 107.2.1 | Stage 3 (changes to 48.018) | 5d | 2002-06-24 A | 2002-06-28 A | 100% |  | 2002-06-24 | 2002-06-28 | 5d |  | finish no earlier than 2002-06-28 | G2 | 40h | 40h |  |  |  |  |  |  |  |
| 1653 | 108 | **Multiple TBF in A/Gb mode** | 421d | 2002-04-19 A | 2003-11-28 | 17% | 349.82d | 2002-04-19 | 2003-11-28 | 421d | 1585d |  | GP | 17480h | 2716.75h | MULTBF | Rel-5 | Gunnar Mildh, Ericsson | TSG |  |  | gunnar.mildh@era.ericsson.se |
| 1654 | 108.1 | **Multiple TBF in A/Gb mode** | 351d | 2002-04-19 A | 2003-08-22 | 26% | 258.09d | 2002-04-19 | 2003-08-22 | 351d | 1655d |  | GP | 8112h | 2147.3h | MULTBF-Agbmode |  |  |  |  |  |  |
| 1655 | 108.1.1 | Multiple TBF Concept paper | 351d | 2002-04-19 A | 2003-08-22 | 50% | 175.5d | 2002-04-19 | 2003-08-22 | 351d | 1655d | finish no earlier than 2003-08-22 | GP | 2808h | 1404h |  |  |  |  |  |  |  |
| 1656 | 108.1.2 | Multiple TBF Stage 2 (43.064) CRs | 156d | 2002-04-19 | 2002-11-22 |  |  | 2002-04-19 | 2002-11-22 | 156d | 1850d | finish no earlier than 2002-11-22 | G1 | 1248h |  |  |  |  |  |  |  |  |
| 1657 | 108.1.3 | Multiple TBF Stage 3 (44.060) CRs | 156d | 2002-04-19 | 2002-11-22 |  |  | 2002-04-19 | 2002-11-22 | 156d | 1850d | finish no earlier than 2002-11-22 | G2 | 1248h |  |  |  |  |  |  |  |  |
| 1658 | 108.2 | **Multiple TBF in A/Gb mode – MS testing** | 375d | 2002-06-24 | 2003-11-28 |  |  | 2002-06-24 | 2003-11-28 | 375d | 1585d |  | GP | 6000h |  |  |  | Ingemar Backlund, Ericsson |  |  |  |  |
| 1659 | 108.2.1 | MS conformance tests | 375d | 2002-06-24 | 2003-11-28 |  |  | 2002-06-24 | 2003-11-28 | 375d | 1585d | finish no earlier than 2003-11-28 | G4 | 3000h |  |  |  |  |  |  |  |  |
| 1660 | 109 | **Alignment of 3G functional split and Iu** | 922d | 2000-06-08 A | 2003-12-19 | 85% | 141.74d | 2000-06-08 | 2003-12-19 | 922d | 1570d |  | GP | 161582h | 124844h | GER3GAL | Rel-5 | Frank Muller, Ericsson | TSG | 2345 | Paolo |  |
| 1661 | 109.1 | **GERAN user / control plane** | 540d | 2000-08-07 A | 2002-08-30 | 99% | 0d | 2000-08-07 | 2002-08-30 | 540d | 0d |  | GP | 36232h | 33672h | GER3GAL-GUCOPL |  | Frank Muller, Ericsson | TSG | 2346 | Paolo |  |
| 1662 | 109.1.1 | **Alignment with UMTS bearer concept** | 540d | 2000-08-07 A | 2002-08-30 | 99% | 0d | 2000-08-07 | 2002-08-30 | 540d | 0d |  | GP | 24952h | 22392h |  |  |  | TSG | 2347 |  |  |
| 1663 | 109.1.1.1 | Enhanced power control | 1d | 2001-08-31 A | 2001-08-31 A | 100% |  | 2001-08-31 | 2001-08-31 | 1d |  | finish no earlier than 2001-08-31 | GP | 8h | 8h |  |  |  | TSG |  |  |  |
| 1664 | 109.1.1.2 | Stage 2 | 235d | 2000-08-07 A | 2001-06-29 A | 100% |  | 2000-08-07 | 2001-06-29 | 235d |  | finish no earlier than 2001-06-29 | GP | 1880h | 1880h |  |  |  | TSG | 2423 |  |  |
| 1665 | 109.1.1.3 | Adoption of the UTRAN PDCP | 295d | 2000-11-06 A | 2001-12-21 A | 100% |  | 2000-11-06 | 2001-12-21 | 295d |  | finish no earlier than 2001-12-21 | GP | 2360h | 2360h |  |  |  | TSG | 2348 |  |  |
| 1666 | 109.1.1.4 | Development of RLC / MAC | 261d | 2001-08-31 A | 2002-08-30 A | 100% |  | 2001-08-31 | 2002-08-30 | 261d |  | finish no earlier than 2002-08-30 | GP | 2088h | 2088h |  |  |  | TSG |  |  |  |
| 1667 | 109.1.1.5 | Development of GERAN RRC | 266d | 2001-06-22 A | 2002-06-28 A | 100% |  | 2001-06-22 | 2002-06-28 | 266d |  | finish no earlier than 2002-06-28 | GP | 2128h | 2128h |  |  |  | TSG |  |  |  |
| 1668 | 109.1.1.6 | Ciphering and integrity protection concept paper | 166d | 2001-08-31 A | 2002-04-19 A | 100% |  | 2001-08-31 | 2002-04-19 | 166d |  | finish no earlier than 2002-04-19 | GP | 1328h | 1328h |  |  |  | TSG |  |  |  |
| 1669 | 109.1.1.7 | Multiple TBF or equivalent Concept paper | 116d | 2001-08-31 A | 2002-02-08 A | 100% |  | 2001-08-31 | 2002-02-08 | 116d |  | finish no earlier than 2002-02-08 | GP | 928h | 928h |  |  |  | TSG |  |  |  |
| 1670 | 109.1.1.8 | Paging concept | 166d | 2001-08-31 A | 2002-04-19 A | 100% |  | 2001-08-31 | 2002-04-19 | 166d |  | finish no earlier than 2002-04-19 | GP | 1328h | 1328h |  |  |  | TSG |  |  |  |
| 1671 | 109.1.1.9 | Dedicated Physical subchannels, includes traffic and control channels | 66d | 2001-08-31 A | 2001-11-30 A | 100% |  | 2001-08-31 | 2001-11-30 | 66d |  | finish no earlier than 2001-11-30 | GP | 528h | 528h |  |  |  | TSG |  |  |  |
| 1672 | 109.1.1.10 | Iu support and broadcast concept | 166d | 2001-08-31 A | 2002-04-19 A | 100% |  | 2001-08-31 | 2002-04-19 | 166d |  | finish no earlier than 2002-04-19 | GP | 1328h | 1328h |  |  |  | TSG |  |  |  |
| 1673 | 109.1.1.11 | Impact of using RLC instead of LAPDm concept | 116d | 2001-08-31 A | 2002-02-08 A | 100% |  | 2001-08-31 | 2002-02-08 | 116d |  | finish no earlier than 2002-02-08 | GP | 928h | 928h |  |  |  | TSG |  |  |  |
| 1674 | 109.1.1.12 | Contention resolution, mobile station identity, and access concept | 66d | 2001-08-31 A | 2001-11-30 A | 100% |  | 2001-08-31 | 2001-11-30 | 66d |  | finish no earlier than 2001-11-30 | GP | 528h | 528h |  |  |  | TSG |  |  |  |
| 1675 | 109.1.1.13 | PDCP concept | 166d | 2001-08-31 A | 2002-04-19 A | 100% |  | 2001-08-31 | 2002-04-19 | 166d |  | finish no earlier than 2002-04-19 | GP | 1328h | 1328h |  |  |  | TSG |  |  |  |
| 1676 | 109.1.1.14 | Downlink delayed TBF release | 261d | 2001-08-31 A | 2002-08-30 A | 100% |  | 2001-08-31 | 2002-08-30 | 261d |  | finish no earlier than 2002-08-30 | GP | 2088h | 2088h |  |  |  | TSG |  |  |  |
| 1677 | 109.1.1.15 | Add transparent RLC Concept | 116d | 2001-08-31 A | 2002-02-08 A | 100% |  | 2001-08-31 | 2002-02-08 | 116d |  | finish no earlier than 2002-02-08 | GP | 928h | 928h |  |  |  | TSG |  |  |  |
| 1678 | 109.1.1.16 | Handover concept | 116d | 2001-08-31 A | 2002-02-08 A | 100% |  | 2001-08-31 | 2002-02-08 | 116d |  | finish no earlier than 2002-02-08 | GP | 928h | 928h |  |  |  |  |  |  |  |

Notes:
- 1640: 8/3/2001: test spec is based on R99 core spec, so deleted from Workplan
- 1642: "Joker" WI, to be used for a Rel 5 CR not related to any feature and with very limited impact on the system
- 1643: "Joker" WI, to be used for small modifications applicable to Rel 5 conformance testing. Moved in from Stoyan/testing WP. / Text3: TS 34.108, TS 34.109, TS 34.121-1, TS 34.121-2, TS 34.122, TS 34.123-1, TS 34.123-2, TS 34.123-3, Ts 34.171, TS 34.229-1, TS 34.229-2, TS 34.229-3
- 1645: az: Rel-5->NA (to cover also Rel-6)
- 1646: Text3: 32.802
- 1647: 50101 -> 50201
- 1648: 50102 -> 50202
- 1650: 50103 -> 50203
- 1654: Started
- 1658: 50106 -> 50206
- 1659: Not started
- 1660: AWS, Nokia, Ericsson, Nortel, Siemens, Vodafone
- 1661: AWS, Nokia, Ericsson, Nortel, Siemens, Vodafone
- 1665: Responsible is GERAN; RAN WG2 help may be needed.

| ID | WBS | Task | Duration | Start | Finish | Complete | Remaining | Baseline start | Baseline finish | Baseline duration | Total slack | Constraint | Resources | Work | Actual work | Text7 | Text9 | Text1 | Text4 | Text8 |
| --- | --- | --- | --- | --- | --- | --- | --- | --- | --- | --- | --- | --- | --- | --- | --- | --- | --- | --- | --- | --- |
| 1679 | 109.1.2 | **Physical layer alignment with UMTS bearer concept** | 280d | 2000-11-06 A | 2001-11-30 A | 100% |  | 2000-11-06 | 2001-11-30 | 280d |  |  | GP | 6960h | 6960h | TSG | 2424 |  |  |  |
| 1680 | 109.1.2.1 | PDTCH/TCH in 45.003 | 155d | 2000-11-06 A | 2001-06-08 A | 100% |  | 2000-11-06 | 2001-06-08 | 155d |  | finish no earlier than 2001-06-08 | GP | 1240h | 1240h | TSG | 2356 |  |  |  |
| 1681 | 109.1.2.2 | Control channels in 45.003 | 155d | 2000-11-06 A | 2001-06-08 A | 100% |  | 2000-11-06 | 2001-06-08 | 155d |  | finish no earlier than 2001-06-08 | GP | 1240h | 1240h | TSG | 2357 |  |  |  |
| 1682 | 109.1.2.3 | Receiver performance in 45.005 for PDTCH/TCH and control channels | 280d | 2000-11-06 A | 2001-11-30 A | 100% |  | 2000-11-06 | 2001-11-30 | 280d |  | finish no earlier than 2001-11-30 | GP | 2240h | 2240h | TSG | 2358 |  |  |  |
| 1683 | 109.2 | **Iu rg interface** | 430d | 2000-11-06 A | 2002-06-28 | 100% | 0d | 2000-11-06 | 2002-06-28 | 430d | 0d |  | GP; RP | 59660h | 56220h | TSG | 2359 | GER3GAL-Iurg | Frank Muller, Ericsson | Paolo |
| 1684 | 109.2.1 | **Inter BSS interface** | 430d | 2000-11-06 A | 2002-06-28 A | 100% |  | 2000-11-06 | 2002-06-28 | 430d |  |  | GP; RP | 24080h | 24080h |  | 2425 |  |  |  |
| 1685 | 109.2.1.1 | Identification of requirements | 430d | 2000-11-06 A | 2002-06-28 A | 100% |  | 2000-11-06 | 2002-06-28 | 430d |  | finish no earlier than 2002-06-28 | GP | 3440h | 3440h |  | 2360 |  |  |  |
| 1686 | 109.2.1.2 | Stage 2 | 430d | 2000-11-06 A | 2002-06-28 A | 100% |  | 2000-11-06 | 2002-06-28 | 430d |  | finish no earlier than 2002-06-28 | GP | 3440h | 3440h |  | 2361 |  |  |  |
| 1687 | 109.2.1.3 | Adoption of relevant parts from Iur | 430d | 2000-11-06 A | 2002-06-28 A | 100% |  | 2000-11-06 | 2002-06-28 | 430d |  | finish no earlier than 2002-06-28 | GP | 3440h | 3440h |  | 2362 |  |  |  |
| 1688 | 109.2.1.4 | Complementation with GERAN specifics | 430d | 2000-11-06 A | 2002-06-28 A | 100% |  | 2000-11-06 | 2002-06-28 | 430d |  | finish no earlier than 2002-06-28 | GP | 3440h | 3440h |  | 2363 |  |  |  |
| 1689 | 109.2.1.5 | Stage 3 | 430d | 2000-11-06 A | 2002-06-28 A | 100% |  | 2000-11-06 | 2002-06-28 | 430d |  | finish no earlier than 2002-06-28 | GP | 3440h | 3440h |  | 2364 |  |  |  |
| 1690 | 109.2.2 | **Inter BSS-RNS interface** | 430d | 2000-11-06 A | 2002-06-28 A | 100% |  | 2000-11-06 | 2002-06-28 | 430d |  |  | GP; RP | 28700h | 28700h |  | 2426 |  |  |  |
| 1691 | 109.2.2.1 | Identification of requirements | 430d | 2000-11-06 A | 2002-06-28 A | 100% |  | 2000-11-06 | 2002-06-28 | 430d |  | start no earlier than 2000-11-06 | GP; R3 | 6880h | 6880h |  | 2365 |  |  |  |
| 1692 | 109.2.2.2 | Stage 2 | 430d | 2000-11-06 A | 2002-06-28 A | 100% |  | 2000-11-06 | 2002-06-28 | 430d |  | finish no earlier than 2002-06-28 | GP; R3 | 5744.8h | 5744.8h |  | 2366 |  |  |  |
| 1693 | 109.2.2.3 | Adoption of relevant parts from Iur | 430d | 2000-11-06 A | 2002-06-28 A | 100% |  | 2000-11-06 | 2002-06-28 | 430d |  | finish no earlier than 2002-06-28 | GP; R3 | 6880h | 6880h |  | 2367 |  |  |  |
| 1694 | 109.2.2.4 | Complementation with GERAN specifics | 107.5d | 2002-01-30 A | 2002-06-28 A | 100% |  | 2002-01-30 | 2002-06-28 | 107.5d |  | finish no earlier than 2002-06-28 | GP; R3 | 1720h | 1720h |  | 2368 |  |  |  |
| 1695 | 109.2.2.5 | Stage 3 | 107.5d | 2002-01-30 A | 2002-06-28 A | 100% |  | 2002-01-30 | 2002-06-28 | 107.5d |  | finish no earlier than 2002-06-28 | GP; R3 | 1720h | 1720h |  | 2369 |  |  |  |
| 1696 | 109.3 | **Voice over GERAN PS and CS concept** | 430d | 2000-11-06 A | 2002-06-28 A | 100% |  | 2000-11-06 | 2002-06-28 | 430d |  |  | GP; R3 | 33338.4h | 33338.4h |  | 2370 |  |  | Paolo |
| 1697 | 109.3.1 | Architecture for A, Iu cs and Iu ps | 430d | 2000-11-06 A | 2002-06-28 A | 100% |  | 2000-11-06 | 2002-06-28 | 430d |  | finish no earlier than 2002-06-28 | GP; R3 | 6412.8h | 6412.8h |  | 2371 |  |  |  |
| 1698 | 109.3.2 | Transcoder position/operation | 115d | 2000-11-06 A | 2001-04-13 A | 100% |  | 2000-11-06 | 2001-04-13 | 115d |  | finish no earlier than 2001-04-13 | GP | 920h | 920h |  | 2372 |  |  |  |
| 1699 | 109.3.3 | Handover | 430d | 2000-11-06 A | 2002-06-28 A | 100% |  | 2000-11-06 | 2002-06-28 | 430d |  | finish no earlier than 2002-06-28 | GP; R3 | 6412.8h | 6412.8h |  | 2373 |  |  |  |
| 1700 | 109.3.4 | RTP payload | 430d | 2000-11-06 A | 2002-06-28 A | 100% |  | 2000-11-06 | 2002-06-28 | 430d |  | finish no earlier than 2002-06-28 | GP; R3 | 6412.8h | 6412.8h |  | 2374 |  |  |  |
| 1701 | 109.3.5 | Codec renegotiation concept | 365d | 2000-11-06 A | 2002-03-29 A | 100% |  | 2000-11-06 | 2002-03-29 | 365d |  | finish no earlier than 2002-03-29 | GP; R3 | 5840h | 5840h |  |  |  |  |  |
| 1702 | 109.3.6 | LA | 115d | 2000-11-06 A | 2001-04-13 A | 100% |  | 2000-11-06 | 2001-04-13 | 115d |  | finish no earlier than 2001-04-13 | GP | 920h | 920h |  |  |  |  |  |

Notes:
- 1683: AWS, Nokia, Ericsson, Nortel, Siemens, Vodafone

| ID | WBS | Task | Duration | Start | Finish | Complete | Remaining | Baseline start | Baseline finish | Baseline duration | Total slack | Constraint | Resources | Work | Actual work | Text8 | Text9 | Text1 | Text4 | Text6 | Text7 |
| --- | --- | --- | --- | --- | --- | --- | --- | --- | --- | --- | --- | --- | --- | --- | --- | --- | --- | --- | --- | --- | --- |
| 1703 | 109.4 | **GERAN MS Conformance test for GERAN interface evolution** | 660d | 2001-06-11 | 2003-12-19 |  |  | 2001-06-11 | 2003-12-19 | 660d | 1570d |  | GP | 10560h |  | Paolo | 2388 |  |  |  |  |
| 1704 | 109.4.1 | MS test | 660d | 2001-06-11 | 2003-12-19 |  |  | 2001-06-11 | 2003-12-19 | 660d | 1570d | finish no earlier than 2003-12-19 | GP | 5280h |  |  | 2389 |  |  |  |  |
| 1705 | 109.5 | **GERAN BSS Conformance test for GERAN interface evolution** | 922d | 2000-06-08 | 2003-12-19 |  |  | 2000-06-08 | 2003-12-19 | 922d | 1570d |  | GP | 14752h |  | Paolo | 2390 |  |  |  |  |
| 1706 | 109.5.1 | BSS test | 922d | 2000-06-08 | 2003-12-19 |  |  | 2000-06-08 | 2003-12-19 | 922d | 1570d | finish no earlier than 2003-12-19 | GP | 7376h |  |  | 2391 |  |  |  |  |
| 1707 | 110 | **GERAN support for IMS** | 690d | 2000-05-01 A | 2002-12-20 | 59% | 286.24d | 2000-05-01 | 2002-12-20 | 690d | 1830d |  | GP | 66591.8h | 38052.6h | Paolo |  | GERIMS | Shkumbin Hamiti, Nokia | Rel-5 | TSG |
| 1708 | 110.1 | **GERAN Header adaptation** | 690d | 2000-05-01 A | 2002-12-20 | 100% | 0d | 2000-05-01 | 2002-12-20 | 690d | 0d |  | GP; S2; RP | 27325.8h | 18525.8h | Paolo |  | GERIMS-HEADAPT | Shkumbin Hamiti, Nokia |  | TSG |
| 1709 | 110.1.1 | Definition of compression and removal modes for PDCP protocol | 22.1d | 2000-05-01 A | 2000-11-10 A | 100% |  | 2000-05-01 | 2000-11-10 | 22.1d |  | finish no earlier than 2000-09-01 | GP; S2; RP | 248.4h | 248.4h |  | 2332 |  |  |  | TSG |
| 1710 | 110.1.2 | Conceptual description in stage 2 | 393d | 2000-05-01 A | 2001-10-31 A | 100% |  | 2000-05-01 | 2001-10-31 | 393d |  | finish no earlier than 2001-10-31 | GP; S2; RP | 5989.93h | 5989.93h |  | 2333 |  |  |  | TSG |
| 1711 | 110.1.3 | Necessary changes on stage 3 regarding header removal | 439.8d | 2000-11-06 A | 2002-12-20 A | 100% |  | 2000-11-06 | 2002-12-20 | 439.8d |  | finish no earlier than 2002-12-20 | GP; S2; RP | 6767.47h | 6767.47h |  |  |  |  |  | TSG |
| 1712 | 110.2 | **GERAN Radio access bearer design for IMS** | 430d | 2000-11-06 A | 2002-06-28 | 89% | 46.49d | 2000-11-06 | 2002-06-28 | 430d | 1955d |  | GP; S2; RP | 21658h | 16713.3h | Paolo | 2335 | GERIMS-RABDES | Shkumbin Hamiti, Nokia |  | TSG |
| 1713 | 110.2.1 | **MuM control signalling for conversational multimedia services** | 430d | 2000-11-06 A | 2002-06-28 | 89% | 46.49d | 2000-11-06 | 2002-06-28 | 430d | 1955d |  | GP; S2; RP | 12458h | 8507.9h |  | 2422 |  |  |  | TSG |
| 1714 | 110.2.1.1 | Identification of requirements | 330d | 2000-11-06 A | 2002-02-08 A | 100% |  | 2000-11-06 | 2002-02-08 | 330d |  | finish no earlier than 2002-02-08 | GP; S2; RP | 5545.6h | 5545.6h |  | 2431 |  |  |  | TSG |
| 1715 | 110.2.1.2 | Necessary modifications due to SIP | 40d | 2002-05-06 | 2002-06-28 |  |  | 2002-05-06 | 2002-06-28 | 40d | 1955d | finish no earlier than 2002-06-28 | GP; S2; RP | 960h |  |  | 2337 |  |  |  | TSG |
| 1716 | 110.3 | **GERAN MS Conformance test for support of IMS** | 400d | 2001-06-11 | 2002-12-20 |  |  | 2001-06-11 | 2002-12-20 | 400d | 1830d |  | GP | 6400h |  | Paolo | 2341 | GERIMS-MSconf | Shkumbin Hamiti, Nokia |  | TSG |
| 1717 | 110.3.1 | MS test | 400d | 2001-06-11 | 2002-12-20 |  |  | 2001-06-11 | 2002-12-20 | 400d | 1830d | finish no earlier than 2002-12-20 | G4 | 3200h |  |  | 2342 |  |  |  | TSG |
| 1718 | 110.4 | **GERAN BTS Conformance test for support of IMS** | 400d | 2001-06-11 | 2002-12-20 |  |  | 2001-06-11 | 2002-12-20 | 400d | 1830d |  | GP | 6400h |  | Paolo | 2343 | GERIMS-BTSconf | Shkumbin Hamiti, Nokia |  | TSG |
| 1719 | 110.4.1 | BTS test | 400d | 2001-06-11 | 2002-12-20 |  |  | 2001-06-11 | 2002-12-20 | 400d | 1830d | finish no earlier than 2002-12-20 | G3 | 3200h |  |  | 2344 |  |  |  | TSG |
| 1720 | 393 | MS Conformance Testing of Dual Transfer Mode | 65d? | 2002-11-11 A | 2003-02-07 A | 100% |  | 2002-11-11 | 2003-02-07 | 65d? |  | finish no earlier than 2003-02-07 | G4; G5 | 1040h | 1040h |  |  | MSCTDTM | Dave Fox, Vodafone | NA | TSG |
| 1721 | 394 | **Handling of early UEs** | 910d? | 2000-01-03 A | 2003-06-27 A | 100% |  | 2000-01-03 | 2003-06-27 | 910d? |  |  | S2 | 4480h | 4480h | Alain |  | LATE_UE |  | Rel-5 | TSG |
| 1722 | 394.1 | Feasibility Study | 50d? | 2002-10-07 A | 2002-12-13 A | 100% |  | 2002-10-07 | 2002-12-13 | 50d? |  | finish no earlier than 2002-12-13 | S2 | 400h | 400h |  |  |  |  |  | WG |
| 1723 | 394.2 | Stage 2 | 125d? | 2003-01-06 A | 2003-06-27 A | 100% |  | 2003-01-06 | 2003-06-27 | 125d? |  | start no earlier than 2003-01-06 | S2 | 1000h | 1000h |  |  |  |  |  | WG |
| 1724 | 394.3 | FS for the Early Mobile Handling in UTRAN | 195d | 2002-09-09 A | 2003-06-06 A | 100% |  | 2002-09-09 | 2003-06-06 | 195d |  | finish no earlier than 2003-06-06 | R2 | 1560h | 1560h |  |  | FSEarlyUE | Alan Law, Vodafone Ltd | Rel-5 | TSG |
| 1725 | 394.4 | Note: Stage 3 RAN part not shown | 1d | 2000-01-03 A | 2000-01-03 A | 100% |  | 2000-01-03 | 2000-01-03 | 1d |  |  |  |  |  |  | 96 |  |  |  |  |
| 1726 | 395 | Release 4 Features | 1d? | 2000-01-03 | 2000-01-03 |  |  | 2000-01-03 | 2000-01-03 | 1d? | 2604d |  | CP,GP, RP,SP,TP | 8h |  |  |  |  |  | Rel-4 |  |

Notes:
- 1703: Not started
- 1704: Not started
- 1705: Not started
- 1706: Not started
- 1707: AWS, Nokia, Ericsson, Nortel, Siemens, Motorola
- 1708: AWS, Nokia, Ericsson, Nortel, Siemens, Motorola
- 1712: TERMINATED - NOT STANDARDIZED
- 1713: TERMINATED - NOT STANDARDIZED
- 1714: TERMINATED - NOT STANDARDIZED
- 1715: TERMINATED - NOT STANDARDIZED
- 1716: TERMINATED - NOT STANDARDIZED
- 1717: TERMINATED - NOT STANDARDIZED
- 1718: TERMINATED - NOT STANDARDIZED
- 1719: TERMINATED - NOT STANDARDIZED
- 1720: Needed to complete DTM (R99)

| ID | WBS | Task | Duration | Start | Finish | Predecessors | Complete | Remaining | Baseline start | Baseline finish | Baseline duration | Total slack | Constraint | Resources | Work | Actual work | Text1 | Text6 | Text8 | Text9 | Text3 | Text7 | Text2 | Text4 | Text5 |
| --- | --- | --- | --- | --- | --- | --- | --- | --- | --- | --- | --- | --- | --- | --- | --- | --- | --- | --- | --- | --- | --- | --- | --- | --- | --- |
| 1727 | 15 | **Miscelleneous UE Conformance Testing Activities** | 958d | 2001-04-02 A | 2004-12-01 |  | 50% | 483.11d | 2001-04-02 | 2004-12-01 | 958d | 1322d |  | T1 | 36360h | 18023.9h | MISTST1 | NA | Lidia | 1861 |  |  |  |  |  |
| 1728 | 15.1 | Optimisation of Test Time, RF Aspects (FDD) | 508d | 2001-09-24 A | 2003-09-03 |  | 70% | 152.4d | 2001-09-24 | 2003-09-03 | 508d | 1647d | finish no earlier than 2003-09-03 | T1 | 4064h | 2844.8h | MISTST1-OpFDD | Rel Indep |  | 1862 | 34.121 | TSG |  |  |  |
| 1729 | 15.2 | Optimisation of Test Time, RF Aspects (TDD) | 508d | 2001-09-24 A | 2003-09-03 |  | 70% | 152.4d | 2001-09-24 | 2003-09-03 | 508d | 1647d | finish no earlier than 2003-09-03 | T1 | 4064h | 2844.8h | MISTST1-OpTDD | Rel Indep |  | 1863 | 34.122 | TSG |  |  |  |
| 1730 | 15.3 | Extensions to R99 Test cases | 139.4w | 2001-04-02 A | 2003-12-02 |  | 70% | 41.82w | 2001-04-02 | 2003-12-02 | 139.4w | 1583d | finish no earlier than 2003-12-02 | T1 | 5576h | 3903.2h | MISTST1-Ext |  |  | 1907 | 34.123 pts 1,2 | TSG |  |  |  |
| 1731 | 15.4 | Extension to R99 Test cases - TTCN | 439d | 2002-06-28 A | 2004-03-03 |  | 50% | 219.5d | 2002-06-28 | 2004-03-03 | 439d | 1517d | finish no earlier than 2004-03-03 | T1 | 3512h | 1756h |  |  |  |  |  | TSG |  |  |  |
| 1732 | 15.5 | Creation of R99 TCs for TDD - prose | 719d | 2001-10-01 A | 2004-07-01 |  | 50% | 359.5d | 2001-10-01 | 2004-07-01 | 719d | 1431d | finish no earlier than 2004-07-01 | T1 | 5752h | 2876h | MISTST1-TDD |  |  |  | 34.123-1 | TSG |  |  |  |
| 1733 | 15.6 | Creation of R99 TCs for TDD - TTCN | 587d | 2002-09-03 | 2004-12-01 |  |  |  | 2002-09-03 | 2004-12-01 | 587d | 1322d | finish no earlier than 2004-12-01 | T1 | 4696h |  |  |  |  |  |  | TSG |  |  |  |
| 1734 | 15.7 | Review all other work items for impact on new or exiting 34 series specs. | 25.8w | 2002-07-02 | 2002-12-27 |  |  |  | 2002-07-02 | 2002-12-27 | 25.8w | 1825d | finish no earlier than 2002-12-27 | T1 | 1032h |  | MISTST1 |  |  | 1908 | 34.121,122,123,125 |  |  |  |  |
| 1735 | 46 | **Facsimile** | 89d | 2000-02-22 A | 2000-06-23 A |  | 100% |  | 2000-02-22 | 2000-06-23 | 89d |  |  | S1 | 4376h | 4376h | FAX | Rel-4 | Alain | 1340 |  | TSG |  |  |  |
| 1736 | 46.1 | **Real Time Fax** | 89d | 2000-02-22 A | 2000-06-23 A |  | 100% |  | 2000-02-22 | 2000-06-23 | 89d |  |  | S2 | 3664h | 3664h | FAX-RT |  |  | 1341 |  |  | CCaR |  |  |
| 1737 | 46.1.1 | Terminal capabilities, AT commands | 89d | 2000-02-22 A | 2000-06-23 A |  | 100% |  | 2000-02-22 | 2000-06-23 | 89d |  | finish no earlier than 2000-06-23 | T2 | 712h | 712h |  |  |  | 1808 | 21.904, 27.007 |  | CCaR |  |  |
| 1738 | 46.1.2 | Signalling aspects (e.g. ICM) | 89d | 2000-02-22 A | 2000-06-23 A |  | 100% |  | 2000-02-22 | 2000-06-23 | 89d |  | start no earlier than 2000-02-22 | N1 | 712h | 712h |  |  |  | 1343 |  |  | CCaR |  |  |
| 1739 | 46.1.3 | Service provision | 89d | 2000-02-22 A | 2000-06-23 A |  | 100% |  | 2000-02-22 | 2000-06-23 | 89d |  | finish no earlier than 2000-06-23 | N3 | 712h | 712h |  |  |  | 1648 | 23.146 |  | CCaR |  |  |
| 1740 | 46.1.4 | Review whether service/stage 1 aspects need to be aligned | 51d | 2000-04-14 A | 2000-06-23 A |  | 100% |  | 2000-04-14 | 2000-06-23 | 51d |  | finish no earlier than 2000-12-14 | S1 | 408h | 408h |  |  |  | 1345 |  |  | CCaR |  |  |
| 1741 | 46.1.5 | Review whether architecture/stage 2 aspects need to be aligned | 51d | 2000-04-14 A | 2000-06-23 A |  | 100% |  | 2000-04-14 | 2000-06-23 | 51d |  | finish no earlier than 2000-12-14 | S2 | 408h | 408h |  |  |  | 1346 |  |  | CCaR |  |  |
| 1742 | 47 | Transparent End-to-End PS mobile streaming application | 253d | 2000-04-03 A | 2001-03-21 A |  | 100% |  | 2000-04-03 | 2001-03-21 | 253d |  | finish no earlier than 2000-12-29 | S4 | 2024h | 2024h | PSTREAM | Rel-4 | Paolo | 1539 | 26.233, 26.234 | TSG |  |  |  |
| 1743 | 48 | **Multimedia Messaging** | 277d | 2000-02-22 A | 2001-03-14 |  | 99% | 0d | 2000-02-22 | 2001-03-14 | 277d | 0d |  | T2 | 12208h | 10661.6h | MMS | Rel-4 | Friedhelm | 1818 | 22.140, 23.140 | TSG | Mes | Josef Laumen, Siemens | Josef.Laumen@SAL.SIEMENS.DE |
| 1744 | 48.1 | Definition of service requirements | 72d | 2000-02-22 A | 2000-05-31 A |  | 100% |  | 2000-02-22 | 2000-05-31 | 72d |  | start no earlier than 2000-02-22 | S1 | 576h | 576h | MMS |  |  | 136 |  |  | Mes |  |  |
| 1745 | 48.2 | Review of definition of service requirements | 205d | 2000-06-01 A | 2001-03-14 A | 1744 | 100% |  | 2000-06-01 | 2001-03-14 | 205d |  | finish no earlier than 2000-09-08 | T2 | 1640h | 1640h |  |  |  | 1819 | 22.140, 23.140 | TSG | Mes | Josef Laumen, Siemens |  |
| 1746 | 48.3 | **Technical Realisation** | 243d | 2000-04-10 A | 2001-03-14 A |  | 100% |  | 2000-04-10 | 2001-03-14 | 243d |  |  | T2 | 7776h | 7776h |  |  |  | 1820 | 22.140, 23.140 | TSG | Mes | Josef Laumen, Siemens | Josef.Laumen@SAL.SIEMENS.DE |
| 1747 | 48.3.1 | Review of definition of reference Achitecture model | 243d | 2000-04-10 A | 2001-03-14 A |  | 100% |  | 2000-04-10 | 2001-03-14 | 243d |  | finish no earlier than 2001-03-14 | T2 | 1944h | 1944h |  |  |  | 1821 | 22.140, 23.140 | TSG | Mes | Josef Laumen, Siemens | Josef.Laumen@SAL.SIEMENS.DE |
| 1748 | 48.3.2 | "Fulfill Requirements of Stage 1" | 243d | 2000-04-10 A | 2001-03-14 A |  | 100% |  | 2000-04-10 | 2001-03-14 | 243d |  | finish no earlier than 2001-03-14 | T2 | 1944h | 1944h |  |  |  | 1822 | 22.140, 23.140 | TSG | Mes | Josef Laumen, Siemens | Josef.Laumen@SAL.SIEMENS.DE |
| 1749 | 48.3.3 | Definition of MMS primitives in Stage 2 | 243d | 2000-04-10 A | 2001-03-14 A |  | 100% |  | 2000-04-10 | 2001-03-14 | 243d |  | finish no earlier than 2001-03-14 | T2 | 1944h | 1944h |  |  |  | 1823 | 22.140, 23.140 | TSG | Mes | Josef Laumen, Siemens | Josef.Laumen@SAL.SIEMENS.DE |
| 1750 | 49 | **Transcoder-Free Operation** | 325d | 2000-01-03 A | 2001-03-30 A |  | 100% |  | 2000-01-03 | 2001-03-30 | 325d |  |  | N4 | 13040h | 13040h | TrFO | Rel-4 | Kimmo | 1541 |  |  | Cod |  |  |
| 1751 | 49.1 | **OoBTC solution** | 325d | 2000-01-03 A | 2001-03-30 A |  | 100% |  | 2000-01-03 | 2001-03-30 | 325d |  |  | N4 | 8440h | 8440h | TRFO-OOBTC |  |  | 112 |  | WG | Cod | Tosshiyuki Tamura, NEC | tamurato@elsf.ncos.nec.co.jp |
| 1752 | 49.1.1 | implementation in UTRAN | 145d | 2000-09-11 A | 2001-03-30 A |  | 100% |  | 2000-09-11 | 2001-03-30 | 145d |  | finish no earlier than 2001-03-30 | R3 | 1160h | 1160h | TRFO-OOBTC-UTRAN |  |  | 1512 | 25.401, 25.410, 25.413, 25.415, 23.153 | TSG |  | Alexander Vesely, Siemens | alexander.vesely@SIEMENS.AT |
| 1753 | 49.1.2 | Impact on architecture, Principles and Terminology | 210d | 2000-01-03 A | 2000-10-20 A |  | 100% |  | 2000-01-03 | 2000-10-20 | 210d |  | finish no earlier than 2000-10-20 | S2 | 1680h | 1680h |  |  |  | 896 |  |  | Cod |  |  |
| 1754 | 49.1.3 | Codec Negotiation between UE and MSC | 125d | 2000-08-14 A | 2001-02-02 A |  | 100% |  | 2000-08-14 | 2001-02-02 | 125d |  | finish no earlier than 2001-02-02 | N1 | 1000h | 1000h |  |  |  | 1657 | 24.008, 23.009, 23.108, (29.002) | TSG | Cod | Andrew Howell / Motorola |  |
| 1755 | 49.1.4 | Codec Negotiation inter MSC | 125d | 2000-07-03 A | 2000-12-22 A |  | 100% |  | 2000-07-03 | 2000-12-22 | 125d |  | finish no earlier than 2000-12-22 | N4 | 1000h | 1000h |  |  |  | 115 |  |  | Cod |  |  |
| 1756 | 49.1.5 | Bearer establishment inter MSC | 125d | 2000-07-03 A | 2000-12-22 A |  | 100% |  | 2000-07-03 | 2000-12-22 | 125d |  | finish no earlier than 2000-12-22 | N4 | 1000h | 1000h |  |  |  | 894 | 23.153 | TSG | Cod |  |  |

Notes:
- 1728: It is believed that the current R99 test spec. can be optimised for faster overall test times
- 1729: It is believed that the current R99 test spec. can be optimised for faster overall test times
- 1730: Further test coverage of the R99 specification to cover supplementry services
- 1734: Can't start until most core specs are stable
- 1736: postponed from R99 to R00, SP-000169
- 1748: e.g. minimum set of media formats, media format conversion, personalization of MMS.
- 1750: Lead given to CN4 from CN / [DAB 28/11/00]
- 1752: moved according to NP-000575
- 1753: e.g. study cascading TrFO/TFO/TrFO
- 1754: the link to NP-000085has been deleted because refering to a R99 status sheet / One common set of codec negotiation procedures will be specified as in ID1656.
- 1755: Bearer establishment inter MSC. TS 23.153 R99 part complete. capabilities moved to annex + list of open issues
- 1756: Bearer establishment inter MSC. TS 23.153 R99 part complete. capabilities moved to annex. / See NP-000127 / Open issues: / Handling of Conference Calls; / Handling of Multi Party Supplementary Services; / Handling of Handover UMTS to GSM; / Handling of Sending a ...

| ID | WBS | Task | Type | Duration | Start | Finish | Complete | Remaining | Baseline start | Baseline finish | Baseline duration | Total slack | Constraint | Resources | Work | Actual work | Text1 | Text2 | Text7 | Text9 | Text6 | Text8 | Text4 |
| --- | --- | --- | --- | --- | --- | --- | --- | --- | --- | --- | --- | --- | --- | --- | --- | --- | --- | --- | --- | --- | --- | --- | --- |
| 1757 | 49.2 | **Speech Transcoder: Location and Control at the UMTS Core Network Border** |  | 125d | 2000-04-10 A | 2000-09-29 A | 100% |  | 2000-04-10 | 2000-09-29 | 125d |  |  | S2 | 2000h | 2000h | TRFO-STLC | Cod | WG | 905 |  |  |  |
| 1758 | 49.2.1 | Transcoder at Edge |  | 125d | 2000-04-10 A | 2000-09-29 A | 100% |  | 2000-04-10 | 2000-09-29 | 125d |  | finish no earlier than 2000-09-29 | NP | 1000h | 1000h |  | Cod |  | 124 |  |  |  |
| 1759 | 50 | **GERAN improvements 1 (Gb over IP)** |  | 225d | 2000-05-09 A | 2001-03-19 A | 100% |  | 2000-05-09 | 2001-03-19 | 225d |  |  | GP | 6472h | 6472h | GEIMP1 |  | TSG | 2310 | Rel-4 | Paolo |  |
| 1760 | 50.1 | **Gb over IP (Ip-fication of Gb)** |  | 225d | 2000-05-09 A | 2001-03-19 A | 100% |  | 2000-05-09 | 2001-03-19 | 225d |  |  | GP | 4672h | 4672h | GbIP |  | TSG | 2311 |  | Paolo |  |
| 1761 | 50.1.1 | Concept |  | 134d | 2000-05-09 A | 2000-11-10 A | 100% |  | 2000-05-09 | 2000-11-10 | 134d |  |  | GP | 1072h | 1072h |  |  | TSG | 2312 |  |  |  |
| 1762 | 50.1.2 | Changes to 08.16, 08.18 |  | 225d | 2000-05-09 A | 2001-03-19 A | 100% |  | 2000-05-09 | 2001-03-19 | 225d |  |  | GP | 1800h | 1800h |  |  | TSG | 2313 |  |  |  |
| 1763 | 51 | **GERAN improvements 2 (NACC)** |  | 815d | 2000-11-06 A | 2003-12-19 | 80% | 159.32d | 2000-11-06 | 2003-12-19 | 815d | 1570d |  | GP | 24616h | 13616h | GEIMP2 |  | TSG | 2314 | Rel-4 | Paolo |  |
| 1764 | 51.1 | **Gb enhancements** |  | 155d | 2000-11-06 A | 2001-06-08 A | 100% |  | 2000-11-06 | 2001-06-08 | 155d |  |  | GP | 7440h | 7440h | Gben |  | TSG | 2315 |  | Paolo |  |
| 1765 | 51.1.1 | **Intra BSC NACC (Network Assisted Cell Change)** |  | 155d | 2000-11-06 A | 2001-06-08 A | 100% |  | 2000-11-06 | 2001-06-08 | 155d |  |  | GP | 6200h | 6200h |  |  | TSG | 2316 |  |  |  |
| 1766 | 51.1.1.1 | Concept |  | 155d | 2000-11-06 A | 2001-06-08 A | 100% |  | 2000-11-06 | 2001-06-08 | 155d |  | finish no earlier than 2001-06-08 | GP | 1240h | 1240h |  |  | TSG | 2420 |  |  |  |
| 1767 | 51.1.1.2 | Changes in 03.64 |  | 155d | 2000-11-06 A | 2001-06-08 A | 100% |  | 2000-11-06 | 2001-06-08 | 155d |  | finish no earlier than 2001-06-08 | GP | 1240h | 1240h |  |  | TSG | 2317 |  |  |  |
| 1768 | 51.1.1.3 | Changes in 04.60 |  | 155d | 2000-11-06 A | 2001-06-08 A | 100% |  | 2000-11-06 | 2001-06-08 | 155d |  | finish no earlier than 2001-06-08 | GP | 1240h | 1240h |  |  | TSG | 2318 |  |  |  |
| 1769 | 51.1.1.4 | Changes in 44.008 |  | 155d | 2000-11-06 A | 2001-06-08 A | 100% |  | 2000-11-06 | 2001-06-08 | 155d |  | finish no earlier than 2001-06-08 | GP | 1240h | 1240h |  |  | TSG | 2319 |  |  |  |
| 1770 | 51.2 | Start Testing | milestone | 0d | 2001-06-04 | 2001-06-04 |  |  | 2001-06-04 | 2001-06-04 | 0d | 2235d | start no earlier than 2001-06-04 |  |  |  |  |  |  |  |  |  |  |
| 1771 | 51.3 | **MS conformance test for Intra BSC NACC** |  | 536d | 2001-11-30 A | 2003-12-19 | 50% | 268d | 2001-11-30 | 2003-12-19 | 536d | 1570d |  | GP | 10656h | 5328h | GEIMP2-Msconf |  |  |  |  |  |  |
| 1772 | 51.3.1 | Changes in 51.010 |  | 398d | 2001-11-30 A | 2003-12-19 | 50% | 199d | 2001-11-30 | 2003-12-19 | 398d | 1570d | finish no earlier than 2003-12-19 | G5; G4 | 6368h | 3184h |  |  |  |  |  |  |  |
| 1773 | 52 | **GERAN improvements 4 (Delayed TBF)** |  | 105d | 2001-01-15 A | 2001-06-08 A | 100% |  | 2001-01-15 | 2001-06-08 | 105d |  |  | GP | 3960h | 3960h | GEIMP4 |  | TSG | 2324 | Rel-4 | Paolo |  |
| 1774 | 52.1 | **Gb enhancements 2** |  | 105d | 2001-01-15 A | 2001-06-08 A | 100% |  | 2001-01-15 | 2001-06-08 | 105d |  |  | GP | 3120h | 3120h | GEIMP4-Gben2 |  | TSG | 2325 |  |  |  |
| 1775 | 52.1.1 | stage 2 |  | 105d | 2001-01-15 A | 2001-06-08 A | 100% |  | 2001-01-15 | 2001-06-08 | 105d |  | finish no earlier than 2001-06-08 | GP | 840h | 840h |  |  |  | 2429 |  |  |  |
| 1776 | 52.1.2 | **Stage 3 (changes in 44.060)** |  | 60d | 2001-01-15 A | 2001-04-06 A | 100% |  | 2001-01-15 | 2001-04-06 | 60d |  |  | G2 | 1440h | 1440h |  |  | TSG | 2421 |  |  |  |
| 1777 | 52.1.2.1 | Definition of enhanced countdown procedure |  | 60d | 2001-01-15 A | 2001-04-06 A | 100% |  | 2001-01-15 | 2001-04-06 | 60d |  | finish no earlier than 2001-04-06 | G2 | 480h | 480h |  |  | TSG | 2327 |  |  |  |
| 1778 | 52.1.2.2 | Definition of enhanced TBF release procedure |  | 60d | 2001-01-15 A | 2001-04-06 A | 100% |  | 2001-01-15 | 2001-04-06 | 60d |  | finish no earlier than 2001-04-06 | G2 | 480h | 480h |  |  | TSG | 2328 |  |  |  |
| 1779 | 52.1.2.3 | Definition of USF=FREE type polling mechanism on PDCH |  | 60d | 2001-01-15 A | 2001-04-06 A | 100% |  | 2001-01-15 | 2001-04-06 | 60d |  | finish no earlier than 2001-04-06 | G2 | 480h | 480h |  |  | TSG | 2329 |  |  |  |
| 1780 | 53 | **Low Chip Rate TDD option** |  | 880d | 2000-07-19 A | 2003-12-02 | 76% | 208.03d | 2000-07-19 | 2003-12-02 | 880d | 1583d |  | R1 | 25872h | 19687.3h | LCRTDD |  | TSG | 1222 | Rel-4 | Tsukasa | G. Yang, CWTS |
| 1781 | 53.1 | Physical layer |  | 183d | 2000-07-19 A | 2001-03-30 A | 100% |  | 2000-07-19 | 2001-03-30 | 183d |  | finish no earlier than 2001-03-30 | R1 | 1464h | 1464h | LCRTDD-Phys |  | TSG | 1223 |  |  | G. Yang, CWTS |
| 1782 | 53.2 | Layer 2 and layer 3 protocol aspects |  | 183d | 2000-07-19 A | 2001-03-30 A | 100% |  | 2000-07-19 | 2001-03-30 | 183d |  | finish no earlier than 2001-03-30 | R2 | 1464h | 1464h | LCRTDD-L23 | BaAS | TSG | 1224 |  |  | Y. Liu, CWTS |
| 1783 | 53.3 | RF radio transmission/reception, system performance requirements and conformance testing |  | 165d | 2000-08-14 A | 2001-03-30 A | 100% |  | 2000-08-14 | 2001-03-30 | 165d |  | finish no earlier than 2001-03-30 | R4 | 1320h | 1320h | LCRTDD-RF | BaAS | TSG | 1225 |  |  | D. Zhang, CWTS |
| 1784 | 53.4 | UE radio access capability |  | 165d | 2000-08-14 A | 2001-03-30 A | 100% |  | 2000-08-14 | 2001-03-30 | 165d |  | finish no earlier than 2001-03-30 | R2 | 1320h | 1320h | LCRTDD-UErac | BaAS | TSG | 1227 |  |  | Y. Liu, CWTS |
| 1785 | 53.5 | Iub/Iur protocol aspects |  | 165d | 2000-08-14 A | 2001-03-30 A | 100% |  | 2000-08-14 | 2001-03-30 | 165d |  | finish no earlier than 2001-03-30 | R3 | 1320h | 1320h | LCRTDD-IubIur | BaAS | TSG | 1228 |  |  | Y. Liu, CWTS |

Notes:
- 1757: WI description and Tdoc S2-99352 / Speech Transcoder: Location and Control at the UMTS Core Network Border
- 1758: WI description and Tdoc S2-99352...
- 1771: Started
- 1772: 50099 -> 50299

| ID | WBS | Task | Type | Duration | Start | Finish | Predecessors | Complete | Remaining | Baseline start | Baseline finish | Baseline duration | Total slack | Free slack | Constraint | Resources | Work | Actual work | Text8 | Text9 | Text3 | Text7 | Text1 | Text4 | Text6 | Text2 | Text5 |
| --- | --- | --- | --- | --- | --- | --- | --- | --- | --- | --- | --- | --- | --- | --- | --- | --- | --- | --- | --- | --- | --- | --- | --- | --- | --- | --- | --- |
| 1786 | 53.6 | **Low chiprate TDD interworking with GERAN** |  | 101d | 2000-09-01 A | 2001-01-19 A | 1785 | 100% |  | 2000-09-01 | 2001-01-19 | 101d |  |  |  |  |  |  | Paolo | 2262 |  |  |  |  |  |  |  |
| 1787 | 53.6.1 | Handover and Cell Selection / Reselection to UTRA 1.28 Mcps TDD |  | 101d | 2000-09-01 A | 2001-01-19 A |  | 100% |  | 2000-09-01 | 2001-01-19 | 101d |  |  | finish no earlier than 2001-01-19 |  |  |  |  | 2263 |  |  |  |  |  |  |  |
| 1788 | 53.7 | Start Testing | milestone | 0d | 2001-09-03 | 2001-09-03 | 1786 |  |  | 2001-09-03 | 2001-09-03 | 0d | 1893.11d | 10d | start no earlier than 2001-09-03 | MLST |  |  |  | 1911 |  |  |  |  |  |  |  |
| 1789 | 53.8 | **Conformance Test Aspects - Low Chip Rate TDD** |  | 577d | 2001-09-17 A | 2003-12-02 | 1788 | 52% | 276.89d | 2001-09-17 | 2003-12-02 | 577d | 1583d |  |  | T1 | 12088h | 6287.32h |  | 2103 | 0% |  |  |  |  |  |  |
| 1790 | 53.8.1 | Testing Layer 2 and layer 3 protocol aspects |  | 468d | 2001-09-17 A | 2003-07-02 |  | 60% | 187.2d | 2001-09-17 | 2003-07-02 | 468d | 1692d |  | finish no earlier than 2003-07-02 | T1 | 3744h | 2246.4h |  | 2217 | 34.123-1, 34.123-2 | TSG |  |  |  |  |  |
| 1791 | 53.8.2 | Testing Layer 2 and layer 3 protocol aspects - TTCN |  | 261d | 2002-12-03 | 2003-12-02 |  |  |  | 2002-12-03 | 2003-12-02 | 261d | 1583d |  | finish no earlier than 2003-12-02 | T1 | 2088h |  |  |  | 34.123-3 | TSG |  |  |  |  |  |
| 1792 | 53.8.3 | Testing RF Radio Transmission and Reception |  | 205d | 2001-09-17 A | 2002-06-28 A |  | 100% |  | 2001-09-17 | 2002-06-28 | 205d |  |  | finish no earlier than 2002-06-28 | T1 | 1640h | 1640h |  | 2218 |  | TSG |  |  |  |  |  |
| 1793 | 54 | **Enable bearer independent CS architecture** |  | 565d | 2000-01-03 A | 2002-03-01 |  | 80% | 114.5d | 2000-01-03 | 2002-03-01 | 565d | 2040d |  |  | S2 | 20176h | 17180h | Kimmo |  |  | TSG | CSSPLIT | Alexander Milinski, Siemens | Rel-4 |  |  |
| 1794 | 54.1 | **Enable bearer-independent call control** |  | 424d | 2000-01-03 A | 2001-08-16 A |  | 100% |  | 2000-01-03 | 2001-08-16 | 424d |  |  |  | N4 | 12336h | 12336h |  | 1323 |  | WG |  | Heinz-Peter Keutman, Ericsson |  | CCaR | Heinz-Peter.Keutmann@eed.ericsson.se |
| 1795 | 54.1.1 | Architecture and Stage 2 description |  | 180d | 2000-01-03 A | 2000-09-08 A |  | 100% |  | 2000-01-03 | 2000-09-08 | 180d |  |  | finish no earlier than 2000-09-08 | S2 | 1440h | 1440h |  | 1516 | 23.002 |  |  |  |  | CCaR |  |
| 1796 | 54.1.2 | Standardisation of protocols (control & user planes) over Nb interface |  | 64d | 2001-01-02 A | 2001-03-30 A |  | 100% |  | 2001-01-02 | 2001-03-30 | 64d |  |  | finish no earlier than 2001-03-30 | N3 | 512h | 512h |  | 1325 |  | TSG |  |  |  | CCaR |  |
| 1797 | 54.1.3 | Standardisation of protocols over reference points between MSC server and Gateway MSC server |  | 130d | 2000-09-25 A | 2001-03-23 A |  | 100% |  | 2000-09-25 | 2001-03-23 | 130d |  |  | finish no earlier than 2001-03-23 | N4 | 1040h | 1040h |  | 1326 |  | TSG |  |  |  | CCaR |  |
| 1798 | 54.1.4 | Standardisation of detailed stage 2 description |  | 180d | 2000-07-17 A | 2001-03-23 A |  | 100% |  | 2000-07-17 | 2001-03-23 | 180d |  |  | finish no earlier than 2001-03-23 | N4 | 1440h | 1440h |  | 1616 |  | TSG |  |  |  |  |  |
| 1799 | 54.1.5 | **Bearer control between MSC server and MGW** |  | 250d | 2000-09-01 A | 2001-08-16 A |  | 100% |  | 2000-09-01 | 2001-08-16 | 250d |  |  |  | N4 | 4512h | 4512h |  | 1327 |  | TSG |  |  |  | CCaR |  |
| 1800 | 54.1.5.1 | stage 3 - protocol issues |  | 250d | 2000-09-01 A | 2001-08-16 A |  | 100% |  | 2000-09-01 | 2001-08-16 | 250d |  |  | finish no earlier than 2001-08-16 | N4 | 2000h | 2000h |  | 1328 |  | TSG |  |  |  | CCaR |  |
| 1801 | 54.1.5.2 | stage 3 - parameter value issues |  | 64d | 2001-01-02 A | 2001-03-30 A |  | 100% |  | 2001-01-02 | 2001-03-30 | 64d |  |  | finish no earlier than 2001-03-30 | N3 | 512h | 512h |  | 1329 |  |  |  |  |  | CCaR |  |
| 1802 | 54.2 | Lawful interception |  | 155d | 2000-08-21 A | 2001-03-23 A |  | 100% |  | 2000-08-21 | 2001-03-23 | 155d |  |  | finish no earlier than 2001-03-23 | S3 | 1240h | 1240h |  | 1331 |  |  |  |  |  | CCaR |  |
| 1803 | 54.3 | Start Testing | milestone | 0d | 2001-03-05 | 2001-03-05 |  |  |  | 2001-03-05 | 2001-03-05 | 0d | 2040d | 0d | start no earlier than 2001-03-05 | MLST |  |  |  | 1918 |  |  |  |  |  |  |  |
| 1804 | 54.4 | Conformance Test Aspects - Enable bearer independent CS architecture |  | 260d | 2001-03-05 | 2002-03-01 | 1803 |  |  | 2001-03-05 | 2002-03-01 | 260d | 2040d |  |  | T1 | 2080h |  |  |  | 0% |  | CSSPLIT-TEST |  |  |  |  |
| 1805 | 55 | **MExE enhancements Rel-4** |  | 510d | 2000-01-03 A | 2001-12-14 A |  | 100% |  | 2000-01-03 | 2001-12-14 | 510d |  |  |  | T2 | 19024h | 19024h | Friedhelm | 1445 |  | TSG | MEXE |  | Rel-4 | Ter |  |
| 1806 | 55.1 | **MExE Security Analysis Activity** |  | 474d | 2000-02-22 A | 2001-12-14 A |  | 100% |  | 2000-02-22 | 2001-12-14 | 474d |  |  |  | S3 | 8464h | 8464h |  | 1447 |  | TSG | MEXE-SEC | Colin Blanchard, BT |  | Ter | colin.blanchard@bt.com |
| 1807 | 55.1.1 | Stage 3 |  | 370d | 2000-07-17 A | 2001-12-14 A |  | 100% |  | 2000-07-17 | 2001-12-14 | 370d |  |  | finish no earlier than 2001-12-14 | S3 | 2960h | 2960h |  | 2045 |  |  | MEXE1-SEC |  |  | Ter |  |
| 1808 | 55.1.2 | Terminal aspects |  | 214d | 2000-02-22 A | 2000-12-15 A |  | 100% |  | 2000-02-22 | 2000-12-15 | 214d |  |  | finish no earlier than 2000-12-15 | T2 | 1712h | 1712h |  | 1448 |  |  |  |  |  | Ter |  |
| 1809 | 55.2 | **MExE Rel4 Improvements and Investigations** |  | 250d | 2000-01-03 A | 2000-12-15 A |  | 100% |  | 2000-01-03 | 2000-12-15 | 250d |  |  |  | T2 | 6480h | 6480h |  | 1810 | 22.057, 23.057 | TSG | MEXE-ENHANC | Mark CATALDO, Motorola |  | Ter | mcatald1@MOTOROLA.COM |
| 1810 | 55.2.1 | 3rd MExE classmark |  | 250d | 2000-01-03 A | 2000-12-15 A |  | 100% |  | 2000-01-03 | 2000-12-15 | 250d |  |  | finish no earlier than 2000-12-15 | T2 | 2000h | 2000h |  | 1812 | 22.057, 23.057 | TSG |  | Mark CATALDO, Motorola |  | Ter | mcatald1@MOTOROLA.COM |
| 1811 | 55.2.2 | FS on Secure download mechanism and capabilities to support SDR concepts |  | 225d | 2000-02-07 A | 2000-12-15 A |  | 100% |  | 2000-02-07 | 2000-12-15 | 225d |  |  | finish no earlier than 2000-12-15 | T2 | 1800h | 1800h |  | 1814 | 22.057, 23.057 | TSG |  | Mark CATALDO, Motorola |  | Ter | mcatald1@MOTOROLA.COM |
| 1812 | 55.2.3 | FS on Support of MP3/MPEG4 content |  | 225d | 2000-02-07 A | 2000-12-15 A |  | 100% |  | 2000-02-07 | 2000-12-15 | 225d |  |  | finish no earlier than 2000-12-15 | T2 | 1800h | 1800h |  | 1815 | 22.057, 23.057 | TSG |  | Mark CATALDO, Motorola |  | Ter | mcatald1@MOTOROLA.COM |

Notes:
- 1790: duration set to 6 months (was 0)
- 1792: duration set to 6 months (was 0), finish date set
- 1794: DAB 12.12.01 should be 100% hence closed
- 1795: R00 stage 2 at least 80 % complete in TSGS #8 21.-23.6.2000
- 1802: Requirements capture: S3#14 (Aug 00), Feature specification: S3#15 (Sep 00), Definition of architecture. Should be included in general LI work mentioned above.
- 1806: Presentation to S3 of threats and countermeasures analysis: S3#15, Feature specification: S3#16. S3#18: WID updated
- 1807: Analysis undertaken by T2. No additional analysis needed for Rel-4
- 1810: Additional features for MExE R2000

| ID | WBS | Task | Duration | Start | Finish | Complete | Remaining | Baseline start | Baseline finish | Baseline duration | Total slack | Constraint | Resources | Work | Actual work | Text1 | Text2 | Text6 | Text8 | Text9 | Text3 | Text5 | Text7 |
| --- | --- | --- | --- | --- | --- | --- | --- | --- | --- | --- | --- | --- | --- | --- | --- | --- | --- | --- | --- | --- | --- | --- | --- |
| 1813 | 56 | **Tandem Free aspects for 3G and between 2G and 3G systems** | 344d | 2000-02-22 A | 2001-06-15 A | 100% |  | 2000-02-22 | 2001-06-15 | 344d |  |  | S4 | 9696h | 9696h | TFO | Cod | Rel-4 | Paolo | 1631 |  |  |  |
| 1814 | 56.1 | **Tandem Free AMR** | 344d | 2000-02-22 A | 2001-06-15 A | 100% |  | 2000-02-22 | 2001-06-15 | 344d |  |  | S4 | 6944h | 6944h | TFO-AMR | Cod |  |  | 1632 |  |  |  |
| 1815 | 56.1.1 | Specification | 284d | 2000-02-22 A | 2001-03-23 A | 100% |  | 2000-02-22 | 2001-03-23 | 284d |  | start no earlier than 2000-02-22 | S4 | 2272h | 2272h |  | Cod |  |  | 130 | 28.062 |  |  |
| 1816 | 56.1.2 | **Impact on:** | 115d | 2001-01-08 A | 2001-06-15 A | 100% |  | 2001-01-08 | 2001-06-15 | 115d |  |  | NP | 1920h | 1920h |  | Cod |  |  | 907 |  |  |  |
| 1817 | 56.1.2.1 | CN | 60d | 2001-03-26 A | 2001-06-15 A | 100% |  | 2001-03-26 | 2001-06-15 | 60d |  | finish no earlier than 2001-06-15 | NP | 480h | 480h |  | Cod |  |  | 131 |  |  |  |
| 1818 | 56.1.2.2 | GERAN | 65d | 2001-01-08 A | 2001-04-06 A | 100% |  | 2001-01-08 | 2001-04-06 | 65d |  | finish no earlier than 2001-04-06 | GP | 520h | 520h |  | Cod |  |  | 132 |  |  |  |
| 1819 | 57 | **Advanced Speech Call Items enhancements_REL-4** | 334d | 2000-12-03 A | 2002-03-14 A | 100% |  | 2000-12-03 | 2002-03-14 | 334d |  |  | N1 | 5925.6h | 5925.6h | ASCI |  | Rel-4 | Per | 2230 |  | sonia.garapaty@nortelnetworks.com | TSG |
| 1820 | 57.1 | Stage 2 | 326.7d | 2000-12-03 A | 2002-03-14 A | 100% |  | 2000-12-03 | 2002-03-14 | 326.7d |  | finish no earlier than 2002-03-14 | N4 | 2613.6h | 2613.6h |  |  |  | Kimmo | 2232 | 23.067, 24.067 |  | WG |
| 1821 | 57.2 | Stages 2 and 3 on A interface | 80d | 2000-12-03 A | 2001-03-23 A | 100% |  | 2000-12-03 | 2001-03-23 | 80d |  | finish no earlier than 2001-03-23 | N1 | 640h | 640h |  |  |  | Per | 2231 | 44.068, 44.069, 24.008 | sonia.garapaty@nortelnetworks.com | WG |
| 1822 | 58 | **700 MHz spectrum support** | 775d | 2000-01-03 A | 2002-12-20 A | 100% |  | 2000-01-03 | 2002-12-20 | 775d |  |  | GP | 25000h | 25000h | 700SS |  | Rel-4 | Paolo | 2403 |  |  |  |
| 1823 | 58.1 | **GERAN support for the 700 MHz band** | 275d | 2000-01-03 A | 2001-01-19 A | 100% |  | 2000-01-03 | 2001-01-19 | 275d |  |  | GP | 8800h | 8800h |  |  |  |  | 2404 |  |  |  |
| 1824 | 58.1.1 | Signalling support | 275d | 2000-01-03 A | 2001-01-19 A | 100% |  | 2000-01-03 | 2001-01-19 | 275d |  | finish no earlier than 2001-01-19 | GP | 2200h | 2200h |  |  |  |  | 2405 |  |  |  |
| 1825 | 58.1.2 | Physical layer definitions | 275d | 2000-01-03 A | 2001-01-19 A | 100% |  | 2000-01-03 | 2001-01-19 | 275d |  | finish no earlier than 2001-01-19 | GP | 2200h | 2200h |  |  |  |  | 2406 |  |  |  |
| 1826 | 58.1.3 | Receiver performance and RF budget | 275d | 2000-01-03 A | 2001-01-19 A | 100% |  | 2000-01-03 | 2001-01-19 | 275d |  | finish no earlier than 2001-01-19 | GP | 2200h | 2200h |  |  |  |  | 2407 |  |  |  |
| 1827 | 58.2 | **GERAN MS Conformance test for 700 MHz band** | 175d | 2001-04-02 A | 2001-11-30 A | 100% |  | 2001-04-02 | 2001-11-30 | 175d |  |  | GP | 2800h | 2800h |  |  |  |  | 2408 |  |  |  |
| 1828 | 58.2.1 | MS test | 175d | 2001-04-02 A | 2001-11-30 A | 100% |  | 2001-04-02 | 2001-11-30 | 175d |  | finish no earlier than 2001-11-30 | GP | 1400h | 1400h |  |  |  |  | 2409 |  |  |  |
| 1829 | 58.3 | **GERAN BTS Conformance test for 700 MHz band** | 450d | 2001-04-02 A | 2002-12-20 A | 100% |  | 2001-04-02 | 2002-12-20 | 450d |  |  | GP | 7200h | 7200h |  |  |  | Paolo | 2410 |  |  |  |
| 1830 | 58.3.1 | BTS test | 450d | 2001-04-02 A | 2002-12-20 A | 100% |  | 2001-04-02 | 2002-12-20 | 450d |  | finish no earlier than 2002-12-20 | GP | 3600h | 3600h |  |  |  |  | 2411 |  |  |  |
| 1831 | 59 | Operator Determined Barring for Packet Oriented Services | 208d | 2000-06-01 A | 2001-03-19 A | 100% |  | 2000-06-01 | 2001-03-19 | 208d |  | finish no earlier than 2001-03-19 | NP | 1664h | 1664h | ODB |  | Rel-4 |  | 2463 |  | tamurato@nsf.ncos.nec.co.jp | TSG |
| 1832 | 60 | **UMTS QoS Architecture for PS Domain** | 758d | 2000-01-03 A | 2002-11-27 | 61% | 295.18d | 2000-01-03 | 2002-11-27 | 758d | 1847d |  | S2 | 54256h | 20605.3h | QoSPS |  | Rel-4 |  |  |  | Ina.widegren@era.ericsson.se | TSG |
| 1833 | 60.1 | Architecture | 153d | 2000-06-05 A | 2001-01-03 A | 100% |  | 2000-06-05 | 2001-01-03 | 153d |  | finish no earlier than 2001-01-03 | S2 | 1224h | 1224h |  |  |  |  |  | 23.107 |  | TSG |
| 1834 | 60.2 | Charging and OAM&P for QoS Management | 201d | 2001-09-21 A | 2002-06-28 A | 100% |  | 2001-09-21 | 2002-06-28 | 201d |  | finish no earlier than 2002-06-28 | S5 | 1608h | 1608h | QoSPS-OAM |  |  |  |  | 32-series | Albert.Yuhan@voicestream.com; Michael.Truss@MOTOROLA.COM | TSG |
| 1835 | 60.3 | **RAB Quality of Service (re)Negotiation over Iu** | 155d | 2000-08-21 A | 2001-03-23 | 99% | 0d | 2000-08-21 | 2001-03-23 | 155d | 0d |  | R3 | 3648h | 2501.6h | QoSPS-MAPEND-RABQoS |  |  |  | 1681 | 25.413 |  | TSG |
| 1836 | 60.3.1 | RAB Quality of Service Negotiation over Iu | 155d | 2000-08-21 A | 2001-03-23 A | 100% |  | 2000-08-21 | 2001-03-23 | 155d |  | finish no earlier than 2001-03-23 | R3 | 1240h | 1240h | QoSPS-MAPEND-RABQoS-Negot |  |  |  | 1991 |  |  | TSG |
| 1837 | 60.3.2 | RAB Quality of Service Negotiation over Iu during relocation | 16d | 2001-03-02 A | 2001-03-23 A | 100% |  | 2001-03-02 | 2001-03-23 | 16d |  | start no earlier than 2001-03-02 | R3 | 128h | 128h | QoSPS-MAPEND-RABQoS-NegotReloc |  |  |  | 2456 |  |  | TSG |
| 1838 | 60.3.3 | RAB Quality of Service Re-Negotiation over Iu | 130d | 2000-09-25 A | 2001-03-23 A | 100% |  | 2000-09-25 | 2001-03-23 | 130d |  | finish no earlier than 2001-03-23 | R3 | 1040h | 1040h | QoSPS-MAPEND-RABQoS-ReNegot |  |  |  | 1992 |  |  | TSG |

Notes:
- 1813: RAN and CN to verify no problems for GSM terminals roaming in 3G R99
- 1814: RAN and CN to verify UMTS_AMR_2 support
- 1816: "Implementation" changed to "Impact on:" by A. Sultan (for better wording)
- 1817: RAN and CN to verify UMTS_AMR_2 support
- 1818: End date Modified from June to March to have it in Rel4
- 1819: Approved in TSGN_10 / Text4: Sonia Garapaty
- 1820: CN4#11 30/11/02: no inputs received in CN4 / Text4: Vivien Perlic, Sagem
- 1821: Text4: Sonia Garapaty
- 1831: Completed WI missing from the P-plan Added for tracking / Text4: oshiyuki Tamura
- 1832: Text4: Ina Widegren, Ericsson
- 1834: Text4: Albert YUHAN (VoiceStream Wireless), Michael TRUSS (Motorola)
- 1835: Text4: A. Molander, Ericsson
- 1836: Text4: A. Molander, Ericsson
- 1838: Text4: S. Irwin, Motorola

| ID | WBS | Task | Duration | Start | Finish | Complete | Remaining | Baseline start | Baseline finish | Baseline duration | Total slack | Constraint | Resources | Work | Actual work | Text1 | Text2 | Text7 | Text8 | Text9 | Text4 | Text3 | Text6 |
| --- | --- | --- | --- | --- | --- | --- | --- | --- | --- | --- | --- | --- | --- | --- | --- | --- | --- | --- | --- | --- | --- | --- | --- |
| 1839 | 60.4 | **GERAN QoS Aspects - Handovers: maintenance of real-time QoS while moving between cells in the PLMN including inter-SGSN and SRNS relocation or possibly other mechanisms** | 500d | 2000-01-03 A | 2001-11-30 | 99% | 0d | 2000-01-03 | 2001-11-30 | 500d | 0d |  | GP | 14440h | 10544h | GERQoS | QoS | TSG | Paolo | 1553 |  |  |  |
| 1840 | 60.4.1 | **Handover Concept for the PS domain** | 500d | 2000-01-03 A | 2001-11-30 | 99% | 0d | 2000-01-03 | 2001-11-30 | 500d | 0d |  | GP | 10440h | 6544h |  |  | TSG |  | 2306 |  |  |  |
| 1841 | 60.4.1.1 | Stable RT handover report 25.936 including header removal | 13d | 2000-01-03 A | 2000-01-19 A | 100% |  | 2000-01-03 | 2000-01-19 | 13d |  | start no earlier than 2000-01-03 | GP | 104h | 104h |  |  | TSG |  | 2309 |  |  |  |
| 1842 | 60.4.1.2 | Update of stage 2 | 292d | 2000-01-03 A | 2001-02-13 A | 100% |  | 2000-01-03 | 2001-02-13 | 292d |  | finish no earlier than 2001-02-13 | GP | 2336h | 2336h |  |  | TSG |  | 2307 |  |  |  |
| 1843 | 60.4.1.3 | Update of relevant stage 3 specs -> RRC | 500d | 2000-01-03 A | 2001-11-30 A | 100% |  | 2000-01-03 | 2001-11-30 | 500d |  | finish no earlier than 2001-11-30 | G2 | 4000h | 4000h |  |  | TSG |  | 2308 |  |  |  |
| 1844 | 60.5 | **GERAN MS Conformance test for inter-system and intra-system Packet data real-time Handover** | 324d | 2001-08-31 | 2002-11-27 |  |  | 2001-08-31 | 2002-11-27 | 324d | 1847d |  | G4; R3 | 25920h |  | GERQoS-Mstest |  | TSG |  |  |  |  |  |
| 1845 | 60.5.1 | **Handover for the PS domain** | 324d | 2001-08-31 | 2002-11-27 |  |  | 2001-08-31 | 2002-11-27 | 324d | 1847d |  | G4; R3 | 20736h |  |  |  | TSG |  |  |  |  |  |
| 1846 | 60.5.1.1 | Stable RT handover report 25.936 including header removal | 324d | 2001-08-31 | 2002-11-27 |  |  | 2001-08-31 | 2002-11-27 | 324d | 1847d | finish no earlier than 2002-11-27 | G4; R3 | 5184h |  |  |  | TSG |  |  |  |  |  |
| 1847 | 60.5.1.2 | Update of stage 2 | 324d | 2001-08-31 | 2002-11-27 |  |  | 2001-08-31 | 2002-11-27 | 324d | 1847d | finish no earlier than 2002-11-27 | G4; R3 | 5184h |  |  |  | TSG |  |  |  |  |  |
| 1848 | 60.5.1.3 | Update of relevant stage 3 specs | 324d | 2001-08-31 | 2002-11-27 |  |  | 2001-08-31 | 2002-11-27 | 324d | 1847d | finish no earlier than 2002-11-27 | G4; R3 | 5184h |  |  |  | TSG |  |  |  |  |  |
| 1849 | 60.6 | PS-domain handover for real-time services | 155d | 2000-08-28 A | 2001-03-30 A | 100% |  | 2000-08-28 | 2001-03-30 | 155d |  | finish no earlier than 2001-03-30 | R3 | 1240h | 1240h | QoSPS-PSdoRTS | QoS | TSG |  | 1685 | A. Lansisalmi, Nokia |  |  |
| 1850 | 60.7 | RAB QoS Renegotiation at Relocation | 58d | 2001-01-03 | 2001-03-23 |  |  | 2001-01-03 | 2001-03-23 | 58d | 2285d | finish no earlier than 2001-03-23 | R3 | 464h |  |  |  | TSG |  |  |  | 25.851, 25.946 |  |
| 1851 | 61 | **small Technical Enhancements and Improvements for Rel4** | 2177d? | 2000-01-03 A | 2008-05-06 | 99% | 0d? | 2000-01-03 | 2008-05-06 | 2177d? | 0d |  | Generic | 21440h | 6624h | TEI4 |  | TSG |  | 1993 |  |  | Rel-4 |
| 1852 | 412.1 | Small Technical Enhancements and Improvements for Rel-4 Conformance Testing | 503d? | 2000-01-03 A | 2008-05-06 A | 100% |  | 2000-01-03 | 2008-05-06 | 503d? |  | finish no earlier than 2008-12-31 | R5 | 4024h | 4024h | TEI4_Test |  |  | Stoyan Baev |  |  |  | Rel-4 |
| 1853 | 62 | **Rel-4 Evolutions of the transport in the UTRAN** | 525d | 2000-08-21 A | 2002-08-23 | 69% | 162.5d | 2000-08-21 | 2002-08-23 | 525d | 1915d |  | RP | 8600.02h | 6501.38h | ETRAN |  | TSG | Joern |  | Francois Courau |  | NA |
| 1854 | 62.1 | QoS optimisation for AAL2 connections over Iub and Iur interfaces | 160d | 2000-08-21 A | 2001-03-30 A | 100% |  | 2000-08-21 | 2001-03-30 | 160d |  | finish no earlier than 2001-03-30 | R3 | 1280h | 1280h | ETRAN-QoSAAL2 | BaAS | TSG |  | 12 | T. Yoshimura, Japan Telecom |  | Rel-4 |
| 1855 | 62.2 | Transport bearer modification procedure on Iub, Iur, and Iu | 130d | 2000-10-02 A | 2001-03-30 A | 100% |  | 2000-10-02 | 2001-03-30 | 130d |  | finish no earlier than 2001-03-30 | R3 | 1040h | 1040h | ETRAN-MigrMod |  | TSG |  | 1995 | T. Yoshimura, Japan Telecom |  | Rel-4 |
| 1856 | 62.3 | **Conformance Test Aspects of Rel-4 evolutions of the transport in UTRAN** | 130d | 2002-02-25 | 2002-08-23 |  |  | 2002-02-25 | 2002-08-23 | 130d | 1915d |  | T1 | 2080h |  |  |  |  |  | 1834 |  |  |  |
| 1857 | 62.3.1 | Testing RAB support enhancements | 130d | 2002-02-25 | 2002-08-23 |  |  | 2002-02-25 | 2002-08-23 | 130d | 1915d | finish no earlier than 2002-08-23 | T1 | 1040h |  | CT-RABS? |  |  |  | 2208 |  | 34.108, 34. 121, 34.122, 34.123 pts 1,2, 34.123 pt 3 |  |
| 1858 | 63 | **Rel-4 Evolutions of the transport in the CN** | 215d | 2000-05-29 A | 2001-03-23 A | 100% |  | 2000-05-29 | 2001-03-23 | 215d |  |  | N4 | 7968h | 7968h | CNTRSP | BaAS |  | Kimmo |  |  |  | NA |
| 1859 | 63.1 | **IP Transport of CN protocols (e.g., CAP, MAP)** | 77d | 2000-12-07 A | 2001-03-23 A | 100% |  | 2000-12-07 | 2001-03-23 | 77d |  |  | N4 | 2808h | 2808h | SS7IP | BaAS |  |  | 859 |  |  | Rel-4 |
| 1860 | 63.1.1 | **Stage 3** | 77d | 2000-12-07 A | 2001-03-23 A | 100% |  | 2000-12-07 | 2001-03-23 | 77d |  |  | N4 | 2192h | 2192h |  |  |  |  | 1679 |  |  |  |
| 1861 | 63.1.1.1 | CAP | 77d | 2000-12-07 A | 2001-03-23 A | 100% |  | 2000-12-07 | 2001-03-23 | 77d |  | finish no earlier than 2001-03-23 | N2 | 616h | 616h |  |  | WG |  | 2018 |  |  |  |
| 1862 | 63.1.1.2 | MAP | 77d | 2000-12-07 A | 2001-03-23 A | 100% |  | 2000-12-07 | 2001-03-23 | 77d |  | finish no earlier than 2001-03-23 | N4 | 616h | 616h |  |  |  |  | 2019 |  |  |  |
| 1863 | 63.1.1.3 | BSSAP+ | 43d | 2001-01-15 A | 2001-03-14 A | 100% |  | 2001-01-15 | 2001-03-14 | 43d |  | finish no earlier than 2001-03-14 | N1 | 344h | 344h | SS7IP-BSSAP+ | Loc | WG |  | 2253 |  |  |  |

Notes:
- 1844: Still exist? To be clarified by GERAN4/5
- 1851: "Joker" WI, to be used for a Rel 4 CR not related to any feature and with very limited impact on the system
- 1852: "Joker" WI, to be used for small modifications applicable to Rel 4 conformance testing. Moved in from the Stoyan/Testing WP
- 1857: Requires supporting companies
- 1858: WI formulation assigned to N4
- 1859: AS: corrected to Rel4 as stated at SA#10

| ID | WBS | Task | Type | Duration | Start | Finish | Predecessors | Complete | Remaining | Baseline start | Baseline finish | Baseline duration | Total slack | Free slack | Constraint | Resources | Work | Actual work | Text2 | Text4 | Text5 | Text6 | Text7 | Text9 | Text1 | Text8 | Text3 |
| --- | --- | --- | --- | --- | --- | --- | --- | --- | --- | --- | --- | --- | --- | --- | --- | --- | --- | --- | --- | --- | --- | --- | --- | --- | --- | --- | --- |
| 1864 | 63.2 | **FS on Transport and control separation in the PS CN domain** |  | 215d | 2000-05-29 A | 2001-03-23 A |  | 100% |  | 2000-05-29 | 2001-03-23 | 215d |  |  |  | S2 | 3440h | 3440h | BaAS | Juan-Antonio Ibanez, Ericsson Deutschland | Juan-Antonio.Ibanez@eed.ericsson.se | Rel-4 | TSG | 1513 |  |  |  |
| 1865 | 63.2.1 | Architectural impacts |  | 215d | 2000-05-29 A | 2001-03-23 A |  | 100% |  | 2000-05-29 | 2001-03-23 | 215d |  |  | finish no earlier than 2001-03-23 | S2 | 1720h | 1720h | BaAS |  |  |  | WG | 1615 |  |  |  |
| 1866 | 64 | **Rel-4 Improvements of Radio Interface** |  | 700d | 2000-07-10 A | 2003-03-14 |  | 83% | 117.46d | 2000-07-10 | 2003-03-14 | 700d | 1770d |  |  | RP | 28624h | 23247.4h |  |  |  | NA | TSG |  | RInImp | Tsukasa |  |
| 1867 | 64.1 | UTRA repeater specification (master) |  | 183d | 2000-07-10 A | 2001-03-21 A |  | 100% |  | 2000-07-10 | 2001-03-21 | 183d |  |  | finish no earlier than 2001-03-21 | R4 | 1464h | 1464h |  | T. Kummetz, Mikom; Alf Ahlström, Allgon |  | Rel-4 | TSG | 1509 | RInImp-REP |  |  |
| 1868 | 64.2 | DSCH power control improvement in soft handover |  | 140d | 2000-09-11 A | 2001-03-23 A |  | 100% |  | 2000-09-11 | 2001-03-23 | 140d |  |  | finish no earlier than 2001-03-23 | R1 | 1120h | 1120h |  | A. Toskala, Nokia |  | Rel-4 | TSG | 1994 | RInImp-DSCHsho |  |  |
| 1869 | 64.3 | UMTS 1800 |  | 320d | 2000-09-25 A | 2001-12-14 A |  | 100% |  | 2000-09-25 | 2001-12-14 | 320d |  |  | finish no earlier than 2001-12-14 | R4 | 2560h | 2560h |  | H. Benn, Motorola |  | Rel indep | TSG | 1996 | RInImp-UMTS18 |  |  |
| 1870 | 64.4 | UMTS 1900 |  | 195d | 2001-03-19 A | 2001-12-14 A |  | 100% |  | 2001-03-19 | 2001-12-14 | 195d |  |  | finish no earlier than 2001-12-14 | R4 | 1560h | 1560h |  | Howard Benn, Motorola |  | Rel indep | TSG | 2467 | RInImp-UMTS19 | Cesar |  |
| 1871 | 64.5 | FS on High Speed downlink packet access |  | 155d | 2000-08-21 A | 2001-03-23 A |  | 100% |  | 2000-08-21 | 2001-03-23 | 155d |  |  | finish no earlier than 2001-03-23 | R2 | 1240h | 1240h |  | A. Ghosh, Motorola |  |  | TSG | 1219 | RInImp-HSDPA |  |  |
| 1872 | 64.6 | FS on improved common DL channel for Cell-FACH state |  | 340d | 2000-09-11 A | 2001-12-28 A |  | 100% |  | 2000-09-11 | 2001-12-28 | 340d |  |  | finish no earlier than 2001-12-28 | R2 | 2720h | 2720h |  | J. Kwak, GBT |  |  | TSG | 1510 | RInImp-DLCFACH |  |  |
| 1873 | 64.7 | **Conformance Test Spec. Rel-4 improvements in Radio Interface** |  | 375d | 2001-10-08 A | 2003-03-14 |  | 64% | 134.62d | 2001-10-08 | 2003-03-14 | 375d | 1770d |  |  | T1 | 12360h | 7923.08h |  |  |  |  |  |  |  |  |  |
| 1874 | 64.7.1 | Testing Improved usage of downlink resource in FDD for CCTrCHs of dedicated type |  | 140d | 2002-02-18 | 2002-08-30 |  |  |  | 2002-02-18 | 2002-08-30 | 140d | 1910d |  | finish no earlier than 2002-08-30 | T1 | 1120h |  |  |  |  |  |  | 2212 |  |  |  |
| 1875 | 64.7.2 | Testing Terminal Power saving features |  | 140d | 2002-02-18 | 2002-08-30 |  |  |  | 2002-02-18 | 2002-08-30 | 140d | 1910d |  | finish no earlier than 2002-08-30 | T1 | 1120h |  |  |  |  |  |  | 2213 |  |  |  |
| 1876 | 64.7.3 | Testing DSCH power control improvement in soft handover |  | 140d | 2002-02-18 | 2002-08-30 |  |  |  | 2002-02-18 | 2002-08-30 | 140d | 1910d |  | finish no earlier than 2002-08-30 | T1 | 1120h |  |  |  |  | Rel-4 |  | 2214 |  |  |  |
| 1877 | 64.7.4 | Testing UMTS 1800 |  | 180d | 2001-10-08 A | 2002-06-14 A |  | 100% |  | 2001-10-08 | 2002-06-14 | 180d |  |  | finish no earlier than 2002-06-14 | T1 | 1440h | 1440h |  |  |  | Rel indep | TSG | 2215 |  |  | 34.108, 34,121, 34.122, 34.123-1 |
| 1878 | 64.7.5 | Testing UMTS 1900 |  | 180d | 2001-10-08 A | 2002-06-14 A |  | 100% |  | 2001-10-08 | 2002-06-14 | 180d |  |  | finish no earlier than 2002-06-14 | T1 | 1440h | 1440h |  |  |  | Rel indep | TSG | 2215 |  |  | 34.108, 34,121, 34.122, 34.123-1 |
| 1879 | 64.7.6 | Testing UMTS 1800 - TTCN |  | 195d | 2002-06-17 A | 2003-03-14 A |  | 100% |  | 2002-06-17 | 2003-03-14 | 195d |  |  | finish no earlier than 2003-03-14 | T1 | 1560h | 1560h |  |  |  | Rel indep | TSG |  |  |  | 34.123-3 |
| 1880 | 64.7.7 | Testing UMTS 1900 - TTCN |  | 195d | 2002-06-17 A | 2003-03-14 A |  | 100% |  | 2002-06-17 | 2003-03-14 | 195d |  |  | finish no earlier than 2003-03-14 | T1 | 1560h | 1560h |  |  |  | Rel indep | TSG |  |  |  | 34.123-3 |
| 1881 | 65 | **Rel-4 RAN improvements** |  | 938d? | 2000-08-14 A | 2004-03-17 |  | 17% | 783.05d? | 2000-08-14 | 2004-03-17 | 938d? | 1507d |  |  | RP | 29336h | 4185.38h |  |  |  | NA | TSG |  | RANimp | Cesar |  |
| 1882 | 65.1 | Node B synchronisation for TDD |  | 160d | 2000-08-14 A | 2001-03-23 A |  | 100% |  | 2000-08-14 | 2001-03-23 | 160d |  |  | finish no earlier than 2001-03-23 | R1 | 1280h | 1280h | BaAS | S. Oestreich, Siemens |  | Rel-4 | TSG | 655 | RANimp-NBsync |  |  |
| 1883 | 65.2 | RAB support enhancement for Rel-4 |  | 155d | 2000-08-21 A | 2001-03-23 A |  | 100% |  | 2000-08-21 | 2001-03-23 | 155d |  |  | finish no earlier than 2001-03-23 | R2 | 1240h | 1240h |  | M. Israelsson, A. Krishnarajah, Ericsson |  | Rel-4 | TSG | 2206 | RANimp-RABSE |  |  |
| 1884 | 65.3 | Start Testing | milestone | 0d | 2001-12-03 | 2001-12-03 |  |  |  | 2001-12-03 | 2001-12-03 | 0d | 207d | 21d | start no earlier than 2001-12-03 | MLST |  |  |  |  |  |  |  | 1912 |  |  |  |
| 1885 | 65.4 | **Conformance Test Aspects - Rel-4 RAN Improvements** |  | 577d? | 2002-01-01 A | 2004-03-17 | 1884 | 2% | 564.28d? | 2002-01-01 | 2004-03-17 | 577d? | 1507d |  |  | T1 | 19312h | 425.77h |  |  |  |  |  | 2102 |  |  | 0% |
| 1886 | 65.4.1 | Testing Radio access bearer support enhancments |  | 175d | 2002-01-01 | 2002-09-02 |  |  |  | 2002-01-01 | 2002-09-02 | 175d | 1909d |  | finish no earlier than 2002-09-02 | T1 | 1400h |  |  |  |  |  |  | 2222 |  |  |  |
| 1887 | 65.4.2 | Testing RAB support enhancements-Robust Header Compression |  | 332d | 2002-05-28 | 2003-09-03 |  |  |  | 2002-05-28 | 2003-09-03 | 332d | 1647d |  | finish no earlier than 2003-09-03 | T1 | 2656h |  |  |  |  | Rel-4 | TSG | 2461 | RABimp-RoCH |  | 34.123-1, -2 |
| 1888 | 65.4.3 | Testing RAB support enhancements-Robust Header Compression - TTCN |  | 472d | 2002-05-28 | 2004-03-17 |  |  |  | 2002-05-28 | 2004-03-17 | 472d | 1507d |  | finish no earlier than 2004-03-17 | T1 | 3776h |  |  |  |  | Rel-4 | TSG |  |  |  | 34.123-3 |
| 1889 | 65.4.4 | Testing of Extended Robut Header Compression |  | 270d | 2002-09-18 A | 2003-09-30 |  | 15% | 229.5d | 2002-09-18 | 2003-09-30 | 270d | 1628d |  | finish no earlier than 2003-09-30 | T1 | 2160h | 324h |  |  |  | Rel-4 | TSG |  | Ext-RoHC |  | 34.123-1, -2 |
| 1890 | 65.4.5 | Testing of Extended Robut Header Compression - TTCN |  | 325d | 2002-09-18 | 2003-12-16 |  |  |  | 2002-09-18 | 2003-12-16 | 325d | 1573d |  | finish no earlier than 2003-12-16 | T1 | 2600h |  |  |  |  | Rel-4 | TSG |  |  |  | 34.123-3 |
| 1891 | 416.4.6 | General changes to TS34.121 corresponding to release 4 |  | 263d? | 2003-03-03 | 2004-03-03 |  |  |  | 2003-03-03 | 2004-03-03 | 263d? | 1517d |  | finish no earlier than 2004-03-03 | T1 | 2104h |  |  |  |  | Rel-4 | TSG |  | RANimp-test |  | 34.108, 34.121 |

Notes:
- 1864: Rel4 added
- 1872: Stopped at RAN#14
- 1874: start/finish dates set / Not started yet due to lack of supporting companies
- 1875: start/finish dates set / Not started yet due to lack of supporting companies
- 1876: start/finish dates set / Not started yet due to lack of supporting companies
- 1877: finish date set
- 1878: finish date set
- 1879: finish date set
- 1880: finish date set
- 1883: 29 Nov 2000: split into ROHC and non-ROHC part; 5 Mar 2001: splitting off of ROHC for Rel-4 agreed by R2
- 1884: UID changed
- 1886: duration set to 6 months (was 0) / Task not started due to lack of supporting companies
- 1887: UID changed
- 1888: UID changed

| ID | WBS | Task | Duration | Start | Finish | Complete | Remaining | Baseline start | Baseline finish | Baseline duration | Total slack | Constraint | Resources | Work | Actual work | Text1 | Text2 | Text4 | Text5 | Text6 | Text7 | Text8 | Text9 | Text3 |
| --- | --- | --- | --- | --- | --- | --- | --- | --- | --- | --- | --- | --- | --- | --- | --- | --- | --- | --- | --- | --- | --- | --- | --- | --- |
| 1892 | 66 | **Rel-4 Emergency call enhancements** | 627d | 2000-01-03 A | 2002-05-28 | 64% | 227.72d | 2000-01-03 | 2002-05-28 | 627d | 1978d |  | N1 | 7936h | 5161.18h | EMC1 | CCaR | Mr Rouzbeh, Ericsson | EUSFARO@am1.ericsson.se | NA | WG | Per | 1652 |  |
| 1893 | 66.1 | **For CS based calls** | 627d | 2000-01-03 A | 2002-05-28 | 64% | 227.72d | 2000-01-03 | 2002-05-28 | 627d | 1978d |  | N1 | 3600h | 2400h | EMC1-CS | CCaR | Mr Rouzbeh, Ericsson | EUSFARO@am1.ericsson.se | Rel-4 | TSG |  | 1654 |  |
| 1894 | 66.1.1 | Distinction in CS domain of emergency call types to different emergency services | 40d | 2000-05-01 A | 2000-06-23 A | 100% |  | 2000-05-01 | 2000-06-23 | 40d |  | finish no earlier than 2000-06-23 | S1 | 320h | 320h |  | CCaR |  |  | Rel-4 |  |  | 1320 |  |
| 1895 | 66.1.2 | Distinction in CS domain of emergency calls to different emergency types | 22d | 2000-08-28 A | 2000-09-26 A | 100% |  | 2000-08-28 | 2000-09-26 | 22d |  | finish no earlier than 2000-09-22 | N1 | 176h | 176h |  |  |  |  | Rel-4 |  |  | 1999 |  |
| 1896 | 66.1.3 | Conformance Test Aspects - Emergency call enhancements | 150d | 2000-01-03 | 2000-07-28 |  |  | 2000-01-03 | 2000-07-28 | 150d | 2455d |  | T1 | 1200h |  |  |  |  |  |  |  |  | 2224 |  |
| 1897 | 66.1.4 | Testing CS based emergency calls | 67d | 2002-02-25 A | 2002-05-28 A | 100% |  | 2002-02-25 | 2002-05-28 | 67d |  | finish no earlier than 2002-05-28 | T1 | 536h | 536h |  |  |  |  |  | TSG |  | 2226 | 34.123-1 |
| 1898 | 66.1.5 | Testing CS based emergency calls - TTCN | 134d | 2001-11-22 A | 2002-05-28 A | 100% |  | 2001-11-22 | 2002-05-28 | 134d |  | finish no earlier than 2002-05-28 | T1 | 1072h | 1072h |  |  |  |  |  | TSG |  |  | 34.123-3 |
| 1899 | 67 | **Rel-4 Terminal interfaces** | 314d | 2000-01-03 A | 2001-03-15 | 99% | 0d | 2000-01-03 | 2001-03-15 | 314d | 0d |  | T2 | 14272h | 12892.4h | TI | Ter |  |  | NA |  | Friedhelm | 1826 |  |
| 1900 | 67.1 | **AT commands enhancements** | 313d | 2000-01-03 A | 2001-03-14 A | 100% |  | 2000-01-03 | 2001-03-14 | 313d |  |  | T2 | 5008h | 5008h | TI-ATC | Ter |  |  | Rel-4 |  |  | 1827 | 27.007 |
| 1901 | 67.1.1 | Specification of AT commands for new services | 313d | 2000-01-03 A | 2001-03-14 A | 100% |  | 2000-01-03 | 2001-03-14 | 313d |  | finish no earlier than 2001-03-14 | T2 | 2504h | 2504h |  | Ter |  |  |  |  |  | 1828 | 27.007 |
| 1902 | 67.2 | **Wide Area Data Synchronisation** | 313d | 2000-01-03 A | 2001-03-14 | 99% | 0d | 2000-01-03 | 2001-03-14 | 313d | 0d |  | T2 | 5008h | 4360.8h | TI-WADS | Ter |  |  | NA |  |  | 1829 |  |
| 1903 | 67.2.1 | Continues evolution of Synchronisation protocol | 313d | 2000-01-03 A | 2001-03-14 A | 100% |  | 2000-01-03 | 2001-03-14 | 313d |  | finish no earlier than 2001-03-14 | T2 | 2504h | 2504h | TI-SYNC-EVOL | Ter |  |  | Rel-4 |  |  | 1830 | 27.903, 27.103 |
| 1904 | 67.3 | Terminal local model | 218d | 2000-05-16 A | 2001-03-15 A | 100% |  | 2000-05-16 | 2001-03-15 | 218d |  | finish no earlier than 2001-03-15 | T2 | 1744h | 1744h | TLM | Ter | Olga Tomé, Ericsson | Olga.Tome@ECS.ERICSSON.SE | Rel-4 | TSG |  | 1832 | 23.227 |
| 1905 | 68 | **Rel-4 Location Services enhancements** | 455d | 2000-04-03 A | 2001-12-28 | 99% | 0d | 2000-04-03 | 2001-12-28 | 455d | 0d |  | S2 | 26799.2h | 25357.5h | LCS1 |  | Jan Kall, Nokia |  | NA | TSG | Alain | 1536 |  |
| 1906 | 68.1 | CBS interactions | 455d | 2000-04-03 A | 2001-12-28 A | 100% |  | 2000-04-03 | 2001-12-28 | 455d |  | finish no earlier than 2001-12-28 | T2 | 3640h | 3640h | LCS1-CBS | Loc |  |  | Rel-4 |  |  | 2229 | 23.041 |
| 1907 | 68.2 | LCS support in the CS domain | 180d | 2000-05-15 A | 2001-01-19 A | 100% |  | 2000-05-15 | 2001-01-19 | 180d |  | finish no earlier than 2001-01-19 | S2 | 1440h | 1440h | LCS1-CS | Loc |  |  | Rel-4 |  |  | 523 |  |
| 1908 | 68.3 | **LCS support in the PS domain** | 435d | 2000-05-01 A | 2001-12-28 | 99% | 0d | 2000-05-01 | 2001-12-28 | 435d | 0d |  | S2 | 13560h | 12955.2h | LCS1-PS |  |  |  | Rel-4 |  |  | 525 |  |
| 1909 | 68.3.1 | Stage 1 | 40d | 2000-07-03 A | 2000-08-25 A | 100% |  | 2000-07-03 | 2000-08-25 | 40d |  | start no earlier than 2000-07-03 | S1 | 320h | 320h |  | Loc | Randolph Wohlert, Pacific Bell Wireless | rwohlert@tri.sbc.com |  |  |  | 1642 | 22.071 |
| 1910 | 68.3.2 | Stage 2 | 190d | 2000-05-01 A | 2001-01-19 A | 100% |  | 2000-05-01 | 2001-01-19 | 190d |  | finish no earlier than 2001-01-19 | S2 | 1520h | 1520h |  |  |  |  |  |  |  | 1181 | 23.271 |
| 1911 | 68.3.3 | **Stage 3** | 355d | 2000-08-21 A | 2001-12-28 A | 100% |  | 2000-08-21 | 2001-12-28 | 355d |  |  | N1 | 8240h | 8240h |  | Loc |  |  |  |  |  | 1180 |  |
| 1912 | 68.3.3.1 | Layer 3 LCS signaling UE (MS) -SGSN (UMTS PS and and GSM-GPRS) | 355d | 2000-08-21 A | 2001-12-28 A | 100% |  | 2000-08-21 | 2001-12-28 | 355d |  | finish no earlier than 2001-12-28 | N1 | 2840h | 2840h |  | Loc | Janne Muhonen / Nokia |  |  |  |  | 526 |  |
| 1913 | 68.3.3.2 | MAP impacts of LCS | 160d | 2000-08-21 A | 2001-03-30 A | 100% |  | 2000-08-21 | 2001-03-30 | 160d |  | finish no earlier than 2001-03-30 | N4 | 1280h | 1280h |  | Loc |  |  |  |  |  | 2462 |  |
| 1914 | 68.3.3.3 | GTP signaling for LCS | 160d | 2000-08-21 A | 2001-03-30 A | 100% |  | 2000-08-21 | 2001-03-30 | 160d |  | finish no earlier than 2001-03-30 | N4 | 1280h | 1280h |  | Loc |  |  |  |  |  | 527 |  |
| 1915 | 68.4 | **UE positioning Rel-4** | 260d | 2000-04-03 A | 2001-03-30 A | 100% |  | 2000-04-03 | 2001-03-30 | 260d |  |  | RP | 4591.2h | 4591.2h | LCS1-UEpos |  |  |  | NA | TSG |  | 1600 |  |
| 1916 | 68.4.1 | Iub/Iur interfaces for methods Rel 99 | 233.9d | 2000-04-03 A | 2001-03-30 A | 100% |  | 2000-04-03 | 2001-03-30 | 233.9d |  | finish no earlier than 2001-03-30 | R3 | 1871.2h | 1871.2h | LCS1-UEpos-IubIur |  | Yun-Chao Hu, Ericsson |  | Rel-4 | TSG |  | 1601 |  |
| 1917 | 68.4.2 | UE positioning enhancements - IPDL for TDD | 150d | 2000-08-28 A | 2001-03-23 A | 100% |  | 2000-08-28 | 2001-03-23 | 150d |  | finish no earlier than 2001-03-23 | R2 | 1200h | 1200h | LCS1-UEpos-enh |  | M. Beckmann, Siemens |  | Rel-4 | TSG |  | 1602 |  |

Notes:
- 1893: WI approved in TSG_10 / CN1#15: ID 2101 REMOVE-Emergency call recalling capability enhancement, no contributions
- 1895: Calls to different emergency services such as ambulance, fire brigade, police, etc. can be routed to respective different emergency centres. / NP-000447 is the stage 3 changes for CS call control protocol.
- 1896: UID changed
- 1901: goal not completely achieved because of missing input
- 1902: AS: Rel5 changed to Rel4 according to SA#10 decision, milestone on testing added
- 1907: Only MAP impact foreseen so far. To be further split if needed.
- 1909: To be also considered: External LCS client identity, and Privacy options when PDP-context and when no PDP-context is established
- 1910: AS: 23.271 completed at SA#10
- 1913: Missing work task
- 1915: UID changed
- 1916: 27/11: WG corrected; rapporteur corrected
- 1917: 5 Mar 2001: splitting off of IPDL for TDD for Rel-4 agreed by R2

| ID | WBS | Task | Duration | Start | Finish | Complete | Remaining | Baseline start | Baseline finish | Baseline duration | Total slack | Constraint | Resources | Work | Actual work | Text1 | Text2 | Text6 | Text8 | Text9 | Text3 | Text7 | Text5 |
| --- | --- | --- | --- | --- | --- | --- | --- | --- | --- | --- | --- | --- | --- | --- | --- | --- | --- | --- | --- | --- | --- | --- | --- |
| 1918 | 69 | **Rel-4 UICC/(U)SIM enhancements and interworking** | 175d | 2000-07-24 A | 2001-03-23 A | 100% |  | 2000-07-24 | 2001-03-23 | 175d |  |  | T3 | 2800h | 2800h | UICC1 | Ter | NA | Claus | 1560 |  |  |  |
| 1919 | 69.1 | Common PCN Handset Specification (CPHS) | 175d | 2000-07-24 A | 2001-03-23 A | 100% |  | 2000-07-24 | 2001-03-23 | 175d |  | finish no earlier than 2001-03-23 | T3 | 1400h | 1400h | UICC1-CPHS | Ter | Rel-4 |  | 1799 | 27.103 | TSG |  |
| 1920 | 70 | **Rel-4 (U)SIM toolkit enhancements** | 210d | 2000-06-05 A | 2001-03-23 A | 100% |  | 2000-06-05 | 2001-03-23 | 210d |  |  | T3 | 3360h | 3360h | USAT1 | Ter | NA | Claus | 1800 |  |  |  |
| 1921 | 70.1 | USAT local link | 210d | 2000-06-05 A | 2001-03-23 A | 100% |  | 2000-06-05 | 2001-03-23 | 210d |  | finish no earlier than 2001-03-23 | T3 | 1680h | 1680h | USAT1-LocLnk |  | Rel-4 |  | 2034 |  | TSG |  |
| 1922 | 71 | **Rel-4 Security enhancements** | 575d | 2000-01-03 A | 2002-03-15 | 87% | 74.38d | 2000-01-03 | 2002-03-15 | 575d | 2030d |  | S3 | 24144h | 20865.5h | SEC1 |  | NA | Maurice |  |  | TSG | Peter.Howard@vodafone.com |
| 1923 | 71.1 | Evolution of GSM CS algorithms (e.g. A5/3 development and deployment) | 271d | 2000-01-03 A | 2001-01-15 A | 100% |  | 2000-01-03 | 2001-01-15 | 271d |  | finish no earlier than 2001-01-15 | S3 | 2168h | 2168h | SEC1-CSALGO1 | Sec | Rel-4 |  | 1587 |  | TSG |  |
| 1924 | 71.2 | **Evolution of GSM PS algorithms (e.g. GEA 2 deployment)** | 219d | 2000-02-22 A | 2000-12-22 A | 100% |  | 2000-02-22 | 2000-12-22 | 219d |  |  | S3 | 6024h | 6024h | SEC1-PSALGO1 | Sec | Rel-4 |  | 1588 |  | TSG |  |
| 1925 | 71.2.1 | Main aspects | 199d | 2000-02-22 A | 2000-11-24 A | 100% |  | 2000-02-22 | 2000-11-24 | 199d |  | finish no earlier than 2000-11-24 | S3 | 1592h | 1592h |  | Sec |  |  | 1589 |  |  |  |
| 1926 | 71.2.2 | Impact on GTP | 200d | 2000-03-20 A | 2000-12-22 A | 100% |  | 2000-03-20 | 2000-12-22 | 200d |  | finish no earlier than 2000-12-22 | N4 | 1600h | 1600h |  |  |  |  | 1618 |  | WG |  |
| 1927 | 71.2.3 | GEA capability indication in MS CM | 135d | 2000-06-19 A | 2000-12-22 A | 100% |  | 2000-06-19 | 2000-12-22 | 135d |  | finish no earlier than 2000-12-22 | N1 | 1080h | 1080h | SEC1-PSALGO1-GEACAP | Sec |  |  | 1661 |  |  |  |
| 1928 | 71.3 | **MAP application layer security** | 575d | 2000-01-03 A | 2002-03-15 | 76% | 135.92d | 2000-01-03 | 2002-03-15 | 575d | 2030d |  | S3 | 11352h | 8668.58h | SEC1-MAPAL | Sec | Rel-4 |  |  |  | TSG |  |
| 1929 | 71.3.1 | Main aspects | 199d | 2000-02-21 A | 2001-03-29 A | 100% |  | 2000-02-21 | 2001-03-29 | 199d |  | start no earlier than 2000-02-21 | S3 | 1592h | 1592h |  | Sec |  |  | 1584 |  | WG |  |
| 1930 | 71.3.2 | Other stage 3 aspects | 199d | 2000-02-22 A | 2000-11-24 A | 100% |  | 2000-02-22 | 2000-11-24 | 199d |  | finish no earlier than 2000-11-24 | N4 | 1592h | 1592h |  | Sec |  |  | 2025 |  | TSG |  |
| 1931 | 71.3.3 | CHECK STATUS - Visibility and Configurability of security | 575d | 2000-01-03 A | 2002-03-15 | 60% | 230d | 2000-01-03 | 2002-03-15 | 575d | 2030d | finish no earlier than 2002-03-15 | S3 | 4600h | 2760h | SEC1-VCS | Sec | Rel-5 |  | 1594 |  | TSG | Sebastien.nguyenngoc@rd.francetelecom.com |
| 1932 | 72 | **Rel-4 Charging and OAM&P** | 221d | 2000-12-01 A | 2001-10-05 A | 100% |  | 2000-12-01 | 2001-10-05 | 221d |  |  | S5 | 10472h | 10472h | OAM |  | NA | Adrian |  | 32-series | TSG | Albert.Yuhan@voicestream.com; Michael.Truss@MOTOROLA.COM |
| 1933 | 72.1 | Rel4 Principles, high level Requirements and Architecture | 145d | 2000-12-01 A | 2001-06-21 A | 100% |  | 2000-12-01 | 2001-06-21 | 145d |  | finish no earlier than 2001-06-21 | S5 | 1160h | 1160h | OAM-AR/PR | BCaM | Rel-4 |  | 2089 | 32.101, 32.102 | TSG | Michael.Truss@MOTOROLA.COM; Tommy.R.Berggren@TELIA.SE |
| 1934 | 72.2 | Rel4 Performance Management | 216d | 2000-12-01 A | 2001-09-28 A | 100% |  | 2000-12-01 | 2001-09-28 | 216d |  | finish no earlier than 2001-06-21 | S5 | 1728h | 1728h |  | BCaM | Rel-4 |  | 2088 | 32.4xy, 52.402 | TSG | karl-heinz.nenner@t-mobile.de |
| 1935 | 72.3 | Fault Management | 221d | 2000-12-01 A | 2001-10-05 A | 100% |  | 2000-12-01 | 2001-10-05 | 221d |  | finish no earlier than 2001-06-21 | S5 | 1768h | 1768h |  | BCaM | Rel-4 |  | 2081 | 32.111-1/4 | TSG | pjure@LUCENT.COM |
| 1936 | 72.4 | Configuration Management | 145d | 2000-12-01 A | 2001-06-21 A | 100% |  | 2000-12-01 | 2001-06-21 | 145d |  | finish no earlier than 2001-06-21 | S5 | 1160h | 1160h | OAM-CM | BCaM | Rel-4 |  | 2082 | 32.106-1/8 | TSG | Thomas.Tovinger@emw.ericsson.se |
| 1937 | 72.5 | Rel4 Charging Management | 216d | 2000-12-01 A | 2001-09-28 A | 100% |  | 2000-12-01 | 2001-09-28 | 216d |  | finish no earlier than 2001-06-21 | S5 | 1728h | 1728h | OAM-CH | BCaM | Rel-4 |  | 2083 | 32.2xy (Charging) | TSG | karl-heinz.nenner@t-mobile.de |
| 1938 | 72.6 | UTRAN Operations and Maintenance procedures | 145d | 2000-12-01 A | 2001-06-21 A | 100% |  | 2000-12-01 | 2001-06-21 | 145d |  | finish no earlier than 2001-06-21 | S5 | 1160h | 1160h | UOAM |  | Rel-4 | Adrian | 2071 | 32.800 | TSG | bert.boden@d2mannesmann.de |
| 1939 | 73 | **Global Text Telephony** | 2348d? | 2000-01-03 A | 2008-12-31 | 89% | 249.42d? | 2000-01-03 | 2008-12-31 | 2348d? | 257d |  | S2 | 46352h | 39782.3h | GTT |  | Rel Indep | Alain |  |  | TSG | gunnar.hellstrom@omnitor.se |
| 1940 | 73.1 | Stage 1 | 188d | 2000-06-28 A | 2001-03-16 A | 100% |  | 2000-06-28 | 2001-03-16 | 188d |  | finish no earlier than 2000-12-22 | S1 | 1504h | 1504h |  |  |  |  | 1634 | 22.976, 22.226 | TSG |  |
| 1941 | 73.2 | Stage 2 | 205d | 2000-09-11 A | 2001-06-22 A | 100% |  | 2000-09-11 | 2001-06-22 | 205d |  |  | S2 | 1640h | 1640h |  |  |  |  |  | 23.226 | TSG |  |

Notes:
- 1919: 28/5/2001: CRs approved at TP-11. WI complete. / Text4: ?, One2One
- 1921: 25/5/2001:CR was approved at TP-11. WI is complete / Text4: Jean-Francois Rubon (Gemplus)
- 1922: Added BB UE authentication and rapporteur added. TO BE DELETED / Text4: Peter Howard, Vodafone
- 1923: Algorithm development go-ahead at SA3#21. Scheduled for completion in August 2002?. Approved SA#17. DELETE ENTRY FROM REL-4?
- 1924: A5/3 development will consider new GEA algorithm based on Kasumi.
- 1925: Complete TSG#09 (09/2000). S3#17: Proposed for deletion. TO BE DELETED
- 1927: Text4: Duncan Mills / Vodafone Airtouch
- 1928: TO DELETE: REPLACED BY NDS-MAP and NDS-IP. TO BE DELETED, but replacement NDS-MAP was missing. Completed Auto Key Management -> Rel-6
- 1929: UID changed
- 1930: UID changed
- 1931: CR approved at SA3#21 awaiting comments from CN1. / Text4: Sébastien Nguyen Ngoc, France Telecom
- 1932: az: WID appr.SA#13. / Text4: Albert YUHAN (VoiceStream Wireless), Michael TRUSS (Motorola)
- 1933: Text4: Michael TRUSS (Motorola), Tommy BERGGREN (Telia AB)
- 1934: Changed Rapp email / Text4: Karl-Heinz NENNER (T-Mobile)
- 1935: Text4: Patrick JURÉ (Lucent Technologies)
- 1936: Text4: Thomas TOVINGER (Ericsson)
- 1937: Changed Rapp email / Text4: Karl-Heinz NENNER (T-Mobile)
- 1938: Text4: Bert Boden (Mannesmann Mobilfunk)
- 1939: SP-000162 agreed WI. Rapporteur / Gunnar Hellström, Ericsson Radio Systems AB, / email: gunnar.hellstrom@omnitor.se tel: +46 708 204 288 / Text4: Gunnar Hellström, Ericsson

| ID | WBS | Task | Type | Duration | Start | Finish | Predecessors | Complete | Remaining | Baseline start | Baseline finish | Baseline duration | Total slack | Free slack | Constraint | Resources | Work | Actual work | Text1 | Text9 | Text3 | Text6 | Text8 |
| --- | --- | --- | --- | --- | --- | --- | --- | --- | --- | --- | --- | --- | --- | --- | --- | --- | --- | --- | --- | --- | --- | --- | --- |
| 1942 | 73.3 | **Specification of Cellular Text telephone Modem** |  | 136d | 2000-09-11 A | 2001-03-19 A |  | 100% |  | 2000-09-11 | 2001-03-19 | 136d |  |  |  | S4 | 2704h | 2704h | GTT-CTM | 2234 |  |  |  |
| 1943 | 73.3.1 | General description and C-code |  | 66d | 2000-09-11 A | 2000-12-11 A |  | 100% |  | 2000-09-11 | 2000-12-11 | 66d |  |  | finish no earlier than 2000-12-11 | S4 | 528h | 528h |  | 2238 | 26.226, 26.230 |  |  |
| 1944 | 73.3.2 | Minimum Performance requirements |  | 136d | 2000-09-11 A | 2001-03-19 A |  | 100% |  | 2000-09-11 | 2001-03-19 | 136d |  |  | finish no earlier than 2001-03-19 | S4 | 1088h | 1088h |  | 2237 | 26.231 |  |  |
| 1945 | 73.4 | Start Testing | milestone | 0d | 2002-02-18 | 2002-02-18 |  |  |  | 2002-02-18 | 2002-02-18 | 0d | 1658.2d | 0d | start no earlier than 2002-02-18 | MLST |  |  |  |  |  |  |  |
| 1946 | 73.5 | **Conformance Test Aspects - Global Text telephony** |  | 2348d? | 2000-01-03 A | 2008-12-31 | 1945 | 80% | 469.6d? | 2000-01-03 | 2008-12-31 | 2348d? | 257d |  |  | T1 | 24176h | 19340.8h |  |  | 34.125 |  |  |
| 1947 | 424.5.1 | Small Technical Enhancements and Improvements for Rel-4 Conformance Testing |  | 674d? | 2000-01-03 A | 2008-12-31 |  | 80% | 134.8d? | 2000-01-03 | 2008-12-31 | 674d? | 257d |  | finish no earlier than 2008-12-31 | R5 | 5392h | 4313.6h | TEI4_Test |  |  | Rel-4 | Stoyan Baev |

Notes:
- 1946: Bearer services, new spec document? / This task requires supporting companies before it can start
- 1947: "Joker" WI, to be used for small modifications applicable to Rel 4 conformance testing
